# CH Saintes - Planning EXE (phase1,2,3) du 30.04.2025

Schedule from MS Project, 2025-02-17 to 2027-07-12, 7 hours a day.

## Calendars

- Standard: Mon-Fri 09:00-12:00, 14:00-18:00; Sat-Sun off. Exceptions (off unless hours are given): 2025-05-01, 2025-05-08, 2025-05-29, 2025-07-14, 2025-08-15.

## Schedule

| ID | WBS | Task | Type | Duration | Start | Finish | Predecessors | Total slack | Free slack | Constraint |
| --- | --- | --- | --- | --- | --- | --- | --- | --- | --- | --- |
| 1 | 1 | OS Préparation | milestone | 0d | 2025-02-17 | 2025-02-17 |  | 580d | 0d | start no earlier than 2025-02-17 |
| 2 | 2 | Etudes et préparation chantier |  | 40d | 2025-02-17 | 2025-04-11 | 1 | 580d |  |  |
| 3 | 3 | OS TRAVAUX | milestone | 0d | 2025-04-14 | 2025-04-14 |  | 578d | 0d | start no earlier than 2025-04-14 |
| 4 | 4 | **PHASE 1 : SMUR + RESERVES PROVISOIRES + ACCUEIL PROVISOIRE** |  | 108d? | 2025-04-02 | 2025-09-05 |  | 31d |  |  |
| 5 | 4.1 | **CHANTIER PHASE 01** |  | 102d? | 2025-04-02 | 2025-08-28 |  | 31d |  |  |
| 6 | 4.1.1 | Travaux préparatoires de VRD (provisoire Ambulance) |  | 10d | 2025-05-12 | 2025-05-23 | 50 | 552d |  |  |
| 7 | 4.1.2 | Création emprises chantier |  | 2d | 2025-04-14 | 2025-04-15 | 3 | 578d | 0d |  |
| 8 | 4.1.3 | MàD installation élec, eau de chantier |  | 2d | 2025-04-14 | 2025-04-15 | 7SS | 578d |  |  |
| 9 | 4.1.4 | <Nouvelle tâche> |  | 1d? | 2025-04-02 | 2025-04-02 |  | 587d |  |  |
| 10 | 4.1.5 | **Aménagements accueil provisoire** |  | 19d | 2025-06-02 | 2025-06-26 |  | 530d |  |  |
| 11 | 4.1.5.1 | Création emprises chantier |  | 1d | 2025-06-02 | 2025-06-02 |  | 529d | 0d | start no earlier than 2025-06-02 |
| 12 | 4.1.5.2 | MàD installation élec |  | 1d | 2025-06-03 | 2025-06-03 | 11 | 529d | 0d |  |
| 13 | 4.1.5.3 | Consignation, remaniement/dévoiement rsx élec |  | 2d | 2025-06-04 | 2025-06-05 | 12 | 529d | 0d | start no earlier than 2025-04-16 |
| 14 | 4.1.5.4 | Curage |  | 2d | 2025-06-06 | 2025-06-09 | 13 | 529d | 0d |  |
| 15 | 4.1.5.5 | Remaniement cloisons (yc bandes, enduits) |  | 3d | 2025-06-10 | 2025-06-12 | 14 | 529d | 0d |  |
| 16 | 4.1.5.6 | Reprise faux plafond |  | 2d | 2025-06-13 | 2025-06-16 | 15 | 529d | 0d |  |
| 17 | 4.1.5.7 | Mise en peinture |  | 4d | 2025-06-17 | 2025-06-24 | 16 | 529d | 0d |  |
| 18 | 4.1.5.8 | Reprise du sol (IAO) |  | 2d | 2025-06-19 | 2025-06-20 | 17SS+2d | 533d |  |  |
| 19 | 4.1.5.9 | Pose des rideaux d'intimité |  | 2d | 2025-06-25 | 2025-06-26 | 17 | 529d |  |  |
| 20 | 4.1.6 | **Réaménagement existants (futur vestiaires + réserves)** |  | 67d | 2025-04-14 | 2025-07-21 |  | 23d |  |  |
| 21 | 4.1.6.1 | Consignation & remaniement Rsx élecs, fluides (CVC, Plb) |  | 3d | 2025-04-14 | 2025-04-16 |  | 495d | 0d | start no earlier than 2025-04-14 |
| 22 | 4.1.6.2 | Curage, démolition, enlèvement |  | 10d | 2025-04-17 | 2025-04-30 | 21 | 495d | 0d |  |
| 23 | 4.1.6.3 | traçage des cloisonnement et réservations |  | 1d | 2025-05-05 | 2025-05-05 |  | 565d |  | start no earlier than 2025-05-05 |
| 24 | 4.1.6.4 | Dépose étanchéité en toiture |  | 2d | 2025-05-12 | 2025-05-13 |  | 560d |  | start no earlier than 2025-05-12 |
| 25 | 4.1.6.5 | Création/reprises ouvertures (voiles, toiture) |  | 12d | 2025-05-12 | 2025-05-27 | 22 | 537d | 0d | start no earlier than 2025-05-12 |
| 26 | 4.1.6.6 | Pose des skydomes |  | 2d | 2025-05-28 | 2025-05-30 | 25 | 547d | 0d |  |
| 27 | 4.1.6.7 | Reprises étanchéité et batardeaux |  | 1d | 2025-06-02 | 2025-06-02 | 26 | 547d |  |  |
| 28 | 4.1.6.8 | Pose menuiseries EXT |  | 2d | 2025-05-26 | 2025-05-27 | 25FS-2d | 550d |  |  |
| 29 | 4.1.6.9 | Cloisonnement 1ère peau et doublage (yc bandes) | manual | 15d | 2025-05-19 | 2025-06-09 | 25FS-2d |  |  | start no earlier than 2025-05-19 |
| 30 | 4.1.6.10 | Pose menuiserie INT (bâtis, châssis) |  | 5d | 2025-05-19 | 2025-05-23 | 29SS | 552d |  |  |
| 31 | 4.1.6.11 | Pose réseaux fluides (CVC, Plb) |  | 10d | 2025-05-26 | 2025-06-09 | 29SS+5d | 542d |  |  |
| 32 | 4.1.6.12 | Cheminement réseaux élec (Cfo,Cfa, SSI) | manual | 5d | 2025-05-19 | 2025-05-23 | 29SS+5d |  |  | start no earlier than 2025-05-19 |
| 33 | 4.1.6.13 | Passage de câbles |  | 10d | 2025-05-26 | 2025-06-09 | 32SS+5d | 513d | 0d |  |
| 34 | 4.1.6.14 | Bon à fermer (cloisons + faux plafond) | manual | 1d | 2025-05-28 | 2025-05-28 | 33FS-5d |  |  | start no earlier than 2025-05-28 |
| 35 | 4.1.6.15 | 2nd peau (+ bandes) + préparation à la peinture |  | 7d | 2025-05-30 | 2025-06-09 | 34 | 516d | 0d |  |
| 36 | 4.1.6.16 | Bon à calfeutrer |  | 3d | 2025-06-06 | 2025-06-10 | 35FS-2d | 516d | 0d |  |
| 37 | 4.1.6.17 | Peinture 1ère couche |  | 8d | 2025-06-11 | 2025-06-20 | 36 | 516d | 0d |  |
| 38 | 4.1.6.18 | Structure faux plafond |  | 5d | 2025-06-19 | 2025-06-25 | 37FS-2d | 516d | 0d |  |
| 39 | 4.1.6.19 | Pose terminaux CVC |  | 4d | 2025-06-26 | 2025-07-01 | 38 | 518d | 0d |  |
| 40 | 4.1.6.20 | Pose terminaux élec (PC, éclairages, interupt, Arrêt d'urgence) |  | 4d | 2025-06-26 | 2025-07-01 | 38 | 516d | 18d |  |
| 41 | 4.1.6.21 | Mise en peinture finitions |  | 5d | 2025-06-26 | 2025-07-02 | 38 | 520d | 7d |  |
| 42 | 4.1.6.22 | Pose des ouvrants et protection portes |  | 3d | 2025-06-26 | 2025-06-30 | 38 | 527d |  |  |
| 43 | 4.1.6.23 | Revêtements de sol et douches |  | 5d | 2025-07-02 | 2025-07-08 | 39 | 518d | 0d |  |
| 44 | 4.1.6.24 | Pose mobilier, mains courantes |  | 5d | 2025-07-07 | 2025-07-11 | 43FS-2d | 518d |  |  |
| 45 | 4.1.6.25 | blanchir faux plafond |  | 2d | 2025-07-09 | 2025-07-10 | 43 | 519d |  |  |
| 46 | 4.1.6.26 | Pose équipements sanitaires |  | 3d | 2025-07-09 | 2025-07-11 | 43 | 518d |  |  |
| 47 | 4.1.6.27 | nettoyage |  | 5d | 2025-07-15 | 2025-07-21 | 41 | 513d |  | start no earlier than 2025-07-15 |

| ID | WBS | Task | Duration | Start | Finish | Predecessors | Total slack | Free slack | Constraint |
| --- | --- | --- | --- | --- | --- | --- | --- | --- | --- |
| 48 | 4.1.7 | **Création extension garage SMUR** | 94d? | 2025-04-14 | 2025-08-28 |  | 48d |  |  |
| 49 | 4.1.7.1 | Démolition des aménagements EXT (yc évacuation) | 3d | 2025-04-28 | 2025-04-30 |  | 567d |  | start no earlier than 2025-04-28 |
| 50 | 4.1.7.2 | Décapage et terrassement | 5d | 2025-05-02 | 2025-05-09 | 22 | 495d | 0d |  |
| 51 | 4.1.7.3 | Délai appro: Aciers 3 semaines + prefa 2 sem | 25d | 2025-04-14 | 2025-05-20 | 52SF | 555d |  | start no earlier than 2025-04-14 |
| 52 | 4.1.7.4 | Terrassement, Fondations | 10d | 2025-05-12 | 2025-05-23 | 50 | 495d | 0d |  |
| 53 | 4.1.7.5 | Pose prémur / poteaux / poutres | 9d | 2025-05-26 | 2025-06-06 | 52 | 495d | 0d | finish no earlier than 2025-06-06 |
| 54 | 4.1.7.6 | Plancher dalle alvéolée et acrotères | 10d | 2025-06-09 | 2025-06-20 | 53 | 495d | 0d | finish no earlier than 2025-06-20 |
| 55 | 4.1.7.7 | Pose garde corps en toiture | 3d | 2025-06-23 | 2025-06-25 | 54 | 530d |  | start no earlier than 2025-06-20 |
| 56 | 4.1.7.8 | Dalle portée, réseaux et isolant | 9d | 2025-06-18 | 2025-06-30 | 52FS-1d | 527d |  | start no earlier than 2025-06-18 |
| 57 | 4.1.7.9 | Temps de séchage dalle RDC | 15d | 2025-06-30 | 2025-07-21 |  | 513d |  | finish no earlier than 2025-07-21 |
| 58 | 4.1.7.10 | Désétaiement (prévoir passage lots tech) + finitions | 5d | 2025-07-03 | 2025-07-09 | 54FS+8d | 520d |  |  |
| 59 | 4.1.7.11 | Etanchéité, couverture | 5d | 2025-07-10 | 2025-07-17 | 54FS+13d | 495d | 0d |  |
| 60 | 4.1.7.12 | Pose portes sectionnelles et support lamelles | 5d | 2025-08-06 | 2025-08-12 | 63SS+5d | 497d |  |  |
| 61 | 4.1.7.13 | Pose bâti menuiseries EXT | 2d | 2025-07-18 | 2025-07-21 | 59 | 513d |  |  |
| 62 | 4.1.7.14 | Pose réseaux Fluides (CVC, Plb) | 10d | 2025-07-30 | 2025-08-12 | 69 | 497d |  |  |
| 63 | 4.1.7.15 | Création cheminement électrique (Cfo, Cfa, SSI) | 3d | 2025-07-30 | 2025-08-01 | 69 | 495d | 0d |  |
| 64 | 4.1.7.16 | Passage de câbles (Cfo, Cfa, SSI) | 3d | 2025-08-01 | 2025-08-05 | 63FS-1d | 495d | 0d |  |
| 65 | 4.1.7.17 | Cloisonnement y compris pose portes | 5d | 2025-07-16 | 2025-07-22 | 59FS-2d | 495d | 0d |  |
| 66 | 4.1.7.18 | Accompagnement lots élec, fluides (passage rsx dans les cloisons) | 3d | 2025-07-18 | 2025-07-22 | 68SS | 512d |  |  |
| 67 | 4.1.7.19 | Bon à fermer | 1d | 2025-07-18 | 2025-07-18 |  | 514d |  | start no earlier than 2025-07-18 |
| 68 | 4.1.7.20 | grutage et installation équipements terrasse | 10d | 2025-07-18 | 2025-07-31 | 59 | 505d | 0d |  |
| 69 | 4.1.7.21 | Peintures | 5d | 2025-07-23 | 2025-07-29 | 65 | 495d | 0d |  |
| 70 | 4.1.7.22 | plan de travail, paillasse | 2d | 2025-08-06 | 2025-08-07 | 64 | 500d |  |  |
| 71 | 4.1.7.23 | Terminaux élec, CVC | 4d | 2025-08-06 | 2025-08-11 | 64 | 495d | 0d |  |
| 72 | 4.1.7.24 | Peinture de sol & finitions | 3d | 2025-08-12 | 2025-08-14 | 71 | 495d |  |  |
| 73 | 4.1.7.25 | Essais NRBC | 4d | 2025-08-25 | 2025-08-28 |  | 486d |  | finish no earlier than 2025-08-28 |
| 74 | 4.1.7.26 | Enrobés (cis préparation, bordures, finitions) | 5d | 2025-07-21 | 2025-07-25 | 68SS+1d | 509d |  |  |

| ID | WBS | Task | Duration | Start | Finish | Predecessors | Total slack | Free slack | Constraint | Text1 |
| --- | --- | --- | --- | --- | --- | --- | --- | --- | --- | --- |
| 75 | 4.1.7.27 | **Aménagements extérieures** | 3d | 2025-07-15 | 2025-07-17 |  |  |  |  |  |
| 76 | 4.1.7.27.1 | Tranchés pour le paratonerre | 1d | 2025-07-15 | 2025-07-15 |  | 517d |  |  |  |
| 77 | 4.1.7.27.2 | Mise à la terre (date d'intervention à caler avec france tonerre) | 1d | 2025-07-15 | 2025-07-15 |  | 517d |  |  |  |
| 78 | 4.1.7.27.3 | Reemblaiement | 1d | 2025-07-16 | 2025-07-16 |  | 516d |  | start no earlier than 2025-07-16 |  |
| 79 | 4.1.7.28 | **Parking** | 27d? | 2025-06-24 | 2025-07-31 |  |  |  |  |  |
| 80 | 4.1.7.28.1 | **création local cuve NRBC** | 22d | 2025-06-24 | 2025-07-24 |  | 511d |  |  |  |
| 81 | 4.1.7.28.1.1 | Balisage des places de pkg et passage des réseaux (elec, plb) | 10d | 2025-06-24 | 2025-07-07 |  | 522d |  | finish no earlier than 2025-06-06 |  |
| 82 | 4.1.7.28.1.2 | pose porte d'accès | 2d | 2025-07-01 | 2025-07-02 |  | 525d |  | start no earlier than 2025-07-01 |  |
| 83 | 4.1.7.28.1.3 | cloisonnement yc bandes | 2d | 2025-07-02 | 2025-07-03 |  | 510d | 0d | start no earlier than 2025-07-02 |  |
| 84 | 4.1.7.28.1.4 | peinture murs et sols | 5d | 2025-07-04 | 2025-07-10 | 83 | 510d | 0d |  |  |
| 85 | 4.1.7.28.1.5 | Livraison cuve, séparateur hydrocarbure, pompe de relevage | 1d | 2025-07-11 | 2025-07-11 | 84 | 510d | 0d |  |  |
| 86 | 4.1.7.28.1.6 | passage câbles et pose équipements élec | 4d | 2025-07-11 | 2025-07-17 | 84 | 515d |  | start no earlier than 2025-07-10 |  |
| 87 | 4.1.7.28.1.7 | Installation matériel + raccordement | 8d | 2025-07-15 | 2025-07-24 | 85 | 510d |  |  |  |
| 88 | 4.2 | **OPR Phase 01** | 8d | 2025-08-05 | 2025-08-14 |  |  |  |  |  |
| 89 | 4.2.1 | Remise en état pour ouverture du service | 1d | 2025-08-13 | 2025-08-13 |  | 495d | 0d | start no earlier than 2025-08-13 |  |
| 90 | 4.2.2 | Dépose de cloisonnement provisoire | 1d | 2025-08-14 | 2025-08-14 | 89 | 495d |  |  |  |
| 91 | 4.2.3 | Essais et mise en service | 5d | 2025-08-05 | 2025-08-11 | 40FS+5d | 498d |  |  |  |
| 92 | 4.3 | OPR Zone vestiaires | 1d | 2025-07-31 | 2025-07-31 |  | 505d |  | start no earlier than 2025-07-31 |  |
| 93 | 4.4 | OPR Garage SMUR | 1d | 2025-08-14 | 2025-08-14 |  | 495d |  | start no earlier than 2025-08-14 |  |
| 94 | 4.5 | Levée de réserves phase 1 | 5d | 2025-08-22 | 2025-08-28 |  | 486d |  | finish no earlier than 2025-08-28 |  |
| 95 | 4.6 | Réception phase 1 | 1d | 2025-08-29 | 2025-08-29 |  | 478d | 0d | start no earlier than 2025-08-29 |  |
| 96 | 4.7 | **Emménagement phase 01** | 5d | 2025-09-01 | 2025-09-05 |  | 479d |  |  |  |
| 97 | 4.7.1 | Déménagement du SMUR / NRBC et réserve (installations fonctionnelles) | 1w | 2025-09-01 | 2025-09-05 | 95 | 478d | 28d |  |  |
| 98 | 5 | **PHASE 2 : DEMOLITION SMUR ET ACCUEIL EXISTANT** | 43d | 2025-10-15 | 2025-12-12 |  | 268d |  |  |  |
| 99 | 5.1 | Isolement de la zone concernée | 2d | 2025-10-16 | 2025-10-17 |  | 451d |  | start no earlier than 2025-10-16 | PREMYSS |
| 100 | 5.2 | Consignation des réseaux de la zone | 2d | 2025-10-16 | 2025-10-17 | 97 | 451d |  | start no earlier than 2025-10-16 | SPIE/SAITA |
| 101 | 5.3 | Démolition du bâtiment SMUR, Réserve, Accueil, etc | 11d | 2025-10-15 | 2025-10-29 |  | 268d | 0d | start no earlier than 2025-10-15 | PREMYS |
| 102 | 5.4 | Dévoiement réseaux vide sanitaire sous PCSI actuel | 10d | 2025-11-03 | 2025-11-14 |  | 411d | 0d | start no earlier than 2025-11-03 | SPIE/SAITA |
| 103 | 5.5 | construction local SSI en vide sanitaire | 20d | 2025-11-17 | 2025-12-12 | 102 | 411d |  | start no earlier than 2025-08-25 | ALM |

| ID | WBS | Task | Duration | Start | Finish | Predecessors | Total slack | Free slack | Constraint | Text1 |
| --- | --- | --- | --- | --- | --- | --- | --- | --- | --- | --- |
| 104 | 6 | **PHASE 3 : IOA + CHAMBRES R+1 + SAS AMBULANCE** | 203d | 2025-10-13 | 2026-07-22 |  | 253d |  |  |  |
| 105 | 6.1 | **Installation chantier** | 145d | 2025-10-13 | 2026-05-01 |  | 311d |  |  |  |
| 106 | 6.1.1 | Isolement de la zone concernée | 1d | 2025-10-13 | 2025-10-13 |  | 455d |  | start no earlier than 2025-10-13 | PREMYSS |
| 107 | 6.1.2 | Sécurisation de la zone en limite avec le SMUR | 1d | 2025-10-15 | 2025-10-15 | 101SS | 453d |  | start no earlier than 2025-09-16 | PREMYSS |
| 108 | 6.1.3 | Fondation grue | 3d | 2025-11-07 | 2025-11-12 | 109SF-3d | 434d |  | start no earlier than 2025-11-04 | ALM |
| 109 | 6.1.4 | Montage grue | 2d | 2025-11-17 | 2025-11-18 | 114FS+2d | 429d | 0d | start no earlier than 2025-11-13 | ALM |
| 110 | 6.1.5 | Démontage grue | 2d | 2026-04-30 | 2026-05-01 | 266 | 311d |  | start no earlier than 2026-02-23 | ALM |
| 111 | 6.2 | **IOA + chambres R+1** | 197d | 2025-10-21 | 2026-07-22 |  | 253d |  |  |  |
| 112 | 6.2.1 | **Construction du bâtiment IOA** | 124d | 2025-10-21 | 2026-04-10 |  | 275d |  |  |  |
| 113 | 6.2.1.1 | Implantation Projet | 1d | 2025-10-30 | 2025-10-30 | 114SS | 442d |  |  | ALM/EIFFAGE |
| 114 | 6.2.1.2 | Préparation plateforme (décapage et terrassement) | 10d | 2025-10-30 | 2025-11-12 | 101 | 268d | 0d |  | EIFFAGE |
| 115 | 6.2.1.3 | Délai Appro : Aciers 3 Semaines + Prefa 2 Semaines | 25d | 2025-10-21 | 2025-11-25 | 116SF-4d | 425d |  |  | ALM |
| 116 | 6.2.1.4 | Terassement / Gros Béton / Semelles | 12d | 2025-12-01 | 2025-12-16 | 114FS+12d | 268d | 0d |  | EIFFAGE/ALM |
| 117 | 6.2.1.5 | Elevations Sous Sol | 12d | 2025-12-11 | 2025-12-26 | 116FS-4d | 268d | 0d |  | ALM |
| 118 | 6.2.1.6 | Plancher Prédalles Ht VS | 10d | 2025-12-22 | 2026-01-02 | 117FS-5d | 268d | 0d |  | ALM |
| 119 | 6.2.1.7 | Création tranchée VS vers /s sol existant | 15d | 2025-12-01 | 2025-12-19 | 114FS+12d | 406d |  |  | ALM |
| 120 | 6.2.1.8 | Désétaiement Prédalle Haut VS + Finition | 20d | 2026-02-09 | 2026-03-06 |  | 351d |  | start no earlier than 2026-02-09 | ALM |
| 121 | 6.2.1.9 | Réalisation Plan Prémur | 11d | 2025-12-02 | 2025-12-17 | 122SF | 409d |  | start no earlier than 2025-10-17 | ALM |
| 122 | 6.2.1.10 | Fabrication Prémur | 18d | 2025-12-17 | 2026-01-12 | 123SF | 391d | 0d |  | ALM |
| 123 | 6.2.1.11 | Elevation RDC | 19d | 2026-01-12 | 2026-02-05 | 118FS+5d | 268d | 0d | start no earlier than 2026-01-05 | ALM |
| 124 | 6.2.1.12 | **TRAVAUX ZONE ESCALIER** | 38d | 2026-01-26 | 2026-03-18 |  | 343d |  |  |  |
| 125 | 6.2.1.12.1 | Consignation | 1d | 2026-01-26 | 2026-01-26 | 123SS+5d | 344d | 0d | start no earlier than 2026-01-26 | SAITA/ALS |
| 126 | 6.2.1.12.2 | Dépose du coffre | 1d | 2026-01-26 | 2026-01-26 | 125SS | 344d | 0d |  | PREMYS |
| 127 | 6.2.1.12.3 | Création de la parois séparative (provisoire) | 1d | 2026-01-26 | 2026-01-26 | 126SS | 344d | 0d |  | PREMYS |
| 128 | 6.2.1.12.4 | Dépose de la porte automatique existante | 1d | 2026-01-26 | 2026-01-26 | 127SS | 344d | 0d |  | PREMYS |

| ID | WBS | Task | Duration | Start | Finish | Predecessors | Total slack | Free slack | Constraint | Text1 |
| --- | --- | --- | --- | --- | --- | --- | --- | --- | --- | --- |
| 129 | 6.2.1.12.5 | **Ouverture du mur existant pour l'escalier, cpris sciage et reprise en sous oeuvre** | 6d | 2026-01-27 | 2026-02-03 | 128 | 344d | 0d |  | ALM ALLAIN |
| 130 | 6.2.1.12.5.1 | Sciage partiel du mur | 3d | 2026-01-27 | 2026-01-29 |  | 344d | 0d |  | ALM ALLAIN |
| 131 | 6.2.1.12.5.2 | Reprise en sous-oeuvre | 4d | 2026-01-29 | 2026-02-03 | 130FS-1d | 344d |  |  | ALM ALLAIN |
| 132 | 6.2.1.12.6 | Agrandissement ancienne ouverture, cpris sciage et reprise des tableaux | 4d | 2026-01-29 | 2026-02-03 | 129SS+2d | 374d | 0d |  | ALM ALLAIN |
| 133 | 6.2.1.12.7 | Consignation | 1d | 2026-01-29 | 2026-01-29 | 132SS | 376d | 7d |  | SPIE |
| 134 | 6.2.1.12.8 | Consignation des 3 luminaires sur phase 02 | 1d | 2026-02-10 | 2026-02-10 | 133 | 369d |  | start no earlier than 2026-02-10 | SPIE |
| 135 | 6.2.1.12.9 | Changement de la parois séparative provisoire | 2d | 2026-02-04 | 2026-02-10 | 129 | 344d | 0d |  | PREMYS |
| 136 | 6.2.1.12.10 | Reprise des cloisons sur phase 01 suite curage trop fort PREMYS | 2d | 2026-02-04 | 2026-02-05 | 135SS | 372d |  |  | GOURAUD |
| 137 | 6.2.1.12.11 | Dépose partiel du faux plafond au droit de l'exécution | 1d | 2026-02-05 | 2026-02-05 | 135SS+1d | 344d | 0d |  | PREMYS |
| 138 | 6.2.1.12.12 | Curage du doublage existant | 1d | 2026-02-06 | 2026-02-06 | 137 | 344d | 0d |  | PREMYS |
| 139 | 6.2.1.12.13 | Dépose des menuiseries extérieur existante | 1d | 2026-02-06 | 2026-02-06 | 138SS | 344d | 0d |  | PREMYS |
| 140 | 6.2.1.12.14 | Curage des plinthe | 1d | 2026-02-06 | 2026-02-06 | 138SS | 369d | 0d |  | PREMYS |
| 141 | 6.2.1.12.15 | Curage du revêtement de sol existant | 2d | 2026-02-09 | 2026-02-10 | 140 | 369d |  |  | PREMYS |
| 142 | 6.2.1.12.16 | Rebouchage des baies de menuiseries en parpaing | 2d | 2026-02-09 | 2026-02-10 | 139 | 344d | 1d |  | ALM ALLAIN |
| 143 | 6.2.1.12.17 | Pose de l'escalier préfabriqué | 4d | 2026-02-11 | 2026-02-16 | 142SS+1d | 343d | 0d | start no earlier than 2026-02-11 | ALM ALLAIN |
| 144 | 6.2.1.12.18 | Dépose de la parois séparative | 1d | 2026-02-16 | 2026-02-16 | 143FF | 343d | 0d |  | PREMYS |
| 145 | 6.2.1.12.19 | Exécution des cloisons définitives, cpris reprise des raccords | 3d | 2026-02-16 | 2026-02-18 | 144SS | 343d | 0d |  | GOURAUD |
| 146 | 6.2.1.12.20 | Mise en peinture cloison face urgences | 3d | 2026-02-19 | 2026-02-23 | 145 | 360d |  |  | LPP |
| 147 | 6.2.1.12.21 | Préparation des supports et reprise chape | 2d | 2026-02-19 | 2026-02-20 | 145 | 343d | 0d |  | LPP |
| 148 | 6.2.1.12.22 | Temps de séchage chape | 15d | 2026-02-23 | 2026-03-13 | 147 | 343d | 0d |  |  |
| 149 | 6.2.1.12.23 | Ragréage (cprs temps de séchage) | 2d | 2026-03-16 | 2026-03-17 | 148 | 343d | 0d |  | LPP |
| 150 | 6.2.1.12.24 | Ravalement des façades intérieur | 3d | 2026-03-02 | 2026-03-04 | 148SS+5d | 353d |  |  | LPP |
| 151 | 6.2.1.12.25 | Pose du revêtement | 1d | 2026-03-18 | 2026-03-18 | 149 | 343d |  |  | LPP |
| 152 | 6.2.1.13 | Etanchéité soubassement | 3d | 2026-02-03 | 2026-02-05 | 123FF | 372d |  |  | ER PEINT |
| 153 | 6.2.1.14 | Plancher Prédalle Haut RDC | 10d | 2026-02-02 | 2026-02-20 | 123FS-4d | 268d | 0d |  | ALM |
| 154 | 6.2.1.15 | Désétaiement prédalles côté RDC + Finition | 20d | 2026-03-16 | 2026-04-10 | 153FS+15d | 326d |  |  | ALM |
| 155 | 6.2.1.16 | Acrotère Béton Haut RDC | 9d | 2026-01-26 | 2026-02-05 | 123FF | 372d |  | start no earlier than 2025-12-12 | ALM |
| 156 | 6.2.1.17 | Elevation R+1 | 10d | 2026-02-23 | 2026-03-06 | 153 | 268d | 0d | start no earlier than 2026-01-05 | ALM |
| 157 | 6.2.1.18 | Plancher Prédalle Haut R+1 | 5d | 2026-03-05 | 2026-03-11 | 156FS-2d | 268d | 0d |  | ALM |
| 158 | 6.2.1.19 | Délais de séchage de la dalle | 10d | 2026-03-12 | 2026-03-25 | 157 | 338d |  |  | ALM ALLAIN |
| 159 | 6.2.1.20 | Désétaiement prédalles côté R+1 + Finition | 10d | 2026-03-26 | 2026-04-08 | 157FS+10d | 328d |  |  | ALM |
| 160 | 6.2.1.21 | Acrotère Béton Haut R+1 | 10d | 2026-03-10 | 2026-03-23 | 157FS-2d | 268d | 0d |  | ALM |
| 161 | 6.2.1.22 | Délais de séchage des acrotères | 10d | 2026-03-24 | 2026-04-06 | 160 | 319d | 0d |  | ALM ALLAIN |
| 162 | 6.2.1.23 | Socles et Souches Toitures | 4d | 2026-03-18 | 2026-03-23 | 160FF | 268d | 0d |  | ALM |

| ID | WBS | Task | Duration | Start | Finish | Predecessors | Total slack | Free slack | Constraint | Text1 |
| --- | --- | --- | --- | --- | --- | --- | --- | --- | --- | --- |
| 163 | 6.2.2 | **Pose charpente métallique pole gériatrie** | 23d | 2026-03-20 | 2026-04-21 |  | 253d |  |  |  |
| 164 | 6.2.2.1 | Pose de la structure métallique (implantation, appro et montage) | 7d | 2026-03-20 | 2026-03-30 |  | 253d | 0d | start no earlier than 2026-03-20 | BARAN |
| 165 | 6.2.2.2 | Etanchéité | 6d | 2026-03-31 | 2026-04-07 | 164 | 253d | 0d |  | SMAC |
| 166 | 6.2.2.3 | Pose du bardage double peau | 8d | 2026-04-08 | 2026-04-17 | 165 | 314d | 0d |  | SMAC |
| 167 | 6.2.2.4 | Peinture intumescente de la charpente principal | 2d | 2026-04-20 | 2026-04-21 | 166 | 319d |  |  | BARAN |
| 168 | 6.2.3 | **Couverture et étanchéité (hors d'eau / hors d'air)** | 67d | 2026-03-24 | 2026-06-24 |  | 264d |  |  |  |
| 169 | 6.2.3.1 | étanchéité RDC + pose gravillons | 15d | 2026-03-24 | 2026-04-13 | 161SS | 319d | 45d |  | EXETANCH |
| 170 | 6.2.3.2 | étanchéité R+1 | 15d | 2026-04-08 | 2026-04-28 | 165 | 253d | 0d |  | EXETANCH |
| 171 | 6.2.3.3 | Pose des menuiseries extérieures | 15d | 2026-03-24 | 2026-04-13 | 162 | 268d | 0d |  | GEAY MEN |
| 172 | 6.2.3.4 | Installation échafaudage | 5d | 2026-04-14 | 2026-04-20 | 171 | 268d | 0d |  | ER PEINT |
| 173 | 6.2.3.5 | Pose complexe ITE (profilés, fixations, isolation) yc enduit de façade et finitions | 40d | 2026-04-21 | 2026-06-15 | 172 | 268d | 0d |  | ER PEINT |
| 174 | 6.2.3.6 | Prise de côte pour mise en fabrication (compris délais d'approvisionnement) | 11d | 2026-06-01 | 2026-06-15 | 173FF | 280d |  |  | EXETANCH |
| 175 | 6.2.3.7 | Couvetine accrotère bas (RDC) | 2d | 2026-06-16 | 2026-06-17 | 169, 173 | 274d | 1d |  | EXETANCH |
| 176 | 6.2.3.8 | Couvertine accrotèbe haut (R+1) | 3d | 2026-06-16 | 2026-06-18 | 173, 170 | 273d | 0d |  | EXETANCH |
| 177 | 6.2.3.9 | Pose gravillon neuf + cheminement technique | 4d | 2026-06-19 | 2026-06-24 | 175, 176 | 273d |  |  | EXETANCH |
| 178 | 6.2.4 | **Travaux Partie Existante** | 78d | 2026-01-28 | 2026-05-15 |  | 301d |  |  |  |
| 179 | 6.2.4.1 | **Recalage Changement fenêtre R+2** | 14d | 2026-02-23 | 2026-03-12 |  | 347d |  |  |  |
| 180 | 6.2.4.1.1 | Cloison OSB R+2 | 1d | 2026-02-23 | 2026-02-23 |  | 352d | 0d | start no earlier than 2026-02-23 | ALM |
| 181 | 6.2.4.1.2 | Dépose fenêtre R+2 | 1d | 2026-02-24 | 2026-02-24 | 180 | 352d | 0d | start no earlier than 2026-02-11 | GEAY MEN |
| 182 | 6.2.4.1.3 | Montage de l'allège avec rejingot compris décoffrage | 2d | 2026-02-25 | 2026-02-26 | 181 | 352d | 0d | start no earlier than 2026-02-12 | ALM |
| 183 | 6.2.4.1.4 | Pose menuiserie R+2 | 1d | 2026-02-27 | 2026-02-27 | 182 | 352d | 0d | start no earlier than 2026-02-16 | GEAY MEN |
| 184 | 6.2.4.1.5 | Enduit monocouche | 1d | 2026-03-02 | 2026-03-02 | 183 | 355d |  |  | ALM |
| 185 | 6.2.4.1.6 | Platrerie | 1d | 2026-03-05 | 2026-03-05 | 183 | 348d | 0d | start no earlier than 2026-03-05 | GOURAUD |
| 186 | 6.2.4.1.7 | Exécution des bandes | 1d | 2026-03-06 | 2026-03-06 | 185 | 348d | 1d |  | GOURAUD |
| 187 | 6.2.4.1.8 | Peinture | 1d | 2026-03-10 | 2026-03-10 | 186 | 347d | 0d | start no earlier than 2026-03-10 | LPP |
| 188 | 6.2.4.1.9 | Plinthe PVC | 1d | 2026-03-11 | 2026-03-11 | 187 | 347d | 0d |  | LPP |
| 189 | 6.2.4.1.10 | Nettoyage de la zone | 1d | 2026-03-11 | 2026-03-11 | 188FF, 179FF | 347d | 0d |  | LPP |
| 190 | 6.2.4.1.11 | Décloisonnement | 1d | 2026-03-12 | 2026-03-12 | 189 | 347d |  |  | ALM |
| 191 | 6.2.4.2 | Préparation étanchéité (provisoire) | 4d | 2026-03-03 | 2026-03-06 |  | 345d | 2d | start no earlier than 2026-03-03 | EXETANCHE |
| 192 | 6.2.4.3 | Approvisionnement des fers | 30d | 2026-01-28 | 2026-03-11 | 193SF | 349d |  |  | ALM |
| 193 | 6.2.4.4 | Pose des fers métal | 3d | 2026-03-11 | 2026-03-13 | 191 | 343d | 0d | start no earlier than 2026-03-11 | ALM |
| 194 | 6.2.4.5 | Renforts plats carbone (R+1) | 3d | 2026-03-16 | 2026-03-18 | 193 | 343d |  | start no earlier than 2026-03-16 | ALM |
| 195 | 6.2.4.6 | Renforts plats carbone (RDC) | 4d | 2026-05-04 | 2026-05-07 |  | 301d | 0d | start no earlier than 2026-05-04 | ALM |
| 196 | 6.2.4.7 | Démontages des châssis + pose plexis | 4d | 2026-05-04 | 2026-05-07 | 195SS | 307d |  |  | GEAY MEN |
| 197 | 6.2.4.8 | Cloison chantier côté service | 1d | 2026-05-08 | 2026-05-08 | 195 | 301d | 0d |  | PREMYS |
| 198 | 6.2.4.9 | Ouverture Voile Béton Issue de Secours | 5d | 2026-05-11 | 2026-05-15 | 197 | 301d |  |  | ALM |

| ID | WBS | Task | Duration | Start | Finish | Predecessors | Total slack | Free slack | Constraint | Text1 |
| --- | --- | --- | --- | --- | --- | --- | --- | --- | --- | --- |
| 199 | 6.2.5 | **Aménagements intérieurs** | 92d | 2026-03-16 | 2026-07-21 |  | 254d |  |  |  |
| 200 | 6.2.5.1 | **Vide sanitaire** | 37d | 2026-03-16 | 2026-05-05 |  | 309d |  |  |  |
| 201 | 6.2.5.1.1 | Pose Fibralith | 10d | 2026-03-16 | 2026-03-27 | 153 | 309d | 0d | start no earlier than 2026-03-16 | ALM |
| 202 | 6.2.5.1.2 | Pose réseaux VS (EU,EV, Chauffage, calo) | 20d | 2026-03-25 | 2026-04-21 | 201FS-3d | 309d | 0d |  | SAITA |
| 203 | 6.2.5.1.3 | Cheminement de câble + éclairage | 10d | 2026-03-25 | 2026-04-07 | 202SS | 329d |  |  | SPIE |
| 204 | 6.2.5.1.4 | Descente EP + raccordement | 10d | 2026-03-30 | 2026-04-10 | 201 | 316d | 0d |  | SAITA |
| 205 | 6.2.5.1.5 | Descente EU | 10d | 2026-03-30 | 2026-04-10 | 204SS | 326d |  |  | SAITA |
| 206 | 6.2.5.1.6 | Mise en place tige de fixation | 2d | 2026-04-20 | 2026-04-22 | 207SF | 319d |  |  |  |
| 207 | 6.2.5.1.7 | Flocage | 5d | 2026-04-22 | 2026-04-28 | 202 | 309d | 0d | start no earlier than 2026-04-09 | ALM |
| 208 | 6.2.5.1.8 | Raccordement EU | 5d | 2026-04-29 | 2026-05-05 | 207 | 309d |  |  | SAITA |
| 209 | 6.2.5.2 | **Chambres R+1 et gériatrie** | 57d | 2026-04-13 | 2026-06-30 |  | 257d |  |  |  |
| 210 | 6.2.5.2.1 | Descente EP / EU | 10d | 2026-04-13 | 2026-04-24 | 204 | 316d | 0d |  | SAITA |
| 211 | 6.2.5.2.2 | Traçage du cloisonnement | 1d | 2026-04-17 | 2026-04-17 | 170FF-7d | 253d | 0d | start no earlier than 2026-03-02 | GOURAUD |
| 212 | 6.2.5.2.3 | Plafond coupe feu structure métallique | 4d | 2026-04-17 | 2026-04-22 | 211SS | 318d |  |  | GOURAUD |
| 213 | 6.2.5.2.4 | Cloisonnement 1ère peau et doublage yc bandes | 10d | 2026-04-22 | 2026-05-05 | 211, 170FS-5d | 294d | 0d |  | GOURAUD |
| 214 | 6.2.5.2.5 | Pose menuiseries int (bâti) | 6d | 2026-04-24 | 2026-05-01 | 213FS-8d | 311d |  |  | FGV |
| 215 | 6.2.5.2.6 | Distributions des réseaux plomberies et aérauliques | 20d | 2026-04-20 | 2026-05-15 | 211 | 301d |  |  | SAITA |
| 216 | 6.2.5.2.7 | Distributions des réseaux élec (CFO/CFA/SSI/DI) | 20d | 2026-04-20 | 2026-05-15 | 211 | 253d | 0d |  | SPIE |
| 217 | 6.2.5.2.8 | Bon à fermer | 1d | 2026-05-11 | 2026-05-11 | 216FS-5d | 269d | 0d |  | SPIE/SAITA |
| 218 | 6.2.5.2.9 | Cloisonnement 2ème peau yc bandes | 9d | 2026-05-12 | 2026-05-22 | 217SS+1d | 269d | 0d |  | GOURAUD |
| 219 | 6.2.5.2.10 | Préparation peinture et 1ère couche | 10d | 2026-05-21 | 2026-06-03 | 218FS-2d | 269d | 0d |  | LPP |
| 220 | 6.2.5.2.11 | Accompagnement pose réseaux en apparent | 11d | 2026-05-25 | 2026-06-08 | 219SS+2d | 285d |  |  | SPIE/SAITA |
| 221 | 6.2.5.2.12 | Pose FP (rails plafonds ) | 5d | 2026-06-02 | 2026-06-08 | 219FS-2d | 285d | 0d | start no earlier than 2026-05-25 | FGV |
| 222 | 6.2.5.2.13 | Acccompagnement terminaux plénums + pose bâti support | 4d | 2026-06-03 | 2026-06-08 | 221SS+1d | 285d |  |  | SPIE/SAITA |
| 223 | 6.2.5.2.14 | Ragréage sol | 1d | 2026-06-02 | 2026-06-02 | 219FS-2d | 269d | 0d |  | LPP |
| 224 | 6.2.5.2.15 | pose sol | 16d | 2026-06-03 | 2026-06-24 | 223 | 269d | 0d |  | LPP |
| 225 | 6.2.5.2.16 | Revetements muraux (faîence, SPM, cornières, barres d'appui etc) | 8d | 2026-06-05 | 2026-06-16 | 224SS+2d | 269d | 0d |  | FGV/LPP |
| 226 | 6.2.5.2.17 | Pose des équipements, terminaux (élec, sanitaires) | 10d | 2026-06-17 | 2026-06-30 | 225 | 269d |  |  | SPIE/SAITA |
| 227 | 6.2.5.2.18 | Finitions peinture | 7d | 2026-06-17 | 2026-06-25 | 225 | 272d |  |  | LPP |

| ID | WBS | Task | Type | Duration | Start | Finish | Predecessors | Total slack | Free slack | Constraint | Text1 |
| --- | --- | --- | --- | --- | --- | --- | --- | --- | --- | --- | --- |
| 228 | 6.2.5.3 | **Rdc (Box IAO, réserves)** |  | 72d | 2026-04-13 | 2026-07-21 |  | 254d |  |  |  |
| 229 | 6.2.5.3.1 | Descente EP / EU |  | 10d | 2026-04-13 | 2026-04-24 | 210SS | 316d |  |  | SAITA |
| 230 | 6.2.5.3.2 | Traçage du cloisonnement |  | 1d | 2026-04-23 | 2026-04-23 | 170FF-3d | 317d |  | start no earlier than 2026-02-24 | GOURAUD |
| 231 | 6.2.5.3.3 | Cloisonnement 1ère peau et doublage yc bandes |  | 20d | 2026-04-29 | 2026-05-26 | 213SS+5d | 294d | 0d |  | GOURAUD |
| 232 | 6.2.5.3.4 | Pose menuiseries int (bâti) |  | 7d | 2026-04-29 | 2026-05-07 | 231SS | 307d |  |  | FGV |
| 233 | 6.2.5.3.5 | Gaines de désenfumage |  | 10d | 2026-05-06 | 2026-05-19 | 231SS+5d | 299d |  |  | GOURAUD |
| 234 | 6.2.5.3.6 | Distributions des réseaux plomberies et aérauliques (CVC, RIA, PLB et DSF) |  | 35d | 2026-04-20 | 2026-06-05 | 216SS | 286d | 0d | start no earlier than 2026-02-24 | SAITA |
| 235 | 6.2.5.3.7 | Distributions des réseaux élec (CFO/CFA/SSI/DI) |  | 35d | 2026-04-20 | 2026-06-05 | 216SS | 253d | 0d |  | SPIE |
| 236 | 6.2.5.3.8 | Distributions des fluides médicaux |  | 15d | 2026-05-11 | 2026-05-29 | 234FF-5d | 291d |  |  | AIR LIQUIDE |
| 237 | 6.2.5.3.9 | Bon à fermer |  | 5d | 2026-05-18 | 2026-05-22 | 235FS-15d | 253d | 0d |  | SPIE/SAITA/AIR |
| 238 | 6.2.5.3.10 | Cloisonnement 2ème peau yc bandes |  | 15d | 2026-05-18 | 2026-06-05 | 237SS | 253d | 0d |  | GOURAUD |
| 239 | 6.2.5.3.11 | Préparation peinture + 1ère couche |  | 15d | 2026-05-27 | 2026-06-16 | 238FS-8d | 253d | 0d |  | LPP |
| 240 | 6.2.5.3.12 | Accompagnement pose réseaux en apparent |  | 14d | 2026-05-28 | 2026-06-16 | 239SS+1d | 279d |  |  | SPIE/SAITA |
| 241 | 6.2.5.3.13 | Pose FP |  | 15d | 2026-06-10 | 2026-06-30 | 239FS-5d | 253d | 0d |  | FGV |
| 242 | 6.2.5.3.14 | Accompagnement terminaux plénums |  | 9d | 2026-06-11 | 2026-06-23 | 241SS+1d | 253d | 0d |  | SPIE/SAITA |
| 243 | 6.2.5.3.15 | Revetements muraux (SPM, cornières, barres d'appui, plinthes etc) |  | 12d | 2026-06-17 | 2026-07-02 | 242FS-5d | 262d | 0d |  | FGV/LPP |
| 244 | 6.2.5.3.16 | Ragréage et pose sol souple |  | 15d | 2026-06-24 | 2026-07-14 | 242 | 253d | 0d |  | LPP |
| 245 | 6.2.5.3.17 | Finitions peinture |  | 10d | 2026-07-08 | 2026-07-21 | 244FS-5d | 254d |  |  | LPP |
| 246 | 6.2.5.3.18 | Pose des équipements, terminaux (élec, sanitaires) |  | 10d | 2026-07-01 | 2026-07-21 | 244SS+5d | 254d |  |  | SPIE/SAITA |
| 247 | 6.2.5.3.19 | Pose des équipements et mobiliers |  | 10d | 2026-07-01 | 2026-07-21 | 244SS+5d | 253d | 0d |  | FGV |
| 248 | 6.2.6 | Raccordement des fluides (AEP, ECS, EFS, EG, RIA) |  | 10d | 2026-06-11 | 2026-06-24 | 242SS | 273d |  |  | SAITA |
| 249 | 6.2.7 | Raccordement fluides médicaux |  | 8d | 2026-06-30 | 2026-07-09 | 243FS-3d | 262d |  |  | AIR LIQUIDE |
| 250 | 6.2.8 | Pose et raccordement TD U 02 & TD U 04 |  | 15d | 2026-06-03 | 2026-06-23 | 239SS+5d | 259d | 0d |  | SPIE |
| 251 | 6.2.9 | Mise à disposition alim élec définitive | milestone | 0d | 2026-06-23 | 2026-06-23 | 250 | 259d | 0d |  | SPIE |

| ID | WBS | Task | Duration | Start | Finish | Predecessors | Total slack | Free slack | Constraint | Text1 |
| --- | --- | --- | --- | --- | --- | --- | --- | --- | --- | --- |
| 252 | 6.2.10 | **Mises en service & Essais** | 21d | 2026-06-24 | 2026-07-22 | 251 | 253d | 0d |  | SPIE/SAITA/AIRL |
| 253 | 6.2.10.1 | Electricité | 15d | 2026-06-24 | 2026-07-14 | 250 | 259d |  |  |  |
| 254 | 6.2.10.2 | Fluides | 15d | 2026-06-24 | 2026-07-14 | 250 | 259d |  |  |  |
| 255 | 6.2.10.3 | Mise en service du contrôle d'accés | 1d | 2026-07-22 | 2026-07-22 | 247 | 253d |  |  |  |
| 256 | 6.3 | **Aménagements extérieurs (rampes d'accès, escalier)** | 177d | 2025-11-13 | 2026-07-17 |  | 256d |  |  |  |
| 257 | 6.3.1 | Consignation réseaux et dévoiement | 2d | 2025-11-13 | 2025-11-14 | 114 | 428d | 0d | start no earlier than 2025-06-09 | SPIE/EIFFAGE |
| 258 | 6.3.2 | Décapage et terassement | 3d | 2025-11-17 | 2025-11-19 | 257 | 428d |  | start no earlier than 2025-06-10 | EIFFAGE |
| 259 | 6.3.3 | **Recalage d'intervention dévoiement** | 10d | 2026-02-24 | 2026-03-09 |  | 260d |  |  |  |
| 260 | 6.3.3.1 | Dévoiement réseau incendie | 5d | 2026-02-24 | 2026-03-02 |  | 260d | 0d | start no earlier than 2026-02-24 | EIFFAGE |
| 261 | 6.3.3.2 | Dévoiement réseaux EP | 4d | 2026-03-03 | 2026-03-06 | 260 | 351d |  | start no earlier than 2025-03-06 | EIFFAGE |
| 262 | 6.3.3.3 | Raccordement RIA (DATE A CALER) | 1d | 2026-03-09 | 2026-03-09 | 260 | 256d | 0d | start no earlier than 2026-03-09 | EIFFAGE |
| 263 | 6.3.4 | **Murs de Soutènement** | 128d | 2026-01-21 | 2026-07-17 |  | 256d |  |  |  |
| 264 | 6.3.4.1 | Terrassement / Gros Béton / Semelle | 7d | 2026-03-10 | 2026-03-18 | 262 | 256d | 0d | start no earlier than 2026-01-22 | ALM |
| 265 | 6.3.4.2 | Délai Appro : Aciers 3 Semaines + Prefa 3 Semaines | 41d | 2026-01-21 | 2026-03-19 | 266SF | 343d |  | start no earlier than 2025-11-27 | ALM |
| 266 | 6.3.4.3 | Elevation Murs Soutènement | 30d | 2026-03-19 | 2026-04-29 | 264 | 256d | 0d | start no earlier than 2026-02-02 | ALM |
| 267 | 6.3.4.4 | Construction (soutènements) [Exe ALM ALLAIN] | 15d | 2026-03-19 | 2026-04-08 | 264 | 328d |  | start no earlier than 2026-03-09 | EIFFAGE |
| 268 | 6.3.4.5 | Commande + Mise en fab | 55d | 2026-04-27 | 2026-07-10 | 266FS-3d | 256d | 0d |  | MOYNET ALU |
| 269 | 6.3.4.6 | Pose des gardes-corps (Voirie) | 5d | 2026-04-30 | 2026-05-06 | 266 | 303d | 0d | start no earlier than 2026-04-13 | MOYNET ALU |
| 270 | 6.3.4.7 | Pose des gardes-corps (Rampe PMR) | 5d | 2026-07-13 | 2026-07-17 | 268 | 256d |  |  | MOYNET ALU |
| 271 | 6.3.5 | Reconstitution du sol (compactage et prépa pour enrobé) | 3d | 2026-04-30 | 2026-05-05 | 266 | 301d | 0d |  | EIFFAGE |
| 272 | 6.3.6 | Raccordement rsx (élec, fluides) | 3d | 2026-05-06 | 2026-05-08 | 271 | 301d | 0d |  | SPIE/EIFFAGE |
| 273 | 6.3.7 | Marche Béton Extérieur | 5d | 2026-05-11 | 2026-05-15 | 272 | 301d |  |  | ALM |
| 274 | 6.3.8 | Aménagements extérieurs | 10d | 2026-06-16 | 2026-06-29 | 173 | 268d | 0d | start no earlier than 2026-01-12 | EIFFAGE |
| 275 | 6.3.9 | Enrobé | 2d | 2026-06-30 | 2026-07-01 | 274 | 268d |  |  | EIFFAGE |

| ID | WBS | Task | Duration | Start | Finish | Predecessors | Total slack | Free slack | Constraint | Text1 |
| --- | --- | --- | --- | --- | --- | --- | --- | --- | --- | --- |
| 276 | 6.4 | **Construction du bâtiment SAS ambulance** | 83d | 2026-01-19 | 2026-05-13 |  | 303d |  |  |  |
| 277 | 6.4.1 | Terrassement / Gros Béton / Semelle Filante | 5d | 2026-01-19 | 2026-01-23 | 123SS+5d | 372d | 0d | start no earlier than 2026-01-05 | ALM |
| 278 | 6.4.2 | Elevation Béton | 9d | 2026-01-26 | 2026-02-05 | 277 | 372d |  |  | ALM |
| 279 | 6.4.3 | Structure métallique | 5d | 2026-03-31 | 2026-04-06 | 164 | 330d |  |  | BARAN |
| 280 | 6.4.4 | Etanchéité en toiture | 5d | 2026-04-08 | 2026-04-14 | 165 | 322d | 0d |  | SMAC |
| 281 | 6.4.5 | Peinture intumescente de la charpente | 2d | 2026-04-15 | 2026-04-16 | 280 | 322d |  |  | BARAN |
| 282 | 6.4.6 | Pose du bardage (entrée) | 7d | 2026-04-20 | 2026-04-28 | 166 | 314d |  |  | SMAC |
| 283 | 6.4.7 | Pose des portes sectionelles et vitrages | 4d | 2026-05-01 | 2026-05-06 | 269SS+1d | 303d | 0d |  | MOYNET ALU |
| 284 | 6.4.8 | Pose et raccordement des équip Plb (siphons sol, EU, Efs) | 5d | 2026-05-07 | 2026-05-13 | 283 | 303d |  |  | SAITA |
| 285 | 6.4.9 | Pose et raccordement équip élec (CFO/CFA/SSI) | 5d | 2026-05-07 | 2026-05-13 | 283 | 303d |  |  | SPIE |
| 286 | 7 | **OPR Phase 3** | 22d | 2026-07-09 | 2026-08-07 |  | 239d |  |  |  |
| 287 | 7.1 | OPR | 5d | 2026-07-09 | 2026-07-15 | 252SS+11d | 239d | 0d |  |  |
| 288 | 7.2 | Levée de réserves | 10d | 2026-07-16 | 2026-07-29 | 287 | 239d | 0d | start no earlier than 2026-06-25 |  |
| 289 | 7.3 | Réception archi BET et SSI et BC | 1d | 2026-07-30 | 2026-07-30 | 288 | 239d | 0d |  |  |
| 290 | 7.4 | Commission de sécurité | 1d | 2026-07-31 | 2026-07-31 | 289 | 241d | 0d |  |  |
| 291 | 7.5 | Remise en état pour ouverture du service | 5d | 2026-08-03 | 2026-08-07 | 290 | 241d |  |  |  |
| 292 | 8 | **PHASE 4 : CONSTRUCTION URGENCES PEDIATRIQUE + PC SECURITE** | 186d | 2026-06-25 | 2027-03-11 |  | 47d |  |  |  |
| 293 | 8.1 | **Installation de chantier** | 78d | 2026-07-30 | 2026-11-16 |  | 170d |  |  |  |
| 294 | 8.1.1 | Implantation projet | 1d | 2026-07-30 | 2026-07-30 | 289SS | 239d | 11d |  | EIFFAGE/ALM |
| 295 | 8.1.2 | Préparation plateforme (décapage et terrassement) | 8d | 2026-08-17 | 2026-08-26 | 294 | 228d | 0d | start no earlier than 2026-08-17 | EIFFAGE |
| 296 | 8.1.3 | Isolement de la zone concerné | 1d | 2026-08-26 | 2026-08-26 | 295FF | 228d |  | start no earlier than 2026-07-31 | PREMYSS |
| 297 | 8.1.4 | Montage grue | 5d | 2026-08-24 | 2026-08-31 | 301SF | 226d |  |  | ALM |
| 298 | 8.1.5 | Démontage grue | 2d | 2026-11-13 | 2026-11-16 | 314 | 170d |  |  | ALM |
| 299 | 8.2 | **Construction du bâtiment URGENCES PEDIATRIQUES** | 141d | 2026-06-25 | 2027-01-07 |  | 47d |  |  |  |
| 300 | 8.2.1 | Délai Appro : Aciers 3 Semaines + Prefa 3 Semaines | 47d | 2026-06-25 | 2026-08-31 | 301SF | 226d |  |  | ALM |
| 301 | 8.2.2 | Terassement / Gros Béton / Semelles | 9d | 2026-08-31 | 2026-09-10 |  | 0d |  | start no earlier than 2026-08-31 | ALM |
| 302 | 8.2.3 | Elevations Sous Sol | 12d | 2026-09-11 | 2026-09-28 | 301 | 102d | 0d |  | ALM |
| 303 | 8.2.4 | Plancher Prédalles Ht VS | 7d | 2026-09-29 | 2026-10-07 | 302 | 102d | 0d |  | ALM |
| 304 | 8.2.5 | Désétaiement Prédalle Haut VS + | 24d | 2026-10-29 | 2026-12-01 | 303FS+15d | 159d |  |  | ALM |
| 305 | 8.2.6 | Elevation RDC | 14d | 2026-10-06 | 2026-10-23 | 303SS+5d | 102d | 0d |  | ALM |
| 306 | 8.2.7 | Plancher Prédalle Haut RDC | 7d | 2026-10-26 | 2026-11-03 | 305 | 102d | 0d |  | ALM |
| 307 | 8.2.8 | Désétaiement Prédalle Haut RDC + finitions | 10d | 2026-11-18 | 2026-12-01 | 306FS+10d | 151d | 0d |  | ALM |
| 308 | 8.2.9 | Acrotère Béton Haut RDC + | 7d | 2026-11-04 | 2026-11-12 | 306 | 102d | 0d |  | ALM |
| 309 | 8.2.10 | Pose du fibralith | 8d | 2026-12-02 | 2026-12-11 | 307 | 151d |  |  | ALM |
| 310 | 8.2.11 | Flocage | 4d | 2027-01-04 | 2027-01-07 | 319 | 132d |  | start no earlier than 2027-01-04 | ALM |

| ID | WBS | Task | Type | Duration | Start | Finish | Predecessors | Total slack | Free slack | Constraint | Text1 |
| --- | --- | --- | --- | --- | --- | --- | --- | --- | --- | --- | --- |
| 311 | 8.2.12 | **Murs de Soutènement** |  | 55d | 2026-08-28 | 2026-11-12 |  | 170d |  |  |  |
| 312 | 8.2.12.1 | Délai Appro : Aciers 3 Semaines + Préfa 3 semaines |  | 31d | 2026-08-28 | 2026-10-09 | 305FF-10d | 170d | 0d | start no earlier than 2026-08-10 | ALM |
| 313 | 8.2.12.2 | Terrassement / Gros Béton / Semelle |  | 15d | 2026-10-09 | 2026-10-29 | 312FS-1d | 170d | 0d |  | ALM |
| 314 | 8.2.12.3 | Elevation Murs Soutènement |  | 15d | 2026-10-23 | 2026-11-12 | 313FS-5d | 170d | 0d |  | ALM |
| 315 | 8.2.12.4 | Marche Béton Extérieur |  | 15d | 2026-10-23 | 2026-11-12 | 314SS | 172d |  |  | ALM |
| 316 | 8.3 | **Couverture et étanchéité** |  | 35d | 2026-11-04 | 2026-12-22 |  | 116d |  |  |  |
| 317 | 8.3.1 | Pose des gardes corps |  | 3d | 2026-11-13 | 2026-11-17 | 308 | 169d |  |  | MOYNET ALU |
| 318 | 8.3.2 | traitement joint de dilatation |  | 1d | 2026-11-20 | 2026-11-23 | 319SF-1d | 166d |  |  | ALM |
| 319 | 8.3.3 | étanchéité + gravillons |  | 19d | 2026-11-24 | 2026-12-18 | 308FS+7d | 102d | 0d |  | EXETANCHE |
| 320 | 8.3.4 | pose des menuiseries extérieures |  | 10d | 2026-11-04 | 2026-11-17 | 306 | 144d | 0d | start no earlier than 2026-07-27 | GEAY MENUIS |
| 321 | 8.3.5 | Installation échafaudage |  | 3d | 2026-11-18 | 2026-11-20 | 320 | 144d | 0d |  | ER PEINTURE |
| 322 | 8.3.6 | Pose complexe ITE (profilés, isolation yc enduit) |  | 22d | 2026-11-23 | 2026-12-22 | 321 | 144d | 0d |  | ER PEINTURE |
| 323 | 8.3.7 | **AUVENT** |  | 25d | 2026-11-11 | 2026-12-15 |  | 149d |  |  | MOYNET ALU |
| 324 | 8.3.7.1 | Commande + Mise en fab |  | 15d | 2026-11-11 | 2026-12-02 | 325SF | 159d |  |  | MOYNET ALU |
| 325 | 8.3.7.2 | Exécution de l'auvent |  | 10d | 2026-12-02 | 2026-12-15 | 322FF-5d | 149d | 0d |  | MOYNET ALU |
| 326 | 8.4 | **Aménagements intérieures** |  | 61d | 2026-11-26 | 2027-02-18 |  | 102d |  |  |  |
| 327 | 8.4.1 | Traçage du cloisonnement |  | 1d | 2026-12-09 | 2026-12-09 | 319FF-7d | 102d | 0d |  | GOURAUD |
| 328 | 8.4.2 | Cloisonnement 1ère peau et doublage yc bandes |  | 15d | 2026-12-10 | 2026-12-30 | 331SS+10d | 138d | 0d |  | GOURAUD |
| 329 | 8.4.3 | Pose menuiseries int (bâti, chassis) |  | 5d | 2026-12-14 | 2026-12-18 | 328SS+2d | 146d |  |  | FGV |
| 330 | 8.4.4 | Distributions rsx Plb et aérauliques (CVC, RIA, PLB et DSF) |  | 40d | 2026-11-26 | 2027-01-20 | 327FS-10d | 123d | 0d |  | SAITA |
| 331 | 8.4.5 | Distributions des réseaux élec (CFO/CFA/SSI/DI) |  | 40d | 2026-11-26 | 2027-01-20 | 327FS-10d | 102d | 0d |  | SPIE |
| 332 | 8.4.6 | Distributions des fluides médicaux |  | 15d | 2026-12-24 | 2027-01-13 | 330FF-5d | 128d |  |  | AIR LIQUIDE |
| 333 | 8.4.7 | Bon à fermer | milestone | 0d | 2026-12-31 | 2026-12-31 | 331FS-15d | 102d | 0d |  |  |
| 334 | 8.4.8 | Cloisonnement 2ème peau yc bandes |  | 10d | 2026-12-31 | 2027-01-13 | 333 | 102d | 0d |  | GOURAUD |
| 335 | 8.4.9 | Préparation peinture + 1ère couche |  | 12d | 2027-01-07 | 2027-01-22 | 334FS-5d | 102d | 0d |  | LPP |
| 336 | 8.4.10 | Accompagnement pose réseaux en apparent |  | 10d | 2027-01-12 | 2027-01-25 | 335SS+3d | 120d |  |  | SPIE/SAITA |
| 337 | 8.4.11 | Revetements muraux (SPM, cornières, barres d'appui, plinthes etc) |  | 15d | 2027-01-07 | 2027-01-27 | 335SS | 118d |  |  | LPP/FGV |
| 338 | 8.4.12 | Pose FP (rails plafonds + plaques) |  | 14d | 2027-01-19 | 2027-02-05 | 335FS-4d | 102d | 0d |  | FGV |
| 339 | 8.4.13 | Accompagnement terminaux plénums |  | 9d | 2027-01-20 | 2027-02-01 | 338SS+1d | 115d |  |  | SPIE/SAITA |
| 340 | 8.4.14 | Ragréage et pose sol souple |  | 10d | 2027-02-02 | 2027-02-15 | 338FS-4d | 102d | 0d |  | LPP |
| 341 | 8.4.15 | Finitions peintures |  | 8d | 2027-02-09 | 2027-02-18 | 340FS-5d | 102d |  |  | LPP |
| 342 | 8.4.16 | Pose mobiliers |  | 7d | 2027-02-02 | 2027-02-18 | 340SS | 102d |  |  | FGV |
| 343 | 8.4.17 | Pose des équipements, terminaux (élec, sanitaire) |  | 7d | 2027-02-02 | 2027-02-18 | 340SS | 102d |  |  | SPIE/SAITA |
| 344 | 8.4.18 | Raccordement des fluides (AEP, ECS, EFS, EG, RIA) |  | 10d | 2027-01-05 | 2027-01-19 | 338SF | 125d |  |  | SAITA |
| 345 | 8.4.19 | Raccordement fluides médicaux |  | 7d | 2027-01-19 | 2027-01-27 | 338SS | 118d |  |  | AIR LIQUIDE |
| 346 | 8.4.20 | Pose et Raccordement TD électrique |  | 15d | 2026-12-29 | 2027-01-19 | 338SF | 110d | 0d |  | SPIE |
| 347 | 8.4.21 | Mise à disposition alim élec définitive | milestone | 0d | 2027-01-19 | 2027-01-19 | 346 | 110d | 0d |  | SPIE |
| 348 | 8.4.22 | Aménagements extérieurs |  | 10d | 2027-02-02 | 2027-02-15 |  | 105d |  | start no earlier than 2027-02-02 | EIFFAGE |
| 349 | 8.5 | Mise en service et essais |  | 15d | 2027-01-19 | 2027-02-08 | 347 | 110d |  | start no earlier than 2027-01-18 |  |

| ID | WBS | Task | Type | Duration | Start | Finish | Predecessors | Total slack | Free slack | Constraint | Text1 |
| --- | --- | --- | --- | --- | --- | --- | --- | --- | --- | --- | --- |
| 350 | 8.6 | **OPR Phase 4** |  | 27d | 2027-02-03 | 2027-03-11 |  | 82d |  |  |  |
| 351 | 8.6.1 | OPR |  | 5d | 2027-02-03 | 2027-02-09 |  | 82d | 0d | start no earlier than 2027-02-03 |  |
| 352 | 8.6.2 | Levée de réserves |  | 10d | 2027-02-10 | 2027-02-23 | 351 | 82d | 0d |  |  |
| 353 | 8.6.3 | Commission de sécurité |  | 1d | 2027-03-10 | 2027-03-10 | 352FS+10d | 82d | 0d |  |  |
| 354 | 8.6.4 | Réception |  | 1d | 2027-03-11 | 2027-03-11 | 353 | 82d | 0d |  |  |
| 355 | 9 | Emménagement |  | 5d | 2027-03-12 | 2027-03-18 | 354 | 82d |  |  |  |
| 356 | 10 | **PHASE 5 : RESTRUCTURATION DU CIRCUIT COURT** |  | 88d | 2026-09-11 | 2027-01-12 |  | 0d |  |  |  |
| 357 | 10.1 | **PHASE 5a** |  | 37d | 2026-09-11 | 2026-11-02 |  | 0d |  |  |  |
| 358 | 10.1.1 | **Préparation, curage, GO, aménagement cloison** |  | 12d | 2026-09-11 | 2026-09-28 |  | 0d |  |  |  |
| 359 | 10.1.1.1 | Isolement de la zone concernée |  | 2d | 2026-09-11 | 2026-09-14 | 301 | 0d |  |  | PREMYSS |
| 360 | 10.1.1.2 | Curage |  | 2d | 2026-09-11 | 2026-09-14 | 359SS | 215d |  |  | PREMYSS |
| 361 | 10.1.1.3 | Création renforts, réservations, trémies (GO) |  | 10d | 2026-09-15 | 2026-09-28 | 359 | 0d |  |  | ALM |
| 362 | 10.1.1.4 | Traçage du cloisonnement |  | 1d | 2026-09-22 | 2026-09-22 | 363SS | 209d |  |  | GOURAUD |
| 363 | 10.1.1.5 | Cloisonnement 1ère peau et doublage yc bandes |  | 5d | 2026-09-22 | 2026-09-28 | 361FS-5d | 0d |  |  | GOURAUD |
| 364 | 10.1.1.6 | Pose menuiseries int (bâti, chassis) |  | 2d | 2026-09-22 | 2026-09-23 | 363SS | 0d |  |  | FGV |
| 365 | 10.1.2 | **Distribution lots technique** |  | 8d | 2026-09-24 | 2026-10-05 |  | 0d |  |  |  |
| 366 | 10.1.2.1 | Distributions rsx Plb et aérauliques (CVC, RIA, PLB et DSF) |  | 8d | 2026-09-24 | 2026-10-05 | 364 | 200d |  |  | SAITA |
| 367 | 10.1.2.2 | Distributions des réseaux élec (CFO/CFA/SSI/DI) |  | 8d | 2026-09-24 | 2026-10-05 | 364 | 0d |  |  | SPIE |
| 368 | 10.1.2.3 | Distributions des fluides médicaux |  | 4d | 2026-09-30 | 2026-10-05 | 367FF | 200d |  |  | AIR LIQUIDE |
| 369 | 10.1.2.4 | Bon à fermer | milestone | 0d | 2026-10-01 | 2026-10-01 | 367FF-2d | 0d |  |  |  |
| 370 | 10.1.3 | **2nd oeuvre, finitions** |  | 19d | 2026-10-02 | 2026-10-28 |  | 0d |  |  |  |
| 371 | 10.1.3.1 | Cloisonnement 2ème peau yc bandes |  | 2d | 2026-10-02 | 2026-10-05 | 369 | 0d |  |  | GOURAUD |
| 372 | 10.1.3.2 | Préparation peinture + 1ère couche |  | 4d | 2026-10-06 | 2026-10-09 | 371 | 0d |  |  | LPP |
| 373 | 10.1.3.3 | Pose TD élec et raccordement |  | 5d | 2026-10-06 | 2026-10-12 | 372SS | 195d |  |  | SPIE |
| 374 | 10.1.3.4 | Revetements muraux (SPM, cornières, barres d'appui, plinthes etc) |  | 3d | 2026-10-08 | 2026-10-12 | 372SS+2d | 195d |  |  | LPP/FGV |
| 375 | 10.1.3.5 | Pose FP |  | 3d | 2026-10-12 | 2026-10-14 | 372 | 0d |  |  | FGV |
| 376 | 10.1.3.6 | Accompagnement terminaux plénums |  | 3d | 2026-10-13 | 2026-10-15 | 375SS+1d | 0d |  |  | SPIE/SAITA |
| 377 | 10.1.3.7 | Ragréage et pose sol souple |  | 3d | 2026-10-16 | 2026-10-20 | 376 | 0d |  |  | LPP |
| 378 | 10.1.3.8 | Pose mobiliers |  | 2d | 2026-10-21 | 2026-10-22 | 377 | 0d |  |  | FGV |
| 379 | 10.1.3.9 | Finitions peintures |  | 1d | 2026-10-23 | 2026-10-23 | 378 | 186d |  |  | LPP |
| 380 | 10.1.3.10 | Pose équipements, terminaux (sanitaires, élecs) |  | 2d | 2026-10-23 | 2026-10-26 | 378 | 0d |  |  | SPIE/SAITA |
| 381 | 10.1.3.11 | Essais et mise en service |  | 2d | 2026-10-27 | 2026-10-28 | 380 | 0d |  |  |  |
| 382 | 10.1.4 | Fermeture de l'allège phase 4/5 |  | 2d | 2026-10-27 | 2026-10-28 | 380 | 180d | 0d |  | ALM |
| 383 | 10.1.5 | Travaux de finition au droit des zones contigues |  | 3d | 2026-10-29 | 2026-11-02 | 382 | 180d |  |  | LPP/FGV |

| ID | WBS | Task | Type | Duration | Start | Finish | Predecessors | Total slack | Text1 |
| --- | --- | --- | --- | --- | --- | --- | --- | --- | --- |
| 384 | 10.2 | **OPR Phase 5a** |  | 7d | 2026-10-27 | 2026-11-04 |  | 0d |  |
| 385 | 10.2.1 | OPR |  | 6d | 2026-10-27 | 2026-11-03 | 381FS-2d | 0d |  |
| 386 | 10.2.2 | Levée de réserves |  | 5d | 2026-10-28 | 2026-11-03 | 385SS+1d | 0d |  |
| 387 | 10.2.3 | Réception | milestone | 0d | 2026-11-04 | 2026-11-04 | 386FS+1d | 0d |  |
| 388 | 10.3 | Emménagement |  | 3d | 2026-11-05 | 2026-11-09 | 387 | 0d |  |
| 389 | 10.4 | **PHASE 5b** |  | 34d | 2026-11-10 | 2026-12-25 |  | 0d |  |
| 390 | 10.4.1 | **Préparation, curage, GO, aménagements cloison** |  | 12d | 2026-11-10 | 2026-11-25 |  | 0d |  |
| 391 | 10.4.1.1 | Isolement de la zone concernée |  | 2d | 2026-11-10 | 2026-11-11 | 388 | 0d | PREMYSS |
| 392 | 10.4.1.2 | Curage |  | 2d | 2026-11-10 | 2026-11-11 | 391SS | 0d | PREMYSS |
| 393 | 10.4.1.3 | Création renforts, réservations, trémies (GO) |  | 10d | 2026-11-12 | 2026-11-25 | 392 | 0d | ALM |
| 394 | 10.4.1.4 | Traçage du cloisonnement |  | 1d | 2026-11-19 | 2026-11-19 | 395SS | 167d | GOURAUD |
| 395 | 10.4.1.5 | Cloisonnement 1ère peau et doublage yc bandes |  | 5d | 2026-11-19 | 2026-11-25 | 393SS+5d | 0d | GOURAUD |
| 396 | 10.4.1.6 | Pose menuiseries int (bâti, chassis) |  | 2d | 2026-11-19 | 2026-11-20 | 395SS | 0d | FGV |
| 397 | 10.4.2 | **Distribution lots techniques** |  | 8d | 2026-11-23 | 2026-12-02 |  | 0d |  |
| 398 | 10.4.2.1 | Distributions rsx Plb et aérauliques (CVC, RIA, PLB et DSF) |  | 8d | 2026-11-23 | 2026-12-02 | 396 | 158d | SAITA |
| 399 | 10.4.2.2 | Distributions des réseaux élec (CFO/CFA/SSI/DI) |  | 8d | 2026-11-23 | 2026-12-02 | 396 | 0d | SPIE |
| 400 | 10.4.2.3 | Distributions des fluides médicaux |  | 3d | 2026-11-27 | 2026-12-01 | 399FF-1d | 159d | AIR LIQUIDE |
| 401 | 10.4.2.4 | Bon à fermer | milestone | 0d | 2026-11-27 | 2026-11-27 | 399FF-3d | 0d |  |
| 402 | 10.4.3 | **2nd oeuvre, finitions** |  | 17d | 2026-11-30 | 2026-12-22 |  | 0d |  |
| 403 | 10.4.3.1 | Cloisonnement 2ème peau yc bandes |  | 2d | 2026-11-30 | 2026-12-01 | 401 | 0d | FGV |
| 404 | 10.4.3.2 | Préparation peinture + 1ère couche |  | 3d | 2026-12-02 | 2026-12-04 | 403 | 0d | LPP |
| 405 | 10.4.3.3 | Revetements muraux (SPM, cornières, barres d'appui, plinthes etc) |  | 3d | 2026-12-04 | 2026-12-08 | 404SS+2d | 154d | FGV/LPP |
| 406 | 10.4.3.4 | Pose FP |  | 3d | 2026-12-07 | 2026-12-09 | 404 | 0d | FGV |
| 407 | 10.4.3.5 | Accompagnement terminaux plénums |  | 3d | 2026-12-08 | 2026-12-10 | 406SS+1d | 0d | SPIE/SAITA |
| 408 | 10.4.3.6 | Ragréage et pose sol souple |  | 3d | 2026-12-11 | 2026-12-15 | 407 | 0d | LPP |
| 409 | 10.4.3.7 | Pose mobiliers |  | 3d | 2026-12-16 | 2026-12-18 | 408 | 0d | FGV |
| 410 | 10.4.3.8 | Finitions peintures |  | 2d | 2026-12-21 | 2026-12-22 | 409 | 144d | LPP |
| 411 | 10.4.3.9 | Pose équipements, terminaux (sanitaires, élecs) |  | 2d | 2026-12-21 | 2026-12-22 | 409 | 0d | SPIE/SAITA |
| 412 | 10.4.4 | Essais et mise en service |  | 3d | 2026-12-23 | 2026-12-25 | 411 | 0d |  |

| ID | WBS | Task | Type | Duration | Start | Finish | Predecessors | Total slack | Free slack |
| --- | --- | --- | --- | --- | --- | --- | --- | --- | --- |
| 413 | 10.5 | **OPR Phase 5** |  | 14d | 2026-12-24 | 2027-01-12 |  | 0d |  |
| 414 | 10.5.1 | OPR |  | 6d | 2026-12-24 | 2026-12-31 | 412FS-2d | 0d |  |
| 415 | 10.5.2 | Levée de réserves |  | 5d | 2026-12-28 | 2027-01-01 | 414SS+2d | 0d |  |
| 416 | 10.5.3 | Commission de sécurité |  | 1d | 2027-01-11 | 2027-01-11 | 415SS+10d | 0d |  |
| 417 | 10.5.4 | Réception |  | 1d | 2027-01-12 | 2027-01-12 | 416 | 129d |  |
| 418 | 11 | Emménagement |  | 4d | 2027-01-12 | 2027-01-15 | 416 | 0d |  |
| 419 | 12 | **PHASE 6 : RESTRUCTURATION LEGERE, BOX, DECHOCAGE ADULTE** |  | 127d | 2027-01-15 | 2027-07-12 |  | 0d |  |
| 420 | 12.1 | **Phase 6a** |  | 26d | 2027-01-15 | 2027-02-19 |  | 0d |  |
| 421 | 12.1.1 | **Préparation, curage, GO, aménagement cloison** |  | 12d | 2027-01-15 | 2027-02-01 |  | 0d |  |
| 422 | 12.1.1.1 | Isolement de la zone concernée |  | 2d | 2027-01-15 | 2027-01-18 | 418FS-1d | 0d |  |
| 423 | 12.1.1.2 | Curage |  | 2d | 2027-01-15 | 2027-01-18 | 422SS | 0d |  |
| 424 | 12.1.1.3 | Création renforts, réservations, trémies (GO) |  | 10d | 2027-01-19 | 2027-02-01 | 422 | 115d | 0d |
| 425 | 12.1.1.4 | Traçage du cloisonnement |  | 1d | 2027-02-01 | 2027-02-01 | 424FF | 115d |  |
| 426 | 12.1.1.5 | Cloisonnement 1ère peau et doublage yc bandes |  | 5d | 2027-01-22 | 2027-01-28 | 423SS+5d | 0d |  |
| 427 | 12.1.1.6 | Pose menuiseries int (bâti, chassis) |  | 2d | 2027-01-22 | 2027-01-25 | 426SS | 0d |  |
| 428 | 12.1.2 | **Distribution lots technique** |  | 6d | 2027-01-26 | 2027-02-02 |  | 0d |  |
| 429 | 12.1.2.1 | Distributions rsx Plb et aérauliques (CVC, RIA, PLB et DSF) |  | 6d | 2027-01-26 | 2027-02-02 | 427 | 114d |  |
| 430 | 12.1.2.2 | Distributions des réseaux élec (CFO/CFA/SSI/DI) |  | 6d | 2027-01-26 | 2027-02-02 | 427 | 0d |  |
| 431 | 12.1.2.3 | Distributions des fluides médicaux |  | 4d | 2027-01-28 | 2027-02-02 | 430FF | 114d |  |
| 432 | 12.1.2.4 | Bon à fermer | milestone | 0d | 2027-01-29 | 2027-01-29 | 430FF-2d | 0d |  |
| 433 | 12.1.3 | **2nd oeuvre, finitions** |  | 15d | 2027-02-01 | 2027-02-19 |  | 0d |  |
| 434 | 12.1.3.1 | Cloisonnement 2ème peau yc bandes |  | 2d | 2027-02-01 | 2027-02-02 | 432 | 0d |  |
| 435 | 12.1.3.2 | Préparation peinture + 1ère couche |  | 2d | 2027-02-03 | 2027-02-04 | 434 | 0d |  |
| 436 | 12.1.3.3 | Pose TD élec et raccordement |  | 3d | 2027-02-03 | 2027-02-05 | 435SS | 111d |  |
| 437 | 12.1.3.4 | Revetements muraux (SPM, cornières, barres d'appui, plinthes etc) |  | 2d | 2027-02-05 | 2027-02-08 | 435SS+2d | 110d |  |
| 438 | 12.1.3.5 | Pose FP |  | 2d | 2027-02-05 | 2027-02-08 | 435 | 0d |  |
| 439 | 12.1.3.6 | Accompagnement terminaux plénums |  | 2d | 2027-02-08 | 2027-02-09 | 438SS+1d | 0d |  |
| 440 | 12.1.3.7 | Ragréage et pose sol souple |  | 2d | 2027-02-10 | 2027-02-11 | 439 | 0d |  |
| 441 | 12.1.3.8 | Pose mobiliers |  | 2d | 2027-02-12 | 2027-02-15 | 440 | 0d |  |
| 442 | 12.1.3.9 | Finitions peintures |  | 1d | 2027-02-16 | 2027-02-16 | 441 | 104d |  |
| 443 | 12.1.3.10 | Pose équipements, terminaux (sanitaires, élecs) |  | 2d | 2027-02-16 | 2027-02-17 | 441 | 0d |  |
| 444 | 12.1.3.11 | Essais et mise en service |  | 2d | 2027-02-18 | 2027-02-19 | 443 | 0d |  |

| ID | WBS | Task | Duration | Start | Finish | Predecessors | Total slack |
| --- | --- | --- | --- | --- | --- | --- | --- |
| 445 | 12.2 | **OPR phase 6a** | 7d | 2027-02-22 | 2027-03-02 |  | 0d |
| 446 | 12.2.1 | Durée | 7d | 2027-02-22 | 2027-03-02 | 444 | 0d |
| 447 | 12.3 | Emménagement | 3d | 2027-03-03 | 2027-03-05 | 446 | 0d |
| 448 | 12.4 | **Phase 6b** | 31d | 2027-03-08 | 2027-04-19 |  | 0d |
| 449 | 12.4.1 | **Préparation, curage, GO, aménagement cloison** | 12d | 2027-03-08 | 2027-03-23 |  | 0d |
| 450 | 12.4.1.1 | durée | 12d | 2027-03-08 | 2027-03-23 | 447 | 0d |
| 451 | 12.4.2 | **Distribution lots technique** | 6d | 2027-03-22 | 2027-03-29 |  | 0d |
| 452 | 12.4.2.1 | durée | 6d | 2027-03-22 | 2027-03-29 | 450FS-2d | 0d |
| 453 | 12.4.3 | **2nd oeuvre, finitions** | 15d | 2027-03-30 | 2027-04-19 |  | 0d |
| 454 | 12.4.3.1 | durée | 15d | 2027-03-30 | 2027-04-19 | 452 | 0d |
| 455 | 12.5 | **OPR phase 6b** | 7d | 2027-04-20 | 2027-04-28 |  | 0d |
| 456 | 12.5.1 | durée | 7d | 2027-04-20 | 2027-04-28 | 454 | 0d |
| 457 | 12.6 | Emménagement | 3d | 2027-04-29 | 2027-05-03 | 456 | 0d |
| 458 | 12.7 | **Phase 6c** | 33d | 2027-05-04 | 2027-06-17 |  | 0d |
| 459 | 12.7.1 | **Préparation, curage, GO, aménagement cloison** | 12d | 2027-05-04 | 2027-05-19 |  | 0d |
| 460 | 12.7.1.1 | durée | 12d | 2027-05-04 | 2027-05-19 | 457 | 0d |
| 461 | 12.7.2 | **Distribution lots technique** | 6d | 2027-05-20 | 2027-05-27 |  | 0d |
| 462 | 12.7.2.1 | durée | 6d | 2027-05-20 | 2027-05-27 | 460 | 0d |
| 463 | 12.7.3 | **2nd oeuvre, finitions** | 15d | 2027-05-28 | 2027-06-17 |  | 0d |
| 464 | 12.7.3.1 | durée | 15d | 2027-05-28 | 2027-06-17 | 462 | 0d |
| 465 | 12.8 | **OPR phase 6a** | 14d | 2027-06-18 | 2027-07-07 |  | 0d |
| 466 | 12.8.1 | durée | 14d | 2027-06-18 | 2027-07-07 | 464 | 0d |
| 467 | 12.9 | Emménagement | 3d | 2027-07-08 | 2027-07-12 | 466 | 0d |
