# Planning Matha EXE commun - le 05.09.25

Schedule from MS Project, 2025-08-11 to 2027-06-17, 7 hours a day.

## Calendars

- Standard: Mon-Fri 09:00-12:00, 14:00-18:00; Sat-Sun off.

## Resources

| Resource |
| --- |
| 30 |

## Schedule

| ID | WBS | Task | Type | Duration | Start | Finish | Predecessors | Total slack | Free slack | Constraint | Text1 |
| --- | --- | --- | --- | --- | --- | --- | --- | --- | --- | --- | --- |
| 1 | 1 | **Phase 1** |  | 145d | 2025-08-11 | 2026-02-27 |  | 339d |  |  |  |
| 2 | 1.1 | **Bâtiment D** |  | 139d | 2025-08-19 | 2026-02-27 |  | 339d |  |  |  |
| 3 | 1.1.1 | **LT Chaufferie** |  | 24d | 2025-08-19 | 2025-09-19 |  | 454d |  |  |  |
| 4 | 1.1.1.1 | Livraison chaudière mobile + mise en service |  | 1d | 2025-08-19 | 2025-08-19 |  | 475d | 0d | start no earlier than 2025-08-19 | EIFFAGE |
| 5 | 1.1.1.2 | Dépose équipements chaufferie existante |  | 2d | 2025-08-20 | 2025-08-21 | 4 | 475d |  |  | EIFFAGE |
| 6 | 1.1.1.3 | Dépose socles / Agrandissemt de la baie |  | 3d | 2025-08-26 | 2025-08-28 |  | 470d |  | start no earlier than 2025-08-26 | ALM |
| 7 | 1.1.1.4 | Livraison chaudière biofioul + pose |  | 2d | 2025-08-28 | 2025-08-29 |  | 454d | 0d | start no earlier than 2025-08-28 | EIFFAGE |
| 8 | 1.1.1.5 | Pose réseaux CVC/Plb |  | 10d | 2025-09-01 | 2025-09-12 | 7 | 454d | 0d |  | EIFFAGE |
| 9 | 1.1.1.6 | Pose réseaux élec |  | 10d | 2025-09-01 | 2025-09-12 | 7 | 454d | 0d |  | EIFFAGE |
| 10 | 1.1.1.7 | Mise à dispo alim élec (TD CVC+chaufferie) | milestone | 0d | 2025-09-10 | 2025-09-10 |  | 462d |  | start no earlier than 2025-09-10 | FAUCHE |
| 11 | 1.1.1.8 | Mise en service chaufferie |  | 3d | 2025-09-15 | 2025-09-17 | 8, 9 | 454d | 0d |  | EIFFAGE |
| 12 | 1.1.1.9 | Essais |  | 3d | 2025-09-17 | 2025-09-19 | 11FS-1d | 454d | 0d |  | EIFFAGE |
| 13 | 1.1.1.10 | Evacuation chaufferie mobile | milestone | 0d | 2025-09-19 | 2025-09-19 | 12FF | 454d |  |  | EIFFAGE |
| 14 | 1.1.2 | **INTERVENTION PATIO** |  | 58d | 2025-12-10 | 2026-02-27 |  | 339d |  |  |  |
| 15 | 1.1.2.1 | Exécution des massifs |  | 10d | 2025-12-10 | 2025-12-23 |  | 374d | 18d | start no earlier than 2025-12-10 | ALM ALLAIN |
| 16 | 1.1.2.2 | Ponçage du sol |  | 3d | 2026-01-19 | 2026-01-21 | 15 | 356d | 0d | start no earlier than 2026-01-19 | ALM ALLAIN |
| 17 | 1.1.2.3 | Parement Extérieur muret |  | 5d | 2026-01-22 | 2026-01-28 | 16 | 356d | 0d |  | ALM ALLAIN |
| 18 | 1.1.2.4 | Pose MOB + charpente |  | 5d | 2026-01-22 | 2026-01-28 | 17SS | 356d | 0d |  | POUGNAND |
| 19 | 1.1.2.5 | Étanchéité |  | 5d | 2026-02-02 | 2026-02-06 | 18 | 354d |  | start no earlier than 2026-02-02 | SOPREMA |
| 20 | 1.1.2.6 | Pose des couvertines |  | 2d | 2026-02-12 | 2026-02-13 |  | 346d | 0d | start no earlier than 2026-02-12 | SOPREMA |
| 21 | 1.1.2.7 | Dépose cloison provisoire |  | 1d | 2026-02-12 | 2026-02-12 | 20SS | 346d | 0d |  | ALM ALLAIN |
| 22 | 1.1.2.8 | Pose Men EXT |  | 2d | 2026-02-02 | 2026-02-03 | 18FS+2d | 357d |  |  | GEAY MEN |
| 23 | 1.1.2.9 | Tracé cloison | milestone | 0d | 2026-02-12 | 2026-02-12 | 21 | 346d | 0d |  | GOURAUD |
| 24 | 1.1.2.10 | Cloisonnement/doublage, cpris finitions intérieur |  | 4d | 2026-02-13 | 2026-02-18 | 23 | 346d | 0d |  | GOURAUD |
| 25 | 1.1.2.11 | Faux-plafond |  | 2d | 2026-02-17 | 2026-02-18 | 24FF | 346d |  |  | FGV |
| 26 | 1.1.2.12 | Prépa Peintures + 1ère couche |  | 2d | 2026-02-18 | 2026-02-19 |  | 339d | 0d | start no earlier than 2026-02-18 | LPP |
| 27 | 1.1.2.13 | Distribution élec |  | 2d | 2026-02-20 | 2026-02-23 | 26 | 339d | 0d |  | FAUCHE |
| 28 | 1.1.2.14 | Passage des réseaux |  | 2d | 2026-02-20 | 2026-02-23 | 27SS | 343d |  |  | EIFFAGE |
| 29 | 1.1.2.15 | Raccordement élec |  | 1d | 2026-02-23 | 2026-02-23 | 27FF | 339d | 0d |  | FAUCHE |
| 30 | 1.1.2.16 | Revêtement de sol |  | 3d | 2026-02-24 | 2026-02-26 | 29 | 340d | 0d |  | LPP |
| 31 | 1.1.2.17 | Finitions peintures |  | 2d | 2026-02-25 | 2026-02-26 | 30SS+1d | 340d |  |  | LPP |
| 32 | 1.1.2.18 | Bardage |  | 5d | 2026-02-23 | 2026-02-27 | 29SS | 339d |  |  | POUGNAND |

| ID | WBS | Task | Type | Duration | Start | Finish | Predecessors | Total slack | Free slack | Constraint | Text1 |
| --- | --- | --- | --- | --- | --- | --- | --- | --- | --- | --- | --- |
| 33 | 1.2 | **Bâtiment I** |  | 130d | 2025-08-11 | 2026-02-06 |  | 354d |  |  |  |
| 34 | 1.2.1 | Passage réseaux |  | 2d | 2025-08-11 | 2025-08-12 |  | 452d | 8d | start no earlier than 2025-08-11 | EIFFAGE |
| 35 | 1.2.2 | Plateforme |  | 2d | 2025-08-25 | 2025-08-26 | 34 | 444d | 5d | start no earlier than 2025-08-25 | COLAS |
| 36 | 1.2.3 | Bétonnage dalle Extérieur |  | 2d | 2025-08-27 | 2025-08-28 |  | 470d |  | start no earlier than 2025-08-27 | ALM |
| 37 | 1.2.4 | Pose escalier |  | 5d | 2025-09-03 | 2025-09-09 | 35 | 439d | 0d | start no earlier than 2025-09-03 | ALM |
| 38 | 1.2.5 | Livraison + pose échafaudage |  | 3d | 2025-09-03 | 2025-09-05 |  | 449d | 0d | start no earlier than 2025-09-03 | OLIVIER |
| 39 | 1.2.6 | Couverture |  | 15d | 2025-09-08 | 2025-09-26 | 38 | 449d | 0d |  | OLIVIER |
| 40 | 1.2.7 | Reprise d'étanchéité à faire |  | 2d | 2026-01-29 | 2026-01-30 | 242FF | 359d |  |  | OLIVIER |
| 41 | 1.2.8 | Pose Men EXT (côté Intérieur) |  | 2d | 2025-10-06 | 2025-10-07 |  | 442d |  | start no earlier than 2025-10-06 | GEAY MEN |
| 42 | 1.2.9 | HO/HA | milestone | 0d | 2025-09-26 | 2025-09-26 | 39 | 449d |  |  |  |
| 43 | 1.2.10 | Finalisation des couvertines |  | 3d | 2026-01-28 | 2026-01-30 | 268FF | 354d | 0d | start no earlier than 2026-01-28 | SOPREMA |
| 44 | 1.2.11 | Finalisation des dalles |  | 2d | 2026-02-02 | 2026-02-03 | 43 | 357d |  |  | SOPREMA |
| 45 | 1.2.12 | Fab + Appro garde-corps |  | 20d | 2025-09-15 | 2025-10-10 | 37FS+3d | 439d |  |  | ST ALM |
| 46 | 1.2.13 | Pose Garde-corps toiture Silo |  | 5d | 2026-02-02 | 2026-02-06 | 43 | 354d |  | start no earlier than 2025-10-13 | ALM |
| 47 | 1.2.14 | **RDC** |  | 29d | 2025-08-25 | 2025-10-02 |  | 445d |  |  |  |
| 48 | 1.2.14.1 | Pose Men EXT + volets (côté rue) |  | 4d | 2025-08-25 | 2025-08-28 |  | 469d | 0d | start no earlier than 2025-08-25 | POUGNAND |
| 49 | 1.2.14.2 | Bouchage baies RDC |  | 3d | 2025-08-27 | 2025-08-29 | 48SS+2d | 469d | 0d |  | ALM |
| 50 | 1.2.14.3 | Dépose faïence |  | 1d | 2025-08-27 | 2025-08-27 | 49SS | 471d |  |  | ALM |
| 51 | 1.2.14.4 | **Installation Chaufferie Bois** |  | 23d | 2025-09-01 | 2025-10-01 |  | 446d |  |  |  |
| 52 | 1.2.14.4.1 | Livraison manutention chaudières bois |  | 2d | 2025-09-01 | 2025-09-02 |  | 446d | 0d | start no earlier than 2025-09-01 | EIFFAGE |
| 53 | 1.2.14.4.2 | Pose porte provisoire |  | 1d | 2025-09-02 | 2025-09-02 | 52FF | 467d |  |  | GEAY MEN |
| 54 | 1.2.14.4.3 | Montage |  | 5d | 2025-09-02 | 2025-09-08 | 52SS+1d | 446d | 0d |  | EIFFAGE |
| 55 | 1.2.14.4.4 | Réseaux CVC,Plb |  | 13d | 2025-09-10 | 2025-09-26 | 54FS+1d | 446d | 0d |  | EIFFAGE |
| 56 | 1.2.14.4.5 | Réseaux élec |  | 10d | 2025-09-15 | 2025-09-26 | 55FF | 446d | 0d |  | EIFFAGE |
| 57 | 1.2.14.4.6 | Mise à dispo alimentation élec | milestone | 0d | 2025-09-25 | 2025-09-25 | 56FF-2d, 76SS | 451d |  |  | FAUCHE |
| 58 | 1.2.14.4.7 | Mise en service chaufferie |  | 3d | 2025-09-29 | 2025-10-01 | 56 | 446d | 0d |  | EIFFAGE |
| 59 | 1.2.14.4.8 | arrêt chaudière biofioul | milestone | 0d | 2025-10-01 | 2025-10-01 | 58FS-1d | 447d |  |  | EIFFAGE |

| ID | WBS | Task | Type | Duration | Start | Finish | Predecessors | Total slack | Free slack | Constraint | Text1 |
| --- | --- | --- | --- | --- | --- | --- | --- | --- | --- | --- | --- |
| 60 | 1.2.14.5 | **Local adoucisseur** |  | 21d | 2025-09-04 | 2025-10-02 |  | 445d |  |  |  |
| 61 | 1.2.14.5.1 | Fermeture façade |  | 3d | 2025-09-08 | 2025-09-10 |  | 460d | 0d | start no earlier than 2025-09-08 | ALM |
| 62 | 1.2.14.5.2 | Séparation Local adoucisseur (maçon) |  | 3d | 2025-09-08 | 2025-09-10 | 61SS | 460d | 15d |  | ALM |
| 63 | 1.2.14.5.3 | Installation adoucisseur |  | 6d | 2025-09-04 | 2025-09-11 |  | 460d |  | start no earlier than 2025-09-04 |  |
| 64 | 1.2.14.5.4 | Livraison + pose Men INT |  | 1d | 2025-09-30 | 2025-09-30 | 62SS | 447d |  | start no earlier than 2025-09-30 | FGV |
| 65 | 1.2.14.5.5 | Distrib réseau élec |  | 3d | 2025-09-30 | 2025-10-02 | 62SS+1d | 445d |  | start no earlier than 2025-09-30 | FAUCHE |
| 66 | 1.2.15 | **R+1** |  | 21d | 2025-09-11 | 2025-10-09 |  | 440d |  |  |  |
| 67 | 1.2.15.1 | Bouchement de la baie |  | 2d | 2025-09-11 | 2025-09-15 | 68SF | 459d |  |  | ALM |
| 68 | 1.2.15.2 | Pose chappe + isolant |  | 2d | 2025-09-15 | 2025-09-16 | 126SS | 440d | 0d |  | LPP |
| 69 | 1.2.15.3 | Tracé cloison | milestone | 0d | 2025-09-17 | 2025-09-17 | 68 | 440d | 0d | start no earlier than 2025-09-17 | GOURAUD |
| 70 | 1.2.15.4 | Cloisonnement/doublage |  | 5d | 2025-09-17 | 2025-09-23 | 69 | 440d | 0d | start no earlier than 2025-09-01 | GOURAUD |
| 71 | 1.2.15.5 | Appro + pose menuiserie INT |  | 1d | 2025-09-17 | 2025-09-17 | 70SS | 456d |  |  | FGV |
| 72 | 1.2.15.6 | Distribution élec |  | 5d | 2025-09-17 | 2025-09-23 | 70SS | 452d | 0d | start no earlier than 2025-09-15 | FAUCHE |
| 73 | 1.2.15.7 | Distribution CVC/Plb |  | 5d | 2025-09-17 | 2025-09-23 | 72SS | 452d | 0d |  | EIFFAGE |
| 74 | 1.2.15.8 | Bon à fermer cloison | milestone | 0d | 2025-09-22 | 2025-09-22 | 72FS-2d, 73FS-2d | 454d |  |  |  |
| 75 | 1.2.15.9 | Prépa Peintures + 1ère couche |  | 5d | 2025-09-24 | 2025-09-30 | 70 | 440d | 0d |  | LPP |
| 76 | 1.2.15.10 | Pose tableau élec + raccordement |  | 5d | 2025-09-25 | 2025-10-01 | 75SS+1d | 446d | 0d |  | FAUCHE |
| 77 | 1.2.15.11 | Pose terminaux (Cfo,Cfa, CVC/Plb) |  | 2d | 2025-09-30 | 2025-10-01 | 75FS-1d | 440d | 0d |  | EIFFAGE/FAUCHE |
| 78 | 1.2.15.12 | Revêtement de sol |  | 4d | 2025-10-02 | 2025-10-07 | 77 | 440d | 0d |  | LPP |
| 79 | 1.2.15.13 | Pose mobilier (kitchenette) |  | 2d | 2025-10-08 | 2025-10-09 | 78 | 440d |  |  | FGV |
| 80 | 1.2.15.14 | Pose sanitaires |  | 2d | 2025-10-08 | 2025-10-09 | 78 | 440d |  |  |  |
| 81 | 1.2.15.15 | Mise à dispo R+1 | milestone | 0d | 2025-10-07 | 2025-10-07 | 78 | 442d |  |  |  |
| 82 | 2 | **Phase 2** |  | 191d | 2025-08-18 | 2026-05-11 |  | 170d |  |  |  |
| 83 | 2.1 | **Bâtiment H** |  | 179d | 2025-08-18 | 2026-04-23 |  | 300d |  |  |  |
| 84 | 2.1.1 | **RDC** |  | 169d | 2025-09-01 | 2026-04-23 |  | 300d |  |  |  |
| 85 | 2.1.1.1 | Distribution réseaux évac (EU, EP) |  | 3d | 2025-09-17 | 2025-09-19 | 126 | 454d |  |  | EIFFAGE |
| 86 | 2.1.1.2 | Fab + Appro Men EXT |  | 30d | 2025-09-01 | 2025-10-13 | 87SF | 439d |  |  | POUGNAND |
| 87 | 2.1.1.3 | Pose Men bardage à clairevoie |  | 3d | 2025-10-13 | 2025-10-16 | 92SF | 433d | 0d |  | POUGNAND |

| ID | WBS | Task | Type | Duration | Start | Finish | Predecessors | Total slack | Free slack | Constraint | Text1 |
| --- | --- | --- | --- | --- | --- | --- | --- | --- | --- | --- | --- |
| 88 | 2.1.1.4 | **Recalage d'intervention POUGNAND** |  | 10d | 2025-11-24 | 2025-12-05 |  | 399d |  |  |  |
| 89 | 2.1.1.4.1 | Finalisation bardage extérieur |  | 3d | 2025-11-24 | 2025-11-26 | 87 | 406d |  | start no earlier than 2025-11-24 | POUGNAND |
| 90 | 2.1.1.4.2 | Finalisation des encadrements |  | 5d | 2025-12-01 | 2025-12-05 |  | 399d | 0d | start no earlier than 2025-12-01 | POUGNAND |
| 91 | 2.1.1.4.3 | Dépose du bois entre le bâtiment A et H au sol |  | 1d | 2025-12-01 | 2025-12-01 | 90SS | 403d |  |  | POUGNAND |
| 92 | 2.1.1.5 | Reprise des trottoirs (bordures, enrobés) |  | 10d | 2025-10-16 | 2025-10-30 | 95SF | 426d | 0d |  | COLAS |
| 93 | 2.1.1.6 | Aménagement RDC |  | 10d | 2025-10-20 | 2025-10-31 | 95FF | 424d |  |  | COLAS |
| 94 | 2.1.1.7 | Préparation revêtement |  | 5d | 2025-10-23 | 2025-10-30 | 95SF | 426d |  |  | COLAS |
| 95 | 2.1.1.8 | coulage béton désactivé |  | 2d | 2025-10-30 | 2025-10-31 |  | 417d | 0d | finish no earlier than 2025-10-31 | COLAS |
| 96 | 2.1.1.9 | Mise à dispo 1ère moitié terrasse Nord-Ouest Bât B | milestone | 0d | 2025-10-31 | 2025-10-31 | 95 | 417d | 0d |  | COLAS |
| 97 | 2.1.1.10 | Fab + Appro Men EXT |  | 30d | 2025-09-22 | 2025-11-03 | 98SF | 424d |  |  | GEAY MEN |
| 98 | 2.1.1.11 | Pose Men EXT (local pharmacie) |  | 3d | 2025-11-03 | 2025-11-05 | 96 | 421d | 0d |  | GEAY MEN |
| 99 | 2.1.1.12 | Pose grilles + portail |  | 7d | 2025-11-03 | 2025-11-11 | 96 | 417d |  |  | ALM |
| 100 | 2.1.1.13 | Pose grille |  | 2d | 2026-02-02 | 2026-02-03 |  | 357d |  | start no earlier than 2026-02-02 | ALM |
| 101 | 2.1.1.14 | Reprise EU/EP |  | 4d | 2026-02-09 | 2026-02-12 | 242FS+5d | 350d |  | start no earlier than 2026-01-05 | COLAS |
| 102 | 2.1.1.15 | **Finition de sol** |  | 8d | 2026-03-03 | 2026-03-12 |  | 300d | 0d |  | COLAS |
| 103 | 2.1.1.15.1 | Coffrage |  | 1d | 2026-03-03 | 2026-03-04 | 104SF | 307d |  |  |  |
| 104 | 2.1.1.15.2 | Béton lavé |  | 2d | 2026-03-04 | 2026-03-05 | 201 | 300d | 0d |  |  |
| 105 | 2.1.1.15.3 | Temps de séchage |  | 5d | 2026-03-06 | 2026-03-12 | 104 | 300d |  |  |  |
| 106 | 2.1.1.15.4 | Terre végétale |  | 3d | 2026-03-06 | 2026-03-10 | 104 | 301d | 0d |  |  |
| 107 | 2.1.1.15.5 | Jardinière |  | 1d | 2026-03-11 | 2026-03-11 | 106 | 301d |  |  |  |
| 108 | 2.1.1.16 | Habillage réseaux EXT |  | 5d | 2026-03-13 | 2026-03-19 | 102 | 300d | 0d |  | ALM |
| 109 | 2.1.1.17 | Pose éclairage EXT |  | 3d | 2026-03-20 | 2026-03-24 | 108 | 300d | 0d |  | FAUCHE |
| 110 | 2.1.1.18 | **stabilisé calcaire** |  | 3d | 2026-03-24 | 2026-03-26 |  | 300d | 0d |  | COLAS |
| 111 | 2.1.1.18.1 | Réglage avant stabilisé |  | 1d | 2026-03-24 | 2026-03-24 | 109FF | 300d | 0d |  |  |
| 112 | 2.1.1.18.2 | Exécution du stabilisé |  | 2d | 2026-03-25 | 2026-03-26 | 111 | 300d |  |  |  |
| 113 | 2.1.1.19 | Parement Extérieur |  | 10d | 2026-03-27 | 2026-04-09 | 110 | 300d | 0d | start no earlier than 2026-03-23 | ALM |
| 114 | 2.1.1.20 | Débachage stabilité + nivellement terre végétale | milestone | 0d | 2026-04-09 | 2026-04-09 | 113 | 300d | 0d |  | COLAS |
| 115 | 2.1.1.21 | Végétalisation |  | 10d | 2026-04-10 | 2026-04-23 | 114 | 300d |  |  | COLAS |

| ID | WBS | Task | Type | Duration | Start | Finish | Predecessors | Total slack | Free slack | Constraint | Text1 |
| --- | --- | --- | --- | --- | --- | --- | --- | --- | --- | --- | --- |
| 116 | 2.1.2 | **R+1** |  | 147d | 2025-08-18 | 2026-03-10 |  | 332d |  |  |  |
| 117 | 2.1.2.1 | Pose MOB |  | 10d | 2025-08-18 | 2025-08-29 |  | 420d | 0d | start no earlier than 2025-08-18 | POUGNAND |
| 118 | 2.1.2.2 | Complément MOB + habillage Men EXT |  | 7d | 2025-11-03 | 2025-11-11 | 131SS | 417d |  |  | POUGNAND |
| 119 | 2.1.2.3 | Tour d'accès |  | 5d | 2025-08-25 | 2025-08-29 | 117FS-5d | 420d | 5d |  | SOPREMA |
| 120 | 2.1.2.4 | Etanchéité en toiture |  | 5d | 2025-09-08 | 2025-09-12 | 119 | 415d | 0d | start no earlier than 2025-09-08 | SOPREMA |
| 121 | 2.1.2.5 | **Recalage d'intervention SOPREMA** |  | 50d | 2025-12-15 | 2026-02-20 |  | 344d |  |  |  |
| 122 | 2.1.2.5.1 | Pose des couvertines et EP |  | 5d | 2025-12-15 | 2025-12-19 |  | 389d |  | start no earlier than 2025-12-15 | SOPREMA |
| 123 | 2.1.2.5.2 | Ouverture en toiture + couvertine a finalisé |  | 4d | 2026-01-20 | 2026-01-23 |  | 364d |  | start no earlier than 2026-01-20 | SOPREMA |
| 124 | 2.1.2.5.3 | Exécution des bandes de rives |  | 4d | 2026-02-17 | 2026-02-20 |  | 344d |  | start no earlier than 2026-02-17 |  |
| 125 | 2.1.2.6 | Fermeture provisoire des baies |  | 3d | 2025-09-01 | 2025-09-03 | 117 | 466d |  |  | GEAY MEN |
| 126 | 2.1.2.7 | Pose isolant au sol + réseaux sous chappe |  | 2d | 2025-09-15 | 2025-09-16 | 120 | 415d | 0d |  | EIFFAGE/LPP |
| 127 | 2.1.2.8 | Création chappe |  | 2d | 2025-09-17 | 2025-09-18 | 126 | 415d | 1d |  | LPP |
| 128 | 2.1.2.9 | Pose des cloisons/doublage |  | 10d | 2025-09-22 | 2025-10-03 | 127 | 414d | 0d | start no earlier than 2025-09-22 | GOURAUD |
| 129 | 2.1.2.10 | Mise à dispo cloison (1ère moitié - EST) | milestone | 0d | 2025-09-26 | 2025-09-26 | 128SS+5d | 414d | 0d |  | GOURAUD |
| 130 | 2.1.2.11 | Mise à dispo cloison (2nd moitié - OUEST) | milestone | 0d | 2025-10-03 | 2025-10-03 | 128 | 444d |  |  | GOURAUD |
| 131 | 2.1.2.12 | Livraison + pose Men EXT |  | 5d | 2025-11-03 | 2025-11-07 | 128 | 417d | 0d | start no earlier than 2025-11-03 | GEAY MEN |
| 132 | 2.1.2.13 | Fab + appro Men INT |  | 25d | 2025-08-20 | 2025-09-23 |  | 449d | 0d | start no earlier than 2025-08-20 | FGV |
| 133 | 2.1.2.14 | Livraison + pose Men INT |  | 3d | 2025-09-24 | 2025-09-26 | 132, 128SS+2d | 449d |  |  | FGV |
| 134 | 2.1.2.15 | **Recalage intervention FGV** |  | 8d | 2026-01-19 | 2026-01-28 |  | 361d |  |  |  |
| 135 | 2.1.2.15.1 | Livraison + pose Men INT |  | 3d | 2026-01-19 | 2026-01-21 | 156 | 361d | 0d | start no earlier than 2026-01-19 | FGV |
| 136 | 2.1.2.15.2 | Mains courantes et cimaises |  | 3d | 2026-01-26 | 2026-01-28 | 135FS+2d | 361d |  |  | FGV |
| 137 | 2.1.2.16 | Distribution réseaux élec |  | 15d | 2025-09-29 | 2025-10-17 | 129 | 414d | 0d |  | FAUCHE |
| 138 | 2.1.2.17 | Distribution réseaux CVC,Plb |  | 15d | 2025-09-29 | 2025-10-17 | 137SS | 434d | 0d |  | EIFFAGE |
| 139 | 2.1.2.18 | Bon à fermer cloison (cis renforts) | milestone | 0d | 2025-10-07 | 2025-10-07 | 137SS+7d | 414d | 0d |  |  |
| 140 | 2.1.2.19 | 2nd peau |  | 6d | 2025-10-08 | 2025-10-15 | 139, 128 | 414d | 0d |  | GOURAUD |
| 141 | 2.1.2.20 | Pose et raccordement TD |  | 5d | 2025-10-13 | 2025-10-17 | 140SS+3d | 434d |  |  |  |
| 142 | 2.1.2.21 | Prépa peinture + 1ère couche |  | 5d | 2025-10-16 | 2025-10-22 | 140 | 414d | 0d |  | LPP |
| 143 | 2.1.2.22 | Bon à fermer faux plafond (struct) | milestone | 0d | 2025-10-17 | 2025-10-17 | 137, 138 | 434d |  |  |  |
| 144 | 2.1.2.23 | Pose structure faux plafond |  | 5d | 2025-10-20 | 2025-10-24 | 142SS+2d | 426d | 60d |  | GOURAUD |
| 145 | 2.1.2.24 | Pose des faux-plafond |  | 10d | 2025-12-01 | 2025-12-12 |  | 389d | 0d | start no earlier than 2025-12-01 | FGV |

| ID | WBS | Task | Type | Duration | Start | Finish | Predecessors | Total slack | Free slack | Constraint | Text1 |
| --- | --- | --- | --- | --- | --- | --- | --- | --- | --- | --- | --- |
| 146 | 2.1.2.25 | **Recalage d'intervention GOURAUD** |  | 30d | 2025-12-15 | 2026-01-23 |  | 364d |  |  |  |
| 147 | 2.1.2.25.1 | Finir placo circulation |  | 5d | 2025-12-15 | 2025-12-19 | 145 | 389d |  | start no earlier than 2025-12-15 | GOURAUD |
| 148 | 2.1.2.25.2 | Jonction entre Bât G et H |  | 5d | 2026-01-19 | 2026-01-23 | 156 | 364d |  |  | GOURAUD |
| 149 | 2.1.2.26 | Pose terminaux (Cfo,Cfa, CVC/PLb) |  | 5d | 2026-01-15 | 2026-01-21 | 144FS-2d | 366d |  | finish no earlier than 2026-01-21 | EIFFAGE/FAUCHE |
| 150 | 2.1.2.27 | Revêtement mural |  | 7d | 2025-10-27 | 2025-11-04 | 142 | 412d | 0d | start no earlier than 2025-10-27 | LPP |
| 151 | 2.1.2.28 | Revêtement sol |  | 10d | 2025-11-03 | 2025-11-14 | 150FS-2d | 414d |  |  | LPP |
| 152 | 2.1.2.29 | Finitions peintures |  | 7d | 2025-11-10 | 2025-11-18 | 150FS+3d | 412d |  |  | LPP |
| 153 | 2.1.2.30 | **Recalage d'intervention LPP (Circulation)** |  | 47d | 2025-11-28 | 2026-02-02 |  | 358d |  |  |  |
| 154 | 2.1.2.30.1 | couche de propreté local électrique |  | 1d | 2025-11-28 | 2025-11-28 |  | 404d |  | start no earlier than 2025-11-28 | LPP |
| 155 | 2.1.2.30.2 | Prépration des murs, toile et 1ère couche Circulation |  | 7d | 2026-01-06 | 2026-01-14 | 169FF | 346d | 0d |  | LPP |
| 156 | 2.1.2.30.3 | Revêtement sol |  | 10d | 2026-01-05 | 2026-01-16 | 170FF | 361d | 0d |  | LPP |
| 157 | 2.1.2.30.4 | Finitions peintures Murs et portes |  | 10d | 2026-01-20 | 2026-02-02 | 155FS+3d | 346d | 0d |  | LPP |
| 158 | 2.1.2.31 | Pose afficheurs, enjoliveurs élec/CVC |  | 2d | 2026-02-03 | 2026-02-04 | 157 | 346d | 0d |  | EIFFAGE/FAUCHE |
| 159 | 2.1.2.32 | Blanchiment |  | 3d | 2026-02-05 | 2026-02-09 | 158 | 346d | 0d |  | GOURAUD |
| 160 | 2.1.2.33 | Pose mobiliers (placards, tablettes,…) |  | 7d | 2026-02-10 | 2026-02-18 | 159 | 346d |  |  | FGV |
| 161 | 2.1.2.34 | **Salles de bain/sanitaires** |  | 72d | 2025-10-23 | 2026-01-30 |  | 359d |  |  |  |
| 162 | 2.1.2.34.1 | Revêtement mural |  | 6d | 2025-10-23 | 2025-10-30 | 142 | 422d | 0d | start no earlier than 2025-10-23 | LPP |
| 163 | 2.1.2.34.2 | Revêtement sol |  | 5d | 2025-10-29 | 2025-11-04 | 162FS-2d | 422d |  |  | LPP |
| 164 | 2.1.2.34.3 | Pose appareillages sanitaires |  | 7d | 2026-01-19 | 2026-01-27 | 170 | 359d | 0d |  | EIFFAGE |
| 165 | 2.1.2.34.4 | Pose mobilier/équip sanitaires |  | 3d | 2026-01-28 | 2026-01-30 | 164 | 359d |  |  | EIFFAGE/FAUCHE |
| 166 | 2.1.2.35 | **Recalage d'intervention LPP (Chambres)** |  | 35d | 2025-12-01 | 2026-01-16 |  | 363d |  |  |  |
| 167 | 2.1.2.35.1 | reprise pente des douches |  | 3d | 2025-12-01 | 2025-12-03 |  | 401d |  | start no earlier than 2025-12-01 | LPP |
| 168 | 2.1.2.35.2 | prépration des murs, toile et 1ère couche Chambres |  | 10d | 2025-12-08 | 2025-12-19 |  | 358d | 12d | start no earlier than 2025-12-08 | LPP |
| 169 | 2.1.2.35.3 | Revêtement mural |  | 6d | 2026-01-07 | 2026-01-14 | 168 | 346d | 0d | finish no earlier than 2026-01-14 | LPP |
| 170 | 2.1.2.35.4 | Revêtement sol |  | 5d | 2026-01-12 | 2026-01-16 | 169FS-3d | 359d | 0d |  | LPP |
| 171 | 2.1.2.36 | Distribution Alim TD + mise en service |  | 2d | 2026-02-03 | 2026-02-05 | 363SF | 347d | 0d |  | FAUCHE |
| 172 | 2.1.2.37 | Essais et mise en service |  | 8d | 2026-02-06 | 2026-02-17 | 171FS+1d | 347d |  |  | FAUCHE |
| 173 | 2.1.2.38 | Mise en chauffe bât H | milestone | 0d | 2026-02-09 | 2026-02-09 | 301 | 347d | 0d | start no earlier than 2026-02-09 | EIFFAGE |
| 174 | 2.1.2.39 | Essais et mise en service |  | 7d | 2026-03-02 | 2026-03-10 | 173 | 332d |  | start no earlier than 2026-03-02 | EIFFAGE |

| ID | WBS | Task | Type | Duration | Start | Finish | Predecessors | Total slack | Free slack | Constraint | Text1 |
| --- | --- | --- | --- | --- | --- | --- | --- | --- | --- | --- | --- |
| 175 | 2.2 | **Bâtiment G** |  | 189d | 2025-08-20 | 2026-05-11 |  | 168d |  |  |  |
| 176 | 2.2.1 | **Extérieurs, prépa et préalable GO** |  | 152d | 2025-08-25 | 2026-03-24 |  | 322d |  |  |  |
| 177 | 2.2.1.1 | Plateforme bât G (NORD) |  | 5d | 2025-08-25 | 2025-08-29 |  | 381d | 0d | start no earlier than 2025-08-25 | COLAS |
| 178 | 2.2.1.2 | Réception de la plateforme (NORD) | milestone | 0d | 2025-09-01 | 2025-09-01 | 177 | 381d | 0d | start no earlier than 2025-09-01 | COLAS/ALM |
| 179 | 2.2.1.3 | Déconnexion cuve fioul existante |  | 1d | 2025-08-25 | 2025-08-25 |  | 471d | 0d | start no earlier than 2025-08-25 | EIFFAGE |
| 180 | 2.2.1.4 | Vidange, neutralisation, évacuation |  | 2d | 2025-08-26 | 2025-08-27 | 179 | 471d |  |  | MOA |
| 181 | 2.2.1.5 | Livraison Biofioul |  | 1d | 2025-09-11 | 2025-09-11 | 8FS-2d | 460d |  |  | MOA |
| 182 | 2.2.1.6 | Plateforme bât G (SUD) |  | 5d | 2025-09-22 | 2025-09-26 | 212SS | 449d | 0d |  | COLAS |
| 183 | 2.2.1.7 | Réception de la plateforme (SUD) | milestone | 0d | 2025-09-26 | 2025-09-26 | 182 | 449d |  |  | COLAS/ALM |
| 184 | 2.2.1.8 | Dépose échafaudage intérieur |  | 7d | 2026-02-06 | 2026-02-16 |  | 338d | 0d | start no earlier than 2026-02-06 | OLIVIER |
| 185 | 2.2.1.9 | **réseaux enterrés (2ème partie bat G)** |  | 7d | 2026-02-16 | 2026-02-24 |  | 300d |  |  |  |
| 186 | 2.2.1.9.1 | Tranchée vers local /s Station bat G |  | 1d | 2026-02-16 | 2026-02-16 |  | 300d | 0d | start no earlier than 2026-02-16 | COLAS |
| 187 | 2.2.1.9.2 | Passage rsx enterrés (cheminement) |  | 0.5d | 2026-02-16 | 2026-02-16 | 186FF | 348d |  | start no earlier than 2026-02-09 | EIFFAGE |
| 188 | 2.2.1.9.3 | Pose pompes de relevage |  | 0.5d | 2026-02-16 | 2026-02-16 | 186SS+0.5d | 348d |  |  | COLAS |
| 189 | 2.2.1.9.4 | Raccordement réseau EP et EU entre Bât G & C |  | 4d | 2026-02-17 | 2026-02-20 | 186 | 300d | 0d |  | COLAS |
| 190 | 2.2.1.9.5 | Raccordement EP sous domaine public |  | 3d | 2026-02-16 | 2026-02-18 | 186SS | 342d | 0d |  | COLAS |
| 191 | 2.2.1.9.6 | Raccordement rsx EP et EU sous voirie d'accès |  | 4d | 2026-02-19 | 2026-02-24 | 190 | 342d |  |  | COLAS |
| 192 | 2.2.1.10 | Pose des gouttières, rives etc.. |  | 10d | 2026-02-09 | 2026-02-20 | 184SS+1d | 344d |  |  | SOPREMA |
| 193 | 2.2.1.11 | Descente en façade |  | 3d | 2026-02-12 | 2026-02-16 | 184FF | 338d | 0d |  | SOPREMA |
| 194 | 2.2.1.12 | Parements EXT |  | 10d | 2026-02-17 | 2026-03-02 | 193 | 338d | 0d | start no earlier than 2026-02-11 | ALM |
| 195 | 2.2.1.13 | Raccord bardage |  | 5d | 2026-02-17 | 2026-02-23 | 194SS | 343d |  |  | POUGNAND |
| 196 | 2.2.1.14 | **Nivellement, bordures** |  | 10d | 2026-02-23 | 2026-03-06 | 186 | 300d |  |  | COLAS |
| 197 | 2.2.1.14.1 | Cordure P1 + coffrage |  | 3d | 2026-02-23 | 2026-02-25 | 189 | 300d | 0d |  |  |
| 198 | 2.2.1.14.2 | Bordure T2 |  | 3d | 2026-03-04 | 2026-03-06 | 202 | 325d | 0d |  |  |

| ID | WBS | Task | Type | Duration | Start | Finish | Predecessors | Total slack | Free slack | Constraint | Text1 |
| --- | --- | --- | --- | --- | --- | --- | --- | --- | --- | --- | --- |
| 199 | 2.2.1.15 | **Enrobés, bétons désactivés** |  | 19d | 2026-02-26 | 2026-03-24 |  | 300d |  |  | COLAS |
| 200 | 2.2.1.15.1 | Préparation zone béton lavé |  | 2d | 2026-02-26 | 2026-02-27 | 197 | 300d | 0d |  |  |
| 201 | 2.2.1.15.2 | Coulage béton lavé et lavage |  | 2d | 2026-03-02 | 2026-03-03 | 200 | 300d | 0d |  |  |
| 202 | 2.2.1.15.3 | Béton balayé sur partie publique |  | 2d | 2026-03-02 | 2026-03-03 | 201SS | 325d | 0d |  |  |
| 203 | 2.2.1.15.4 | Temps de séchage |  | 5d | 2026-03-04 | 2026-03-10 | 201, 202 | 325d | 0d |  |  |
| 204 | 2.2.1.15.5 | Terre végétale |  | 2d | 2026-03-09 | 2026-03-10 | 198 | 325d | 0d |  |  |
| 205 | 2.2.1.15.6 | Réglage voirie |  | 5d | 2026-03-11 | 2026-03-17 | 204, 203 | 325d | 0d |  |  |
| 206 | 2.2.1.15.7 | Enduit de cure |  | 1d | 2026-03-18 | 2026-03-18 | 205 | 325d | 3d |  |  |
| 207 | 2.2.1.15.8 | Enrobé |  | 1d | 2026-03-24 | 2026-03-24 | 206 | 322d |  | start no earlier than 2026-03-24 |  |
| 208 | 2.2.2 | **GO/CC** |  | 158d | 2025-08-20 | 2026-03-27 |  | 319d |  |  |  |
| 209 | 2.2.2.1 | Terrassement, fondations |  | 10d | 2025-09-01 | 2025-09-12 | 178 | 381d | 0d |  | ALM |
| 210 | 2.2.2.2 | Réseau sous dalle |  | 8d | 2025-09-15 | 2025-09-24 | 211SS | 381d | 0d |  | ALM |
| 211 | 2.2.2.3 | Elevation sous bassement cis maçon |  | 10d | 2025-09-15 | 2025-09-26 | 209SS+10d | 381d | 0d |  | ALM |
| 212 | 2.2.2.4 | Dalle portée + isolant |  | 7d | 2025-09-22 | 2025-09-30 | 210SS+5d | 381d | 0d |  | ALM |
| 213 | 2.2.2.5 | Etanchéité /s bassement + drain |  | 7d | 2025-09-25 | 2025-10-03 | 210 | 444d |  |  | SOPREMA |
| 214 | 2.2.2.6 | Elévation (voile, poteau, poutre, maçon.) |  | 13d | 2025-10-01 | 2025-10-17 | 212 | 381d | 0d |  | ALM |
| 215 | 2.2.2.7 | suivi lots tech incorpo |  | 5d | 2025-10-01 | 2025-10-31 | 214SS | 424d |  |  | EIFFAGE/FAUCHE |
| 216 | 2.2.2.8 | PH RDC |  | 17d | 2025-10-09 | 2025-10-31 | 214FS-7d | 381d | 2d |  | ALM |
| 217 | 2.2.2.9 | Mise à dispo PH (Nord) pour MOB | milestone | 0d | 2025-10-31 | 2025-10-31 | 216SS+10d | 375d | 0d | start no earlier than 2025-10-31 | ALM |
| 218 | 2.2.2.10 | Mise à dispo PH (Sud) pour MOB | milestone | 0d | 2025-11-07 | 2025-11-07 | 216FS+2d | 386d | 18d | start no earlier than 2025-11-07 | ALM |
| 219 | 2.2.2.11 | Désétaiement PH file 1 à 6 |  | 5d | 2025-11-24 | 2025-11-28 | 216FS-5d | 375d | 0d | start no earlier than 2025-11-24 | ALM |
| 220 | 2.2.2.12 | Finitions prédalle |  | 5d | 2025-12-01 | 2025-12-05 | 219 | 399d | 0d |  | ALM |
| 221 | 2.2.2.13 | Désétaiement PH file 6 à 8 |  | 5d | 2025-11-27 | 2025-12-03 | 219FS-2d | 396d | 0d |  | ALM |
| 222 | 2.2.2.14 | Finitions prédalle |  | 5d | 2025-12-04 | 2025-12-10 | 221 | 396d | 0d |  | ALM |
| 223 | 2.2.2.15 | Mise à dispo lots tech/2nd oeuvre (Nord) | milestone | 0d | 2025-12-05 | 2025-12-05 | 220 | 399d |  |  | ALM |
| 224 | 2.2.2.16 | Mise à dispo lots tech/2nd oeuvre (Sud) | milestone | 0d | 2025-12-10 | 2025-12-10 | 222 | 396d |  |  | ALM |
| 225 | 2.2.2.17 | Validation Etudes/ commande MOB + fermette | milestone | 0d | 2025-09-08 | 2025-09-08 |  | 424d | 0d | start no earlier than 2025-09-08 | MOE |
| 226 | 2.2.2.18 | Délai d'appro MOB + fermettes |  | 40d | 2025-09-08 | 2025-11-03 | 225, 227SF | 424d |  |  | POUGNAND |
| 227 | 2.2.2.19 | Pose MOB file 1 à 6 |  | 10d | 2025-11-03 | 2025-11-14 |  | 374d | 0d | start no earlier than 2025-11-03 | POUGNAND |
| 228 | 2.2.2.20 | Pose MOB file 6 à 8 |  | 15d | 2025-11-10 | 2025-11-28 | 227SS+5d | 404d |  |  | POUGNAND |

| ID | WBS | Task | Type | Duration | Start | Finish | Predecessors | Total slack | Free slack | Constraint | Text1 |
| --- | --- | --- | --- | --- | --- | --- | --- | --- | --- | --- | --- |
| 229 | 2.2.2.21 | **Recalage d'intervention POUGNAND** |  | 75d | 2025-11-24 | 2026-03-06 |  | 334d |  |  |  |
| 230 | 2.2.2.21.1 | Pose MOB file 1 à 6 |  | 10d | 2025-11-24 | 2025-12-05 | 217FS+16d | 375d | 0d | start no earlier than 2025-11-03 | POUGNAND |
| 231 | 2.2.2.21.2 | Pose bardage et fermette jusqu'au JD |  | 7d | 2025-11-24 | 2025-12-02 | 230SS | 394d | 0d |  | POUGNAND |
| 232 | 2.2.2.21.3 | Fin de la pose bardage et fermette |  | 8d | 2025-12-03 | 2025-12-12 | 231 | 394d |  |  | POUGNAND |
| 233 | 2.2.2.21.4 | Chevêtres en façade de la salle à manger |  | 2d | 2026-01-05 | 2026-01-06 |  | 350d | 0d | start no earlier than 2026-01-05 | POUGNAND |
| 234 | 2.2.2.21.5 | Pose MOB file 6 à 8 |  | 15d | 2025-12-25 | 2026-01-14 | 218FS+16d | 368d | 0d | finish no earlier than 2026-01-14 | POUGNAND |
| 235 | 2.2.2.21.6 | Jonction avec le bâtiment C |  | 3d | 2026-01-15 | 2026-01-19 | 234 | 368d |  | start no earlier than 2026-01-12 | POUGNAND/OLIVIER |
| 236 | 2.2.2.21.7 | Finition des bardages |  | 5d | 2026-01-26 | 2026-01-30 | 242FF | 359d |  |  | POUGNAND |
| 237 | 2.2.2.21.8 | Travaux bâtiment H |  | 7d | 2026-02-16 | 2026-02-24 |  | 334d | 0d | start no earlier than 2026-02-16 | POUGNAND |
| 238 | 2.2.2.21.9 | Travaux bâtiment D |  | 4d | 2026-02-16 | 2026-02-19 | 237SS | 345d |  |  | POUGNAND |
| 239 | 2.2.2.21.10 | Travaux bâtiment G |  | 15d | 2026-02-16 | 2026-03-06 | 237SS | 334d |  |  | POUGNAND |
| 240 | 2.2.2.22 | Couverture |  | 40d | 2025-11-17 | 2026-01-09 | 227 | 374d |  |  | OLIVIER |
| 241 | 2.2.2.23 | **Recalage d'intervention OLIVIER** |  | 85d | 2025-12-01 | 2026-03-27 |  | 319d |  |  |  |
| 242 | 2.2.2.23.1 | **Couverture** |  | 45d | 2025-12-01 | 2026-01-30 | 230FS-5d | 350d | 0d |  | OLIVIER |
| 243 | 2.2.2.23.1.1 | Mise hors d'eau |  | 15d | 2025-12-01 | 2025-12-19 | 230FS-5d | 380d |  |  |  |
| 244 | 2.2.2.23.1.2 | pose des tuiles |  | 20d | 2026-01-05 | 2026-01-30 | 233SS | 350d |  |  |  |
| 245 | 2.2.2.23.2 | pose des crochets d'accès |  | 5d | 2026-02-23 | 2026-02-27 |  | 339d |  | start no earlier than 2026-02-23 |  |
| 246 | 2.2.2.23.3 | pose 3 volets de désenfumage |  | 5d | 2026-02-16 | 2026-02-20 |  | 344d |  | start no earlier than 2026-02-16 |  |
| 247 | 2.2.2.23.4 | pose des descentes pluviales |  | 5d | 2026-03-23 | 2026-03-27 |  | 319d |  | start no earlier than 2026-03-23 |  |
| 248 | 2.2.2.23.5 | Livraison matériel par trémie en toiture |  | 1d | 2026-01-05 | 2026-01-05 | 242SS+25d | 378d |  |  | OLIVIER |
| 249 | 2.2.2.23.6 | HO/HA | milestone | 0d | 2026-01-19 | 2026-01-19 | 242SS+36d | 368d |  |  | OLIVIER |
| 250 | 2.2.2.24 | **PORTAIL D'ENTRÉE** |  | 17d | 2026-03-02 | 2026-03-24 |  | 322d |  |  |  |
| 251 | 2.2.2.24.1 | Terrassement pour passage des fourreaux (cpris remblais) |  | 5d | 2026-03-02 | 2026-03-06 |  | 322d | 0d | start no earlier than 2026-03-02 | COLAS |
| 252 | 2.2.2.24.2 | Exécution des massifs (cpris temps de séchage) |  | 4d | 2026-03-04 | 2026-03-09 | 251SS+2d | 322d | 0d |  | ALM ALLAIN |
| 253 | 2.2.2.24.3 | Exécution des longrines (cpris temps de séchage) |  | 4d | 2026-03-04 | 2026-03-09 | 251SS+2d | 322d | 0d |  | ALM ALLAIN |
| 254 | 2.2.2.24.4 | Pose réseaux élec d'alimentation |  | 3d | 2026-03-06 | 2026-03-10 | 251FS-1d | 332d |  |  | FAUCHE |
| 255 | 2.2.2.24.5 | Temps de séchage massifs et longrines |  | 10d | 2026-03-10 | 2026-03-23 | 252, 253 | 322d | 0d |  | ALM ALLAIN |
| 256 | 2.2.2.24.6 | Pose Portail |  | 2d | 2026-03-23 | 2026-03-24 | 255FS-1d | 322d | 0d |  | GEAY MEN |
| 257 | 2.2.2.24.7 | Raccordement au réseaux élec | milestone | 0d | 2026-03-24 | 2026-03-24 | 256FF | 322d |  |  | GEAY MEN |

| ID | WBS | Task | Type | Duration | Start | Finish | Predecessors | Total slack | Free slack | Constraint | Text1 |
| --- | --- | --- | --- | --- | --- | --- | --- | --- | --- | --- | --- |
| 258 | 2.2.2.25 | **Cuisines** |  | 112d | 2025-08-20 | 2026-01-22 |  | 365d |  |  |  |
| 259 | 2.2.2.25.1 | réseau sous dalle |  | 4d | 2025-08-25 | 2025-08-29 | 260SF-6d | 470d |  |  | ALM |
| 260 | 2.2.2.25.2 | Dalle portée + isolant |  | 8d | 2025-09-08 | 2025-09-18 | 261SF-2d | 456d | 0d |  | ALM |
| 261 | 2.2.2.25.3 | PH RDC |  | 7d | 2025-09-22 | 2025-09-30 |  | 397d | 0d | start no earlier than 2025-09-22 | ALM |
| 262 | 2.2.2.25.4 | Ouverture voiles R+1, dépose balcon |  | 10d | 2025-10-01 | 2025-10-14 | 261 | 429d | 0d |  | ALM |
| 263 | 2.2.2.25.5 | Désétaiement PH Cuisine |  | 5d | 2025-10-22 | 2025-10-28 | 261FS+15d | 397d | 0d |  | ALM |
| 264 | 2.2.2.25.6 | Validation Etudes Charp | milestone | 0d | 2025-08-20 | 2025-08-20 | 265SF | 477d |  |  | MOE |
| 265 | 2.2.2.25.7 | Délai d'appro MOB |  | 40d | 2025-08-20 | 2025-10-15 | 266SF | 437d | 0d |  | POUGNAND |
| 266 | 2.2.2.25.8 | Pose MOB |  | 8d | 2025-10-15 | 2025-10-24 | 262 | 429d | 0d |  | POUGNAND |
| 267 | 2.2.2.25.9 | Etanchéité, couverture toit terrasse |  | 7d | 2025-12-08 | 2025-12-16 | 230 | 383d | 23d |  | SOPREMA |
| 268 | 2.2.2.25.10 | Finition a faire |  | 4d | 2026-01-19 | 2026-01-22 | 267 | 360d | 6d | start no earlier than 2026-01-19 | SOPREMA |
| 269 | 2.2.3 | **RDC - 2nd oeuvres / lots techniques** |  | 93d | 2025-10-27 | 2026-03-04 |  | 336d |  |  |  |
| 270 | 2.2.3.1 | Fab + appro Men EXT |  | 25d | 2025-10-27 | 2025-12-01 | 271SF | 391d | 0d |  | GEAY MEN |
| 271 | 2.2.3.2 | Pose Men EXT |  | 3d | 2025-12-01 | 2025-12-03 | 219 | 389d | 0d |  | GEAY MEN |
| 272 | 2.2.3.3 | Distribution réseaux élec (Cfo/Cfa) |  | 10d | 2026-01-09 | 2026-01-22 | 219 | 346d | 0d | finish no earlier than 2026-01-22 | FAUCHE |
| 273 | 2.2.3.4 | Distribution réseaux CVC/Plb |  | 10d | 2026-01-09 | 2026-01-22 | 272SS | 346d | 0d |  | EIFFAGE |
| 274 | 2.2.3.5 | Bon à fermer cloison | milestone | 0d | 2026-01-16 | 2026-01-16 | 272FS-5d, 273FS-5d | 370d |  |  | EIFFAGE |
| 275 | 2.2.3.6 | Bon à fermer faux plafond | milestone | 0d | 2026-01-22 | 2026-01-22 | 272, 273 | 346d | 0d |  | EIFFAGE |
| 276 | 2.2.3.7 | Fab + appro Men INT |  | 25d | 2025-12-19 | 2026-01-22 | 275FF | 363d | 0d |  | FGV |
| 277 | 2.2.3.8 | Livraison + pose Men INT |  | 2d | 2026-01-23 | 2026-01-26 | 276 | 363d |  |  | FGV |
| 278 | 2.2.3.9 | Doublage, cloisons |  | 10d | 2025-12-01 | 2025-12-12 | 271SS | 389d | 0d |  | GOURAUD |
| 279 | 2.2.3.10 | 2nd peau |  | 5d | 2025-12-15 | 2025-12-19 | 278 | 389d |  |  | GOURAUD |
| 280 | 2.2.3.11 | **Recalage d'intervention GOURAUD** |  | 15d | 2026-01-09 | 2026-01-29 |  | 336d |  |  |  |
| 281 | 2.2.3.11.1 | Doublage, cloisons |  | 10d | 2026-01-09 | 2026-01-22 | 272SS | 336d | 0d |  | GOURAUD |
| 282 | 2.2.3.11.2 | 2nd peau |  | 5d | 2026-01-23 | 2026-01-29 | 281 | 336d | 0d |  | GOURAUD |
| 283 | 2.2.3.12 | Pose et raccordement TD |  | 9d | 2026-01-23 | 2026-02-16 | 282SS, 186FF | 348d |  |  | FAUCHE |
| 284 | 2.2.3.13 | Prépa peinture + 1ère couche |  | 5d | 2026-01-30 | 2026-02-05 | 282 | 336d | 0d |  | LPP |
| 285 | 2.2.3.14 | Pose structure faux plafond |  | 3d | 2026-02-06 | 2026-02-10 | 284, 275 | 336d | 0d |  | GOURAUD |
| 286 | 2.2.3.15 | Faux plafond + isolation |  | 3d | 2026-02-09 | 2026-02-11 | 285SS+1d | 336d | 0d |  | GOURAUD |
| 287 | 2.2.3.16 | Pose terminaux (Cfo,Cfa, CVC) |  | 10d | 2026-02-06 | 2026-02-25 | 285SS, 275 | 341d |  |  | EIFFAGE/FAUCHE |
| 288 | 2.2.3.17 | Revêtement mural |  | 3d | 2026-02-12 | 2026-02-16 | 286 | 336d | 0d |  | LPP |

| ID | WBS | Task | Type | Duration | Start | Finish | Predecessors | Total slack | Free slack | Constraint | Text1 |
| --- | --- | --- | --- | --- | --- | --- | --- | --- | --- | --- | --- |
| 289 | 2.2.3.18 | **Revêtement sol** |  | 6d | 2026-02-17 | 2026-02-24 | 288 | 336d | 0d |  | LPP |
| 290 | 2.2.3.18.1 | Préparation des supports |  | 1d | 2026-02-17 | 2026-02-17 | 288 | 336d | 0d |  |  |
| 291 | 2.2.3.18.2 | Séchage |  | 1d | 2026-02-18 | 2026-02-18 | 290 | 336d | 0d |  |  |
| 292 | 2.2.3.18.3 | Pose du revêtement avec remontée en plinthes |  | 2d | 2026-02-19 | 2026-02-20 | 291 | 336d | 0d |  |  |
| 293 | 2.2.3.18.4 | Soudure |  | 2d | 2026-02-23 | 2026-02-24 | 292 | 336d |  |  |  |
| 294 | 2.2.3.19 | Finitions peintures |  | 3d | 2026-02-25 | 2026-02-27 | 289 | 336d | 0d |  | LPP |
| 295 | 2.2.3.20 | Pose afficheurs, enjoliveurs élec/CVC |  | 2d | 2026-03-02 | 2026-03-03 | 294 | 336d | 0d |  | EIFFAGE/FAUCHE |
| 296 | 2.2.3.21 | Blanchiment |  | 1d | 2026-03-04 | 2026-03-04 | 295 | 336d |  |  | GOURAUD |
| 297 | 2.2.4 | **RDC - LT /station** |  | 52d | 2025-12-01 | 2026-02-10 |  | 352d |  |  |  |
| 298 | 2.2.4.1 | Livraison + installation /s station |  | 10d | 2026-01-19 | 2026-01-30 | 219 | 347d | 0d | start no earlier than 2026-01-19 | EIFFAGE |
| 299 | 2.2.4.2 | Travaux de colorifuge |  | 2d | 2026-02-09 | 2026-02-10 | 173 | 352d |  |  | EIFFAGE |
| 300 | 2.2.4.3 | Mise à dispo alim élec | milestone | 0d | 2026-01-30 | 2026-01-30 | 298 | 347d | 0d | start no earlier than 2026-01-05 | FAUCHE |
| 301 | 2.2.4.4 | Essais mise en service /s station |  | 5d | 2026-02-02 | 2026-02-06 | 300 | 347d | 0d | start no earlier than 2026-01-26 | EIFFAGE |
| 302 | 2.2.4.5 | Mise en peinture du local |  | 1d | 2025-12-01 | 2025-12-01 |  | 403d |  | start no earlier than 2025-12-01 | LPP |
| 303 | 2.2.5 | **RDC Cuisines & R+1 - 2nd oeuvres / lots techniques** |  | 138d | 2025-09-24 | 2026-04-03 |  | 314d |  |  |  |
| 304 | 2.2.5.1 | Fab + appro Men EXT |  | 25d | 2025-09-24 | 2025-10-28 |  | 427d |  | start no earlier than 2025-09-24 | GEAY MEN |
| 305 | 2.2.5.2 | Pose Men EXT |  | 3d | 2025-12-17 | 2025-12-19 | 271FS+9d | 389d |  |  | GEAY MEN |
| 306 | 2.2.5.3 | Distribution réseaux élec (Cfo/Cfa) |  | 15d | 2025-11-10 | 2025-11-28 | 263 | 389d | 0d | start no earlier than 2025-11-10 | FAUCHE |
| 307 | 2.2.5.4 | Distribution réseaux CVC/Plb (cis CTA) |  | 15d | 2025-10-22 | 2025-11-11 | 263SS | 417d |  |  | EIFFAGE |
| 308 | 2.2.5.5 | Doublage, cloisons |  | 10d | 2025-10-03 | 2025-10-16 | 212FS+2d | 435d |  |  | GOURAUD |
| 309 | 2.2.5.6 | Bon à fermer cloison | milestone | 0d | 2025-11-04 | 2025-11-04 | 263SS+10d | 410d | 0d |  | GOURAUD |
| 310 | 2.2.5.7 | Bon à fermer faux plafond | milestone | 0d | 2025-10-28 | 2025-10-28 | 263 | 427d |  |  | GOURAUD |
| 311 | 2.2.5.8 | Livraison + pose Men INT |  | 3d | 2026-01-12 | 2026-01-14 | 309 | 371d |  | start no earlier than 2026-01-12 | FGV |
| 312 | 2.2.5.9 | 2nd peau |  | 5d | 2025-11-05 | 2025-11-11 | 309 | 410d | 0d |  | GOURAUD |
| 313 | 2.2.5.10 | Pose et raccordement TD |  | 7d | 2025-11-27 | 2025-12-05 | 306FS-2d | 389d | 0d |  | FAUCHE |

| ID | WBS | Task | Duration | Start | Finish | Predecessors | Total slack | Free slack | Constraint | Text1 |
| --- | --- | --- | --- | --- | --- | --- | --- | --- | --- | --- |
| 314 | 2.2.5.11 | **Recalage d'intervention FAUCHÉ (Cuisine)** | 67d | 2025-12-08 | 2026-03-10 | 313 | 332d |  |  |  |
| 315 | 2.2.5.11.1 | Distribution Electrique | 10d | 2025-12-08 | 2025-12-19 |  | 389d |  | start no earlier than 2025-12-08 | FAUCHÉ |
| 316 | 2.2.5.11.2 | Encastrements | 6d | 2026-01-07 | 2026-01-14 |  | 371d |  | start no earlier than 2026-01-07 | FAUCHÉ |
| 317 | 2.2.5.11.3 | pose équipements | 5d | 2026-02-27 | 2026-03-05 | 334 | 332d | 0d |  | FAUCHÉ |
| 318 | 2.2.5.11.4 | pose armoire élec et raccordement | 4d | 2026-03-05 | 2026-03-10 | 317FS-1d | 332d |  |  | FAUCHÉ |
| 319 | 2.2.5.12 | **Recalage d'intervention EIFFAGE (Cuisine)** | 72d | 2025-12-01 | 2026-03-10 |  | 332d |  |  |  |
| 320 | 2.2.5.12.1 | Modification réseaux plomberie/chauffage | 5d | 2025-12-01 | 2025-12-05 |  | 394d | 0d | start no earlier than 2025-12-01 | EIFFAGE |
| 321 | 2.2.5.12.2 | pose des réseaux ventil | 5d | 2025-12-08 | 2025-12-12 | 320 | 394d |  |  | EIFFAGE |
| 322 | 2.2.5.12.3 | Pose CTA de compensation | 5d | 2026-02-17 | 2026-02-23 | 332FS+3d | 343d |  |  | EIFFAGE |
| 323 | 2.2.5.12.4 | pose équipements | 5d | 2026-02-27 | 2026-03-05 | 334 | 332d | 0d |  | EIFFAGE |
| 324 | 2.2.5.12.5 | Mise en service | 4d | 2026-03-05 | 2026-03-10 | 323FS-1d | 332d |  |  | EIFFAGE |
| 325 | 2.2.5.13 | Pose panneaux isothermes | 15d | 2026-01-21 | 2026-02-10 |  | 328d | 0d | start no earlier than 2026-01-21 | ERCO |
| 326 | 2.2.5.14 | Finitions (angles, portes,…) | 5d | 2026-02-24 | 2026-03-02 | 334FS-3d | 332d | 0d | start no earlier than 2026-02-24 | ERCO |
| 327 | 2.2.5.15 | installation équipement frigo | 5d | 2026-03-03 | 2026-03-09 | 326 | 333d |  |  | ERCO |
| 328 | 2.2.5.16 | Accompagnemt lots tech (doublage, panneaux iso) | 5d | 2025-11-05 | 2025-11-20 | 312SS | 410d |  |  | EIFFAGE/FAUCHE |
| 329 | 2.2.5.17 | Prépa peinture + 1ère couche | 5d | 2026-01-21 | 2026-01-27 | 325SS | 362d |  |  | LPP |
| 330 | 2.2.5.18 | Revêtement mural | 8d | 2026-02-13 | 2026-02-24 | 333 | 342d |  |  | LPP |
| 331 | 2.2.5.19 | **Revêtement sol** | 12d | 2026-02-11 | 2026-02-26 |  | 328d |  |  | LPP |
| 332 | 2.2.5.19.1 | Préparation des supports | 1d | 2026-02-11 | 2026-02-11 | 325 | 328d | 0d |  |  |
| 333 | 2.2.5.19.2 | Séchage | 1d | 2026-02-12 | 2026-02-12 | 332 | 328d | 0d |  |  |
| 334 | 2.2.5.19.3 | Pose du revêtement avec remontée en plinthes | 10d | 2026-02-13 | 2026-02-26 | 333 | 328d | 0d | start no earlier than 2026-02-13 |  |
| 335 | 2.2.5.19.4 | Soudure | 2d | 2026-02-25 | 2026-02-26 | 334FF | 328d | 0d |  |  |
| 336 | 2.2.5.20 | 2ème couche + Finitions peintures | 10d | 2026-02-26 | 2026-03-11 | 335SS+1d | 328d | 0d |  | LPP |
| 337 | 2.2.5.21 | Ragrégae des locaux du Rdc | 1d | 2026-02-06 | 2026-02-06 |  | 344d | 0d | start no earlier than 2026-02-06 | LPP |
| 338 | 2.2.5.22 | Nettoyage | 2d | 2026-03-12 | 2026-03-13 | 336 | 329d |  |  |  |

| ID | WBS | Task | Type | Duration | Start | Finish | Predecessors | Total slack | Free slack | Constraint | Text1 |
| --- | --- | --- | --- | --- | --- | --- | --- | --- | --- | --- | --- |
| 339 | 2.2.5.23 | **Recalage d'intervention FAUCHÉ** |  | 40d | 2026-02-09 | 2026-04-03 |  | 314d |  |  |  |
| 340 | 2.2.5.23.1 | Pose des chemins de câbles et des réseaux salle à manger |  | 10d | 2026-02-09 | 2026-02-20 | 337 | 344d |  |  | FAUCHÉ |
| 341 | 2.2.5.23.2 | Pose des équipements dans les locaux du RDC |  | 10d | 2026-03-23 | 2026-04-03 | 366 | 314d | 0d |  |  |
| 342 | 2.2.5.23.3 | Pose armoire élec et raccordement |  | 4d | 2026-03-31 | 2026-04-03 | 341FF | 314d |  |  | FAUCHE |
| 343 | 2.2.5.24 | Pose terminaux (Cfo,Cfa, CVC) |  | 3d | 2026-02-16 | 2026-02-18 |  | 336d | 0d | start no earlier than 2026-02-16 | EIFFAGE/FAUCHE |
| 344 | 2.2.5.25 | **Recalage d'intervention EIFFAGE** |  | 33d | 2026-02-16 | 2026-04-01 |  | 316d |  |  |  |
| 345 | 2.2.5.25.1 | Pose réseaux salle à manger |  | 10d | 2026-02-16 | 2026-02-27 | 343SS | 339d |  |  | EIFFAGE |
| 346 | 2.2.5.25.2 | Pose CTA de compensation et extracteurs |  | 5d | 2026-02-19 | 2026-02-25 | 343 | 341d |  |  | EIFFAGE |
| 347 | 2.2.5.25.3 | Pose équipements dans les locaux du RDC |  | 8d | 2026-03-23 | 2026-04-01 | 367FS-10d | 316d |  |  | EIFFAGE |
| 348 | 2.2.5.26 | Pose afficheurs, enjoliveurs élec/CVC |  | 3d | 2026-03-12 | 2026-03-16 | 336 | 328d |  |  | EIFFAGE/FAUCHE |
| 349 | 2.2.5.27 | Pose structure faux plafond |  | 10d | 2026-02-19 | 2026-03-04 | 343 | 336d |  | start no earlier than 2026-02-19 | GOURAUD |
| 350 | 2.2.5.28 | Blanchiment |  | 1d | 2026-03-11 | 2026-03-11 | 336FF | 331d |  |  | GOURAUD |
| 351 | 2.2.5.29 | Pose faux plafond |  | 6d | 2026-03-03 | 2026-03-10 | 326 | 332d |  |  | FGV |
| 352 | 2.2.5.30 | pose coffre bureau |  | 1d | 2026-03-03 | 2026-03-03 | 326 | 332d | 0d |  | FGV |
| 353 | 2.2.5.31 | Pose mobilier |  | 5d | 2026-03-04 | 2026-03-10 | 352 | 332d | 0d |  | FGV |
| 354 | 2.2.5.32 | Pose équipement sanitaires |  | 3d | 2026-03-06 | 2026-03-10 | 353FF | 332d |  |  | EIFFAGE |
| 355 | 2.2.6 | **R+1 - 2nd oeuvres/lots techniques** |  | 138d | 2025-10-20 | 2026-04-29 |  | 296d |  |  |  |
| 356 | 2.2.6.1 | Fab + appro Men EXT |  | 30d | 2025-10-20 | 2025-11-28 | 270SS-5d | 391d | 0d |  | GEAY MEN |
| 357 | 2.2.6.2 | Fab + appro Men INT |  | 25d | 2026-01-05 | 2026-02-09 | 376SF | 354d |  |  | FGV |
| 358 | 2.2.6.3 | **R+1 - 2nd oeuvres/lots tech** |  | 95d | 2025-12-01 | 2026-04-10 |  | 309d |  |  |  |
| 359 | 2.2.6.3.1 | Pose Men EXT |  | 10d | 2025-12-01 | 2025-12-12 | 356 | 391d | 2d | start no earlier than 2025-12-01 | GEAY MEN |
| 360 | 2.2.6.3.2 | Pose dernière fenêtre (Laisser pour appro GOURAUD) |  | 1d | 2026-03-06 | 2026-03-06 |  | 334d |  | start no earlier than 2026-03-06 | GEAY MEN |
| 361 | 2.2.6.3.3 | Création chappe + passage rsx Plb sol |  | 3d | 2025-12-17 | 2025-12-19 | 359 | 389d |  | start no earlier than 2025-12-17 | EIFFAGE/LPP |
| 362 | 2.2.6.3.4 | **Recalage d'intervention LPP** |  | 27d | 2026-02-05 | 2026-03-13 |  | 296d |  |  |  |
| 363 | 2.2.6.3.4.1 | Création chappe |  | 2d | 2026-02-05 | 2026-02-06 |  | 296d | 0d | start no earlier than 2026-02-05 | LPP |
| 364 | 2.2.6.3.4.2 | Séchage dalle |  | 25d | 2026-02-09 | 2026-03-13 | 363 | 299d | 0d |  | LPP |
| 365 | 2.2.6.3.5 | Passage rsx Plb sol |  | 1d | 2026-02-05 | 2026-02-05 | 363SS | 355d |  |  | EIFFAGE |
| 366 | 2.2.6.3.6 | Distribution réseaux élec (Cfo/Cfa) |  | 20d | 2026-02-23 | 2026-03-20 | 383 | 299d | 0d |  | FAUCHE |
| 367 | 2.2.6.3.7 | Distribution réseaux CVC/Plb |  | 30d | 2026-02-23 | 2026-04-03 | 383 | 314d | 0d | start no earlier than 2026-02-23 | EIFFAGE |
| 368 | 2.2.6.3.8 | Bon à fermer cloison (cis renforts) | milestone | 0d | 2026-03-13 | 2026-03-13 | 366FF-5d | 329d |  |  |  |
| 369 | 2.2.6.3.9 | Bon à fermer faux plafond | milestone | 0d | 2026-03-20 | 2026-03-20 | 366FF | 299d | 0d | start no earlier than 2026-01-19 |  |
| 370 | 2.2.6.3.10 | Doublage, cloisons |  | 8d | 2026-01-01 | 2026-01-12 |  | 369d | 0d | start no earlier than 2026-01-01 | GOURAUD |
| 371 | 2.2.6.3.11 | 2nd peau |  | 4d | 2026-01-13 | 2026-01-16 | 370 | 369d |  |  | GOURAUD |

| ID | WBS | Task | Type | Duration | Start | Finish | Predecessors | Total slack | Free slack | Constraint | Text1 |
| --- | --- | --- | --- | --- | --- | --- | --- | --- | --- | --- | --- |
| 372 | 2.2.6.3.12 | **Recalage d'intervention GOURAUD** |  | 30d | 2026-02-09 | 2026-03-20 |  | 299d |  |  |  |
| 373 | 2.2.6.3.12.1 | Doublage, cloisons |  | 15d | 2026-02-09 | 2026-02-27 | 364SS | 299d | 0d | start no earlier than 2026-02-09 | GOURAUD |
| 374 | 2.2.6.3.12.2 | 2nd peau |  | 15d | 2026-02-23 | 2026-03-13 | 373FS-5d | 299d | 0d |  | GOURAUD |
| 375 | 2.2.6.3.12.3 | Réalisation plafond salle à manger |  | 10d | 2026-03-09 | 2026-03-20 | 374FS-5d | 299d | 0d |  | FGV |
| 376 | 2.2.6.3.13 | Livraison + pose Men INT |  | 5d | 2026-02-09 | 2026-02-13 | 373SS | 349d | 0d |  | FGV |
| 377 | 2.2.6.3.14 | Réalisation des plafonds R+1 et RDC (Rdc et douches en priorité) |  | 13d | 2026-03-16 | 2026-04-01 | 374 | 316d |  |  | FGV |
| 378 | 2.2.6.3.15 | Pose appareillages et raccordement TD |  | 15d | 2026-03-23 | 2026-04-10 | 369SS | 299d | 0d |  | FAUCHE |
| 379 | 2.2.6.3.16 | Prépa peinture + 1ère couche |  | 15d | 2026-03-09 | 2026-03-27 | 375SS | 299d | 0d |  | LPP |
| 380 | 2.2.6.3.17 | Pose équipements R+1 et raccordement paillasses |  | 8d | 2026-03-30 | 2026-04-08 | 379 | 299d | 0d |  | EIFFAGE |
| 381 | 2.2.6.4 | **R+1 - Finitions/Aménagements TN** |  | 52d | 2026-02-09 | 2026-04-21 |  | 299d |  |  |  |
| 382 | 2.2.6.4.1 | Habillages et finitions |  | 10d | 2026-03-30 | 2026-04-10 | 379 | 309d |  |  | GEAY MEN |
| 383 | 2.2.6.4.2 | Pose structure faux plafond (Plafond Placo CF et recoupement des combles ) |  | 10d | 2026-02-09 | 2026-02-20 | 373SS | 299d | 0d |  | GOURAUD |
| 384 | 2.2.6.4.3 | isolation soufflée |  | 5d | 2026-02-23 | 2026-02-27 | 383 | 329d | 0d |  | GOURAUD |
| 385 | 2.2.6.4.4 | Réalisation plafond salle à manger |  | 10d | 2026-03-02 | 2026-03-13 | 384 | 329d |  |  | GOURAUD |
| 386 | 2.2.6.4.5 | Pose terminaux (Cfo,Cfa, CVC) |  | 8d | 2026-04-06 | 2026-04-15 | 380SS+5d | 306d |  |  | EIFFAGE/FAUCHE |
| 387 | 2.2.6.4.6 | **Revêtement sol** |  | 25d | 2026-03-02 | 2026-04-03 |  | 296d | 0d |  | LPP |
| 388 | 2.2.6.4.6.1 | Préparation des supports |  | 5d | 2026-03-02 | 2026-03-06 | 363FS+15d | 296d | 0d |  |  |
| 389 | 2.2.6.4.6.2 | Séchage | milestone | 0d | 2026-03-06 | 2026-03-06 | 388 | 296d | 0d |  |  |
| 390 | 2.2.6.4.6.3 | Pose du revêtement avec remontée en plinthes dans les locaux |  | 8d | 2026-03-09 | 2026-03-18 | 389 | 296d | 0d |  |  |
| 391 | 2.2.6.4.6.4 | Pose des sols souples et protection murale des chambres |  | 12d | 2026-03-19 | 2026-04-03 | 390 | 296d | 0d |  |  |
| 392 | 2.2.6.4.6.5 | Soudure |  | 2d | 2026-04-02 | 2026-04-03 | 391FF | 314d |  |  |  |
| 393 | 2.2.6.4.7 | **Recalage d'intervention FGV** |  | 15d | 2026-03-26 | 2026-04-15 |  | 306d |  |  |  |
| 394 | 2.2.6.4.7.1 | Ajustages de portes, Équipement portes décochoc, béquilles, mobiliers |  | 10d | 2026-03-26 | 2026-04-08 | 390FS+5d | 306d | 0d |  | FGV |
| 395 | 2.2.6.4.7.2 | Pose des cimaises & main courantes |  | 7d | 2026-03-30 | 2026-04-07 | 379 | 312d |  |  | FGV |
| 396 | 2.2.6.4.7.3 | Blanchiment des plafonds |  | 7d | 2026-04-06 | 2026-04-14 | 391 | 307d |  |  | FGV |
| 397 | 2.2.6.4.7.4 | Pose mobilier |  | 5d | 2026-04-09 | 2026-04-15 | 394 | 306d |  |  | FGV |
| 398 | 2.2.6.4.8 | Revêtement mural |  | 7d | 2026-04-09 | 2026-04-17 | 406FF | 304d |  |  | LPP |

| ID | WBS | Task | Type | Duration | Start | Finish | Predecessors | Total slack | Free slack | Constraint | Text1 |
| --- | --- | --- | --- | --- | --- | --- | --- | --- | --- | --- | --- |
| 399 | 2.2.6.4.9 | **Salles de bain/sanitaires** |  | 52d | 2026-02-09 | 2026-04-21 |  | 302d |  |  |  |
| 400 | 2.2.6.4.9.1 | Pose struct faux plafond |  | 5d | 2026-02-09 | 2026-02-13 | 383SS | 349d |  |  | GOURAUD |
| 401 | 2.2.6.4.9.2 | **Revêtement sol** |  | 30d | 2026-03-02 | 2026-04-10 | 387SS | 302d | 0d |  | LPP |
| 402 | 2.2.6.4.9.2.1 | Préparation des supports |  | 5d | 2026-03-02 | 2026-03-06 |  | 327d | 0d |  |  |
| 403 | 2.2.6.4.9.2.2 | Séchage | milestone | 0d | 2026-03-06 | 2026-03-06 | 402 | 327d |  |  |  |
| 404 | 2.2.6.4.9.2.3 | Pose du revêtement avec remontée en plinthes |  | 8d | 2026-03-30 | 2026-04-08 | 379 | 302d | 0d |  |  |
| 405 | 2.2.6.4.9.2.4 | Soudure |  | 2d | 2026-04-09 | 2026-04-10 | 404 | 302d | 0d |  |  |
| 406 | 2.2.6.4.9.3 | Revêtement mural |  | 5d | 2026-04-13 | 2026-04-17 | 405 | 304d | 0d |  | LPP |
| 407 | 2.2.6.4.9.4 | Pose appareillages sanitaires |  | 10d | 2026-04-08 | 2026-04-21 | 401FS-3d | 302d | 0d |  | EIFFAGE |
| 408 | 2.2.6.4.9.5 | Pose mobilier/équip sanitaires |  | 5d | 2026-04-15 | 2026-04-21 | 407FF | 302d |  |  |  |
| 409 | 2.2.6.5 | Peinture locaux |  | 20d | 2026-03-19 | 2026-04-15 | 391SS | 296d | 0d |  | LPP |
| 410 | 2.2.6.6 | Finition |  | 7d | 2026-04-16 | 2026-04-24 | 409 | 296d | 0d |  | LPP |
| 411 | 2.2.6.7 | Nettoyage |  | 3d | 2026-04-27 | 2026-04-29 | 410 | 296d |  |  | LPP |
| 412 | 2.2.6.8 | Pose afficheurs, enjoliveurs élec/CVC |  | 8d | 2026-04-15 | 2026-04-24 | 410FF | 299d |  |  | EIFFAGE/FAUCHE |
| 413 | 2.2.6.9 | Essais et mise en service |  | 8d | 2026-04-13 | 2026-04-22 | 380FS+2d | 299d | 0d |  | EIFFAGE |
| 414 | 2.2.6.10 | Réception avec MOE et BC |  | 2d | 2026-04-23 | 2026-04-24 | 413 | 299d |  |  | EIFFAGE/MOE/BC |
| 415 | 2.2.6.11 | Essais et mise en service |  | 9d | 2026-04-13 | 2026-04-23 | 378 | 299d | 0d |  | FAUCHÉ |
| 416 | 2.2.6.12 | Réception avec MOE et BC |  | 1d | 2026-04-24 | 2026-04-24 | 415 | 299d |  |  | FAUCHÉ/MOE/BC |
| 417 | 2.2.7 | OPR |  | 10d | 2026-04-13 | 2026-04-24 |  | 0d |  | start no earlier than 2026-04-13 |  |
| 418 | 2.2.8 | DOE |  | 3d | 2026-04-22 | 2026-04-24 | 417FF | 299d |  |  |  |
| 419 | 2.2.9 | Levées de réserves |  | 10d | 2026-04-20 | 2026-05-01 | 417SS+5d | 0d |  |  |  |
| 420 | 2.2.10 | Réception |  | 5d | 2026-04-28 | 2026-05-04 | 419SS+6d | 0d |  | start no earlier than 2026-03-23 |  |
| 421 | 2.2.11 | Commission de sécurité | milestone | 0d | 2026-05-04 | 2026-05-04 | 420 | 288d | 0d |  |  |
| 422 | 2.2.12 | Remise en état pour ouverture du service |  | 5d | 2026-05-05 | 2026-05-11 | 421 | 288d |  |  |  |

| ID | WBS | Task | Type | Duration | Start | Finish | Predecessors | Total slack | Free slack | Text1 |
| --- | --- | --- | --- | --- | --- | --- | --- | --- | --- | --- |
| 423 | 3 | **Phase 3** |  | 145d | 2026-04-28 | 2026-11-16 |  | 0d |  |  |
| 424 | 3.1 | **Bâtiment B** |  | 142d | 2026-04-28 | 2026-11-11 |  | 0d |  |  |
| 425 | 3.1.1 | Déménagement |  | 5d | 2026-04-28 | 2026-05-04 | 420SS | 0d |  | MOA |
| 426 | 3.1.2 | Isolement de la zone |  | 2d | 2026-05-05 | 2026-05-06 | 425 | 0d |  |  |
| 427 | 3.1.3 | Consignation, dévoiement des réseaux |  | 3d | 2026-05-05 | 2026-05-07 | 425 | 290d |  | EIFFAGE/FAUCHE |
| 428 | 3.1.4 | Pré-curage |  | 8d | 2026-05-07 | 2026-05-18 | 426 | 0d |  |  |
| 429 | 3.1.5 | **Désamiantage (RDC, R+1)** |  | 30d | 2026-05-13 | 2026-06-23 |  | 0d |  |  |
| 430 | 3.1.5.1 | confinement |  | 5d | 2026-05-13 | 2026-05-19 | 428FS-4d | 0d |  | VALGO |
| 431 | 3.1.5.2 | désamiantage |  | 20d | 2026-05-20 | 2026-06-16 | 430 | 0d |  | VALGO |
| 432 | 3.1.5.3 | Mesures restitutions et déconfinements - R+1 |  | 5d | 2026-06-03 | 2026-06-09 | 431SS+10d | 0d |  | VALGO |
| 433 | 3.1.5.4 | Mesures restitutions et déconfinements - RDC |  | 5d | 2026-06-17 | 2026-06-23 | 431 | 252d | 0d | VALGO |
| 434 | 3.1.6 | **R+1 - GO** |  | 35d | 2026-06-09 | 2026-07-28 |  | 0d |  |  |
| 435 | 3.1.6.1 | Mise à dispo R+1 et accès R+1 au GO | milestone | 0d | 2026-06-09 | 2026-06-09 | 432 | 0d |  | VALGO |
| 436 | 3.1.6.2 | Curage |  | 5d | 2026-06-10 | 2026-06-16 | 435 | 0d |  |  |
| 437 | 3.1.6.3 | Dépose des cabines de douche |  | 2d | 2026-06-10 | 2026-06-11 | 435 | 265d |  | ALM |
| 438 | 3.1.6.4 | Reprises maçonneries (ouv, bouch, résa, renfo) |  | 30d | 2026-06-17 | 2026-07-28 | 436 | 0d |  | ALM |
| 439 | 3.1.7 | **RDC - GO** |  | 32d | 2026-06-23 | 2026-08-06 |  | 225d |  |  |
| 440 | 3.1.7.1 | Mise à dispo RDC au GO | milestone | 0d | 2026-06-23 | 2026-06-23 | 433 | 252d | 0d | VALGO |
| 441 | 3.1.7.2 | Curage |  | 5d | 2026-06-24 | 2026-06-30 | 440 | 252d |  |  |
| 442 | 3.1.7.3 | Reprises maçonneries (ouv, bouch, résa, renfo) |  | 17d | 2026-07-15 | 2026-08-06 | 438FS-10d | 225d |  | ALM |
| 443 | 3.1.8 | **2nd oeuvre, lots techniques** |  | 82d | 2026-07-21 | 2026-11-11 |  | 0d |  |  |
| 444 | 3.1.8.1 | Pose Men EXT |  | 15d | 2026-07-22 | 2026-08-11 | 438FS-5d | 0d |  | GEAY MEN |
| 445 | 3.1.8.2 | HO/HA R+1 | milestone | 0d | 2026-08-04 | 2026-08-04 | 444SS+10d | 0d |  |  |
| 446 | 3.1.8.3 | HO/HA RDC | milestone | 0d | 2026-08-11 | 2026-08-11 | 444 | 222d |  |  |
| 447 | 3.1.8.4 | Création chappe |  | 6d | 2026-08-05 | 2026-08-12 | 445 | 0d |  | EIFFAGE/LPP |
| 448 | 3.1.8.5 | Distribution réseaux élec (Cfo/Cfa - Nord) |  | 35d | 2026-07-21 | 2026-09-11 | 447SS-11d | 199d |  | FAUCHE |
| 449 | 3.1.8.6 | Distribution réseaux CVC/Plb (Nord) |  | 35d | 2026-07-21 | 2026-09-11 | 447SS-11d | 0d |  | EIFFAGE |
| 450 | 3.1.8.7 | Bon à fermer cloison (cis renforts) - R+1 | milestone | 0d | 2026-08-18 | 2026-08-18 | 449SS+21d | 0d |  |  |
| 451 | 3.1.8.8 | Bon à fermer faux plafond - R+1 | milestone | 0d | 2026-08-25 | 2026-08-25 | 450SS+5d | 0d |  |  |
| 452 | 3.1.8.9 | Bon à fermer cloison (cis renforts) - RDC | milestone | 0d | 2026-09-01 | 2026-09-01 | 451SS+5d | 0d |  |  |
| 453 | 3.1.8.10 | Bon à fermer faux plafond - RDC | milestone | 0d | 2026-09-11 | 2026-09-11 | 449 | 19d | 14d |  |

| ID | WBS | Task | Duration | Start | Finish | Predecessors | Total slack | Free slack | Text1 |
| --- | --- | --- | --- | --- | --- | --- | --- | --- | --- |
| 454 | 3.1.8.11 | **R+1 - 2nd œuvres, aménagements, finitions** | 53d | 2026-08-13 | 2026-10-26 |  | 4d |  |  |
| 455 | 3.1.8.11.1 | Doublage, cloisons - R+1 & verticalité GT RDC/R+1 | 10d | 2026-08-13 | 2026-08-26 | 447 | 4d | 0d | GOURAUD |
| 456 | 3.1.8.11.2 | Livraison + pose Men INT | 3d | 2026-08-13 | 2026-08-17 | 455SS | 218d |  | FGV |
| 457 | 3.1.8.11.3 | 2nd peau - R+1 | 5d | 2026-08-27 | 2026-09-02 | 450, 455 | 12d | 0d | GOURAUD |
| 458 | 3.1.8.11.4 | Pose TD et raccordement | 5d | 2026-09-03 | 2026-09-09 | 457 | 201d |  | FAUCHE |
| 459 | 3.1.8.11.5 | Prépa peinture + 1ère couche | 7d | 2026-09-03 | 2026-09-11 | 457 | 192d | 0d | LPP |
| 460 | 3.1.8.11.6 | Structure faux plafond | 7d | 2026-09-14 | 2026-09-22 | 459, 451SS-2d | 192d | 0d | GOURAUD |
| 461 | 3.1.8.11.7 | Pose terminaux (Cfo,Cfa, CVC) | 5d | 2026-09-16 | 2026-09-22 | 460FF | 192d |  | EIFFAGE/FAUCHE |
| 462 | 3.1.8.11.8 | Revêtement mural | 7d | 2026-09-17 | 2026-09-25 | 476 | 12d | 0d | LPP |
| 463 | 3.1.8.11.9 | **Revêtement sol** | 8d | 2026-09-22 | 2026-10-01 | 462SS+3d | 185d |  | LPP |
| 464 | 3.1.8.11.9.1 | Préparation des supports | 2d | 2026-09-22 | 2026-09-23 |  | 185d | 0d |  |
| 465 | 3.1.8.11.9.2 | Séchage | 1d | 2026-09-24 | 2026-09-24 | 464 | 185d | 0d |  |
| 466 | 3.1.8.11.9.3 | Pose du revêtement avec remontée en plinthes | 3d | 2026-09-25 | 2026-09-29 | 465 | 185d | 0d |  |
| 467 | 3.1.8.11.9.4 | Soudure | 2d | 2026-09-30 | 2026-10-01 | 466 | 185d |  |  |
| 468 | 3.1.8.11.10 | Finitions peintures | 7d | 2026-09-25 | 2026-10-05 | 462FS-1d | 12d | 0d | LPP |
| 469 | 3.1.8.11.11 | **Pose mobilier** | 28d | 2026-08-27 | 2026-10-05 |  | 12d | 0d | FGV |
| 470 | 3.1.8.11.11.1 | Ajustages de portes, cimaises & main courantes | 4d | 2026-08-27 | 2026-09-01 | 455 | 36d |  |  |
| 471 | 3.1.8.11.11.2 | Équipement portes décochoc, béquilles, mobiliers | 2d | 2026-10-02 | 2026-10-05 | 468FF | 12d |  |  |
| 472 | 3.1.8.11.12 | Pose afficheurs, enjoliveurs élec/CVC | 3d | 2026-10-06 | 2026-10-08 | 468 | 180d |  | EIFFAGE/FAUCHE |
| 473 | 3.1.8.11.13 | Blanchiment | 2d | 2026-10-02 | 2026-10-05 | 469FF | 12d | 0d | GOURAUD |
| 474 | 3.1.8.11.14 | **Salles de bain/sanitaires** | 16d | 2026-09-03 | 2026-09-24 |  | 12d |  |  |
| 475 | 3.1.8.11.14.1 | Pose structure faux plafond | 3d | 2026-09-03 | 2026-09-07 | 457 | 12d | 0d | GOURAUD |
| 476 | 3.1.8.11.14.2 | Revêtement mural | 7d | 2026-09-08 | 2026-09-16 | 475 | 12d | 0d | LPP |
| 477 | 3.1.8.11.14.3 | Revêtement sol | 7d | 2026-09-11 | 2026-09-21 | 476SS+3d | 190d | 0d | LPP |
| 478 | 3.1.8.11.14.4 | Pose appareillages sanitaires | 5d | 2026-09-18 | 2026-09-24 | 477FS-2d | 190d |  | EIFFAGE |
| 479 | 3.1.8.11.14.5 | Pose mobilier/équip sanitaires | 3d | 2026-09-22 | 2026-09-24 | 477 | 190d |  |  |
| 480 | 3.1.8.11.15 | OPR R+1 | 10d | 2026-10-06 | 2026-10-19 | 473 | 12d | 0d |  |
| 481 | 3.1.8.11.16 | Levées de réserves | 10d | 2026-10-13 | 2026-10-26 | 480FS-5d | 12d |  |  |

| ID | WBS | Task | Type | Duration | Start | Finish | Predecessors | Total slack | Free slack | Text1 |
| --- | --- | --- | --- | --- | --- | --- | --- | --- | --- | --- |
| 482 | 3.1.8.12 | **RDC - 2nd œuvres, aménagements, finitions** |  | 39d | 2026-09-02 | 2026-10-26 |  | 0d |  |  |
| 483 | 3.1.8.12.1 | Doublage, cloisons - RDC |  | 10d | 2026-09-02 | 2026-09-15 | 455, 452 | 0d |  | GOURAUD |
| 484 | 3.1.8.12.2 | Livraison + pose Men INT |  | 3d | 2026-09-02 | 2026-09-04 | 483SS | 204d |  | FGV |
| 485 | 3.1.8.12.3 | 2nd peau - RDC |  | 5d | 2026-09-16 | 2026-09-22 | 452, 483 | 0d |  | GOURAUD |
| 486 | 3.1.8.12.4 | Pose TD et raccordement |  | 5d | 2026-09-23 | 2026-09-29 | 485 | 187d |  | FAUCHE |
| 487 | 3.1.8.12.5 | Prépa peinture + 1ère couche |  | 5d | 2026-09-23 | 2026-09-29 | 485 | 0d |  | LPP |
| 488 | 3.1.8.12.6 | Structure faux plafond |  | 7d | 2026-09-30 | 2026-10-08 | 487, 453SS-2d | 0d |  | GOURAUD |
| 489 | 3.1.8.12.7 | Revêtement mural |  | 5d | 2026-10-07 | 2026-10-13 | 488FS-2d | 0d |  | LPP |
| 490 | 3.1.8.12.8 | Pose terminaux (Cfo,Cfa, CVC) |  | 5d | 2026-10-14 | 2026-10-20 | 489 | 172d |  | EIFFAGE/FAUCHE |
| 491 | 3.1.8.12.9 | Revêtement sol |  | 5d | 2026-10-12 | 2026-10-16 | 489SS+3d | 0d |  | LPP |
| 492 | 3.1.8.12.10 | Finitions peintures |  | 5d | 2026-10-15 | 2026-10-21 | 491FS-2d | 0d |  | LPP |
| 493 | 3.1.8.12.11 | **Pose mobilier** |  | 26d | 2026-09-16 | 2026-10-21 |  | 0d |  | FGV |
| 494 | 3.1.8.12.11.1 | Ajustages de portes, cimaises & main courantes |  | 3d | 2026-09-16 | 2026-09-18 | 483 | 23d |  |  |
| 495 | 3.1.8.12.11.2 | Équipement portes décochoc, béquilles, mobiliers |  | 2d | 2026-10-20 | 2026-10-21 | 492FF | 0d |  |  |
| 496 | 3.1.8.12.12 | Pose afficheurs, enjoliveurs élec/CVC |  | 3d | 2026-10-22 | 2026-10-26 | 492 | 168d |  | EIFFAGE/FAUCHE |
| 497 | 3.1.8.12.13 | Blanchiment |  | 2d | 2026-10-20 | 2026-10-21 | 493FF | 0d |  | GOURAUD |
| 498 | 3.1.8.13 | OPR RDC |  | 10d | 2026-10-22 | 2026-11-04 | 497 | 0d |  |  |
| 499 | 3.1.8.14 | Levées de réserves |  | 10d | 2026-10-29 | 2026-11-11 | 498FS-5d | 0d |  |  |
| 500 | 3.1.8.15 | Réception | milestone | 0d | 2026-11-11 | 2026-11-11 | 499, 481 | 0d |  |  |
| 501 | 3.2 | **Bâtiment A** |  | 123d | 2026-05-20 | 2026-11-06 |  | 159d |  |  |
| 502 | 3.2.1 | Déménagement bâtiment A |  | 5d | 2026-05-20 | 2026-05-26 | 431SS | 180d | 0d | MOA |
| 503 | 3.2.2 | Isolement de la zone |  | 1d | 2026-05-26 | 2026-05-26 | 502FF | 180d | 0d |  |
| 504 | 3.2.3 | Consignation, dévoiement des réseaux |  | 3d | 2026-05-26 | 2026-05-28 | 503SS | 180d | 0d | EIFFAGE/FAUCHE |
| 505 | 3.2.4 | Pré-curage |  | 8d | 2026-05-26 | 2026-06-04 | 504SS | 180d | 0d |  |

| ID | WBS | Task | Type | Duration | Start | Finish | Predecessors | Total slack | Free slack | Text1 |
| --- | --- | --- | --- | --- | --- | --- | --- | --- | --- | --- |
| 506 | 3.2.5 | **Désamiantage (RDC, R+1)** |  | 40d | 2026-06-02 | 2026-07-27 | 502 | 180d |  |  |
| 507 | 3.2.5.1 | confinement |  | 5d | 2026-06-02 | 2026-06-08 | 505FS-3d | 180d | 0d | VALGO |
| 508 | 3.2.5.2 | désamiantage |  | 30d | 2026-06-09 | 2026-07-20 | 507 | 180d | 0d | VALGO |
| 509 | 3.2.5.3 | Mesures restitut° et déconfinemts R+1 + escalier |  | 5d | 2026-06-23 | 2026-06-29 | 508SS+10d | 180d | 0d | VALGO |
| 510 | 3.2.5.4 | Mesures restitut° et déconfinemts RDC |  | 5d | 2026-07-21 | 2026-07-27 | 508 | 196d | 0d | VALGO |
| 511 | 3.2.6 | **R+1 - GO** |  | 22d | 2026-06-29 | 2026-07-29 |  | 180d |  |  |
| 512 | 3.2.6.1 | Mise à dispo R+1 et accès escalier R+1 au GO | milestone | 0d | 2026-06-29 | 2026-06-29 | 509 | 180d | 0d | VALGO |
| 513 | 3.2.6.2 | Curage |  | 5d | 2026-06-30 | 2026-07-06 | 512 | 180d | 0d |  |
| 514 | 3.2.6.3 | Reprises maçonneries (ouv, bouch, résa, renfo) |  | 17d | 2026-07-07 | 2026-07-29 | 513 | 180d | 0d | ALM |
| 515 | 3.2.7 | **RDC - GO** |  | 104d | 2026-05-21 | 2026-10-13 |  | 177d |  |  |
| 516 | 3.2.7.1 | Mise à dispo RDC au GO | milestone | 0d | 2026-07-27 | 2026-07-27 | 510 | 196d | 0d | VALGO |
| 517 | 3.2.7.2 | Curage |  | 5d | 2026-07-28 | 2026-08-03 | 516 | 196d | 0d |  |
| 518 | 3.2.7.3 | Reprises maçonneries (ouv, bouch, résa, renfo) |  | 17d | 2026-08-04 | 2026-08-26 | 517 | 196d | 0d | ALM |
| 519 | 3.2.7.4 | Mise à dispo supports ascensoriste | milestone | 0d | 2026-08-20 | 2026-08-20 | 518FS-5d | 196d | 0d |  |
| 520 | 3.2.7.5 | **Ascenseur** |  | 104d | 2026-05-21 | 2026-10-13 |  | 177d |  |  |
| 521 | 3.2.7.5.1 | Dépose de l'ascenseur existant |  | 5d | 2026-08-13 | 2026-08-20 | 519SF | 216d |  | AMS |
| 522 | 3.2.7.5.2 | Fab + Appro ascenseur |  | 70d | 2026-05-21 | 2026-08-27 | 523SF | 211d |  | AMS |
| 523 | 3.2.7.5.3 | Livraison + pose équipement ascenseur |  | 15d | 2026-08-27 | 2026-09-16 | 519FS+5d | 196d | 0d | AMS |
| 524 | 3.2.7.5.4 | Livraison + pose habillage ascenseur |  | 5d | 2026-09-30 | 2026-10-06 | 546 | 177d | 0d | AMS |
| 525 | 3.2.7.5.5 | Essaie et réglage / Mise en service |  | 5d | 2026-10-07 | 2026-10-13 | 524 | 177d |  | AMS |
| 526 | 3.2.8 | **2nd oeuvres, lots technique** |  | 74d | 2026-07-28 | 2026-11-06 |  | 159d |  |  |
| 527 | 3.2.8.1 | Pose Men EXT |  | 15d | 2026-07-28 | 2026-08-17 | 514FS-2d | 180d | 0d | GEAY MEN |
| 528 | 3.2.8.2 | HO/HA R+1 | milestone | 0d | 2026-08-10 | 2026-08-10 | 527SS+10d | 180d | 0d |  |
| 529 | 3.2.8.3 | HO/HA RDC | milestone | 0d | 2026-08-17 | 2026-08-17 | 527 | 218d |  |  |
| 530 | 3.2.8.4 | Création chappe |  | 7d | 2026-08-11 | 2026-08-19 | 528 | 180d | 0d | EIFFAGE/LPP |
| 531 | 3.2.8.5 | Distribution réseaux élec (Cfo/Cfa - Nord) |  | 35d | 2026-07-28 | 2026-09-17 | 530SS-10d | 195d |  | FAUCHE |
| 532 | 3.2.8.6 | Distribution réseaux CVC/Plb (Nord) |  | 35d | 2026-07-28 | 2026-09-17 | 530SS-10d | 159d | 0d | EIFFAGE |
| 533 | 3.2.8.7 | Bon à fermer cloison (cis renforts) - R+1 | milestone | 0d | 2026-08-20 | 2026-08-20 | 532SS+18d | 159d | 0d |  |
| 534 | 3.2.8.8 | Bon à fermer faux plafond - R+1 | milestone | 0d | 2026-08-27 | 2026-08-27 | 533SS+5d | 166d | 0d |  |
| 535 | 3.2.8.9 | Bon à fermer cloison (cis renforts) - RDC | milestone | 0d | 2026-09-10 | 2026-09-10 | 533SS+15d | 164d | 0d |  |
| 536 | 3.2.8.10 | Bon à fermer faux plafond - RDC | milestone | 0d | 2026-09-17 | 2026-09-17 | 535SS+5d | 188d | 5d |  |

| ID | WBS | Task | Duration | Start | Finish | Predecessors | Total slack | Free slack | Text1 |
| --- | --- | --- | --- | --- | --- | --- | --- | --- | --- |
| 537 | 3.2.8.11 | **R+1 - 2nd œuvres, aménagements, finitions** | 34d | 2026-08-21 | 2026-10-07 |  | 159d |  |  |
| 538 | 3.2.8.11.1 | Doublage, cloisons - R+1 & verticalité GT RDC/R+1 | 10d | 2026-08-21 | 2026-09-03 | 533 | 159d | 0d | GOURAUD |
| 539 | 3.2.8.11.2 | Livraison + pose Men INT | 3d | 2026-08-21 | 2026-08-25 | 538SS | 212d |  | FGV |
| 540 | 3.2.8.11.3 | 2nd peau - R+1 | 5d | 2026-09-03 | 2026-09-09 | 538FS-1d | 186d | 0d | GOURAUD |
| 541 | 3.2.8.11.4 | Pose TD + raccordement | 5d | 2026-09-03 | 2026-09-09 | 540SS | 201d |  | FAUCHE |
| 542 | 3.2.8.11.5 | Prépa peinture + 1ère couche | 5d | 2026-09-10 | 2026-09-16 | 540 | 186d | 0d | LPP |
| 543 | 3.2.8.11.6 | Structure faux plafond | 7d | 2026-08-28 | 2026-09-07 | 534 | 166d | 0d | GOURAUD |
| 544 | 3.2.8.11.7 | Pose terminaux (Cfo,Cfa, CVC) | 10d | 2026-09-17 | 2026-09-30 | 542 | 186d |  | EIFFAGE/FAUCHE |
| 545 | 3.2.8.11.8 | Revêtement mural | 7d | 2026-09-17 | 2026-09-25 | 555 | 166d | 0d | LPP |
| 546 | 3.2.8.11.9 | Revêtement sol | 7d | 2026-09-21 | 2026-09-29 | 556 | 177d | 0d | LPP |
| 547 | 3.2.8.11.10 | Finitions peintures | 7d | 2026-09-24 | 2026-10-02 | 545SS+5d | 166d | 0d | LPP |
| 548 | 3.2.8.11.11 | **Pose mobilier** | 21d | 2026-09-04 | 2026-10-02 |  | 184d |  | FGV |
| 549 | 3.2.8.11.11.1 | Ajustages de portes, cimaises & main courantes | 3d | 2026-09-04 | 2026-09-08 | 538 | 202d |  |  |
| 550 | 3.2.8.11.11.2 | Équipement portes décochoc, béquilles, mobiliers | 2d | 2026-10-01 | 2026-10-02 | 547FF | 184d |  |  |
| 551 | 3.2.8.11.12 | Pose afficheurs, enjoliveurs élec/CVC | 3d | 2026-10-05 | 2026-10-07 | 547 | 166d | 0d | EIFFAGE/FAUCHE |
| 552 | 3.2.8.11.13 | Blanchiment | 2d | 2026-10-01 | 2026-10-02 | 547FF | 184d |  | GOURAUD |
| 553 | 3.2.8.11.14 | **Salles de bain/sanitaires** | 15d | 2026-09-08 | 2026-09-28 |  | 166d |  |  |
| 554 | 3.2.8.11.14.1 | Pose structure faux plafond | 3d | 2026-09-08 | 2026-09-10 | 543 | 166d | 0d | GOURAUD |
| 555 | 3.2.8.11.14.2 | Revêtement mural | 5d | 2026-09-10 | 2026-09-16 | 554SS+2d | 166d | 0d | LPP |
| 556 | 3.2.8.11.14.3 | Revêtement sol | 5d | 2026-09-14 | 2026-09-18 | 555FS-3d | 177d | 0d | LPP |
| 557 | 3.2.8.11.14.4 | Pose appareillages sanitaires | 8d | 2026-09-17 | 2026-09-28 | 556FS-2d | 188d |  | EIFFAGE |
| 558 | 3.2.8.11.14.5 | Pose mobilier/équip sanitaires | 3d | 2026-09-21 | 2026-09-23 | 556 | 191d |  |  |
| 559 | 3.2.8.12 | OPR R+1 | 10d | 2026-10-08 | 2026-10-21 | 551 | 166d | 0d |  |
| 560 | 3.2.8.13 | Levées de réserves | 10d | 2026-10-15 | 2026-10-28 | 559FS-5d | 166d | 7d |  |

| ID | WBS | Task | Type | Duration | Start | Finish | Predecessors | Total slack | Free slack | Text1 |
| --- | --- | --- | --- | --- | --- | --- | --- | --- | --- | --- |
| 561 | 3.2.8.14 | **RDC - 2nd œuvres, aménagements, finitions** |  | 41d | 2026-09-04 | 2026-10-30 |  | 159d |  |  |
| 562 | 3.2.8.14.1 | Doublage, cloisons - RDC |  | 10d | 2026-09-04 | 2026-09-17 | 538 | 159d | 0d | GOURAUD |
| 563 | 3.2.8.14.2 | Livraison + pose Men INT |  | 3d | 2026-09-04 | 2026-09-08 | 562SS | 202d |  | FGV |
| 564 | 3.2.8.14.3 | 2nd peau - RDC |  | 5d | 2026-09-18 | 2026-09-24 | 535, 562 | 159d | 0d | GOURAUD |
| 565 | 3.2.8.14.4 | Pose TD & raccordement |  | 5d | 2026-09-18 | 2026-09-24 | 564SS | 190d |  | FAUCHE |
| 566 | 3.2.8.14.5 | Prépa peinture + 1ère couche |  | 5d | 2026-09-25 | 2026-10-01 | 564 | 159d | 0d | LPP |
| 567 | 3.2.8.14.6 | Structure faux plafond |  | 7d | 2026-09-25 | 2026-10-05 | 536, 564 | 183d |  | GOURAUD |
| 568 | 3.2.8.14.7 | Pose terminaux (Cfo,Cfa, CVC) |  | 10d | 2026-10-02 | 2026-10-15 | 566 | 175d |  | EIFFAGE/FAUCHE |
| 569 | 3.2.8.14.8 | Revêtement mural |  | 6d | 2026-10-02 | 2026-10-09 | 566 | 159d | 0d | LPP |
| 570 | 3.2.8.14.9 | Revêtement sol |  | 7d | 2026-10-09 | 2026-10-19 | 569FS-1d | 159d | 0d | LPP |
| 571 | 3.2.8.14.10 | Finitions peintures |  | 7d | 2026-10-19 | 2026-10-27 | 570FS-1d | 159d | 0d | LPP |
| 572 | 3.2.8.14.11 | **Pose mobilier** |  | 28d | 2026-09-18 | 2026-10-27 |  | 167d |  | FGV |
| 573 | 3.2.8.14.11.1 | Ajustages de portes, cimaises & main courantes |  | 3d | 2026-09-18 | 2026-09-22 | 562 | 192d |  |  |
| 574 | 3.2.8.14.11.2 | Équipement portes décochoc, béquilles, mobiliers |  | 2d | 2026-10-26 | 2026-10-27 | 571FF | 167d |  |  |
| 575 | 3.2.8.14.12 | Pose afficheurs, enjoliveurs élec/CVC |  | 3d | 2026-10-28 | 2026-10-30 | 571 | 159d | 0d | EIFFAGE/FAUCHE |
| 576 | 3.2.8.14.13 | Blanchiment |  | 2d | 2026-10-26 | 2026-10-27 | 571FF | 167d |  | GOURAUD |
| 577 | 3.2.8.14.14 | **Salles de bain/sanitaires** |  | 16d | 2026-09-25 | 2026-10-16 |  | 174d |  |  |
| 578 | 3.2.8.14.14.1 | Pose structure faux plafond |  | 3d | 2026-09-25 | 2026-09-29 | 564 | 174d | 0d | GOURAUD |
| 579 | 3.2.8.14.14.2 | Revêtement mural |  | 5d | 2026-09-30 | 2026-10-06 | 578 | 174d | 0d | LPP |
| 580 | 3.2.8.14.14.3 | Revêtement sol |  | 5d | 2026-10-02 | 2026-10-08 | 579FS-3d | 174d | 0d | LPP |
| 581 | 3.2.8.14.14.4 | Pose appareillages sanitaires |  | 8d | 2026-10-07 | 2026-10-16 | 580FS-2d | 174d |  | EIFFAGE |
| 582 | 3.2.8.14.14.5 | Pose mobilier/équip sanitaires |  | 3d | 2026-10-09 | 2026-10-13 | 580 | 177d |  |  |
| 583 | 3.2.8.15 | OPR RDC |  | 10d | 2026-10-19 | 2026-10-30 | 575FF | 159d | 0d |  |
| 584 | 3.2.8.16 | Levées de réserves |  | 10d | 2026-10-26 | 2026-11-06 | 583FS-5d | 159d | 0d |  |
| 585 | 3.2.8.17 | Réception et mise à disposition | milestone | 0d | 2026-11-06 | 2026-11-06 | 584, 560 | 159d |  |  |
| 586 | 3.3 | Réception général phase 03 |  | 3d | 2026-11-12 | 2026-11-16 | 500 | 0d |  |  |
| 587 | 3.4 | Commission de sécurité Bâtiment A & B | milestone | 0d | 2026-11-16 | 2026-11-16 | 586 | 153d |  |  |

| ID | WBS | Task | Type | Duration | Start | Finish | Predecessors | Total slack | Free slack | Text1 |
| --- | --- | --- | --- | --- | --- | --- | --- | --- | --- | --- |
| 588 | 4 | **Phase 4** |  | 156d | 2026-11-12 | 2027-06-17 |  | 0d |  |  |
| 589 | 4.1 | **Bâtiment C** |  | 156d | 2026-11-12 | 2027-06-17 |  | 0d |  |  |
| 590 | 4.1.1 | Déménagement |  | 5d | 2026-11-12 | 2026-11-18 | 586SS | 0d |  | MOA |
| 591 | 4.1.2 | **RDC & R+1 NORD Bât C** |  | 84d | 2026-11-19 | 2027-03-16 |  | 0d |  |  |
| 592 | 4.1.2.1 | Isolement de la zone |  | 3d | 2026-11-19 | 2026-11-23 | 590 | 148d |  |  |
| 593 | 4.1.2.2 | Pré-curage |  | 7d | 2026-11-19 | 2026-11-27 | 590 | 0d |  |  |
| 594 | 4.1.2.3 | Consignation/dévoiements rsx |  | 2d | 2026-11-19 | 2026-11-20 | 593SS | 149d |  | EIFFAGE/FAUCHE |
| 595 | 4.1.2.4 | **Désamiantage** |  | 9d | 2026-11-30 | 2026-12-10 |  | 0d |  |  |
| 596 | 4.1.2.4.1 | Confinement |  | 2d | 2026-11-30 | 2026-12-01 | 593 | 0d |  | VALGO |
| 597 | 4.1.2.4.2 | Désamiantage |  | 3d | 2026-12-02 | 2026-12-04 | 596 | 0d |  | VALGO |
| 598 | 4.1.2.4.3 | Mesures et restitutions |  | 3d | 2026-12-07 | 2026-12-09 | 597 | 0d |  | VALGO |
| 599 | 4.1.2.4.4 | déconfinement |  | 1d | 2026-12-10 | 2026-12-10 | 598 | 0d |  | VALGO |
| 600 | 4.1.2.5 | Curage |  | 6d | 2026-12-11 | 2026-12-18 | 599 | 0d |  |  |
| 601 | 4.1.2.6 | Reprises maçonneries (ouv, bouch, résa, renfo) |  | 16d | 2026-12-15 | 2027-01-05 | 600SS+2d | 0d |  | ALM |
| 602 | 4.1.2.7 | Pose Men EXT (Nord) |  | 10d | 2026-12-21 | 2027-01-01 | 600 | 119d |  | GEAY MEN |
| 603 | 4.1.2.8 | Création chappe |  | 4d | 2027-01-04 | 2027-01-07 | 601FS-2d | 0d |  | LPP |
| 604 | 4.1.2.9 | Distrib rsx élec (Cfo/Cfa - Nord) + accom cloison |  | 20d | 2026-12-28 | 2027-02-01 | 603SS-5d | 0d |  | FAUCHE |
| 605 | 4.1.2.10 | Distrib rsx CVC/Plb (Nord) + accomp cloison |  | 20d | 2026-12-28 | 2027-02-01 | 603SS-5d | 86d | 0d | EIFFAGE |
| 606 | 4.1.2.11 | Bon à fermer cloison (cis renforts) | milestone | 0d | 2027-01-19 | 2027-01-19 | 605FS-10d | 86d | 0d |  |
| 607 | 4.1.2.12 | Bon à fermer faux plafond | milestone | 0d | 2027-02-01 | 2027-02-01 | 604 | 0d |  |  |
| 608 | 4.1.2.13 | Doublage, cloisons |  | 10d | 2027-01-19 | 2027-02-01 | 606SS | 86d | 0d | GOURAUD |
| 609 | 4.1.2.14 | Livraison + pose Men INT |  | 3d | 2027-01-19 | 2027-01-21 | 608SS | 105d |  | FGV |
| 610 | 4.1.2.15 | Prépa peinture + 1ère couche |  | 5d | 2027-02-02 | 2027-02-08 | 608 | 93d |  | LPP |
| 611 | 4.1.2.16 | Pose structure faux plafond |  | 4d | 2027-02-02 | 2027-02-05 | 607 | 0d |  | GOURAUD |
| 612 | 4.1.2.17 | Pose terminaux (Cfo,Cfa, CVC) |  | 6d | 2027-02-04 | 2027-02-11 | 611FS-2d | 90d |  | EIFFAGE/FAUCHE |
| 613 | 4.1.2.18 | Revêtement mural |  | 5d | 2027-02-08 | 2027-02-12 | 611 | 0d |  | LPP |
| 614 | 4.1.2.19 | Revêtement sol |  | 7d | 2027-02-15 | 2027-02-23 | 613 | 0d |  | LPP |

| ID | WBS | Task | Type | Duration | Start | Finish | Predecessors | Total slack | Free slack | Text1 |
| --- | --- | --- | --- | --- | --- | --- | --- | --- | --- | --- |
| 615 | 4.1.2.20 | **Pose mobilier** |  | 20d | 2027-02-02 | 2027-03-01 |  | 78d |  | FGV |
| 616 | 4.1.2.20.1 | Ajustages de portes, cimaises & main courantes |  | 10d | 2027-02-02 | 2027-02-15 | 608 | 87d | 0d |  |
| 617 | 4.1.2.20.2 | Équipement portes décochoc, béquilles, mobiliers |  | 8d | 2027-02-18 | 2027-03-01 | 618SS+3d | 78d |  |  |
| 618 | 4.1.2.21 | Finitions peintures |  | 7d | 2027-02-15 | 2027-02-23 | 613 | 78d | 0d | LPP |
| 619 | 4.1.2.22 | Pose afficheurs, enjoliveurs élec/CVC |  | 1d | 2027-02-24 | 2027-02-24 | 618 | 81d |  | EIFFAGE/FAUCHE |
| 620 | 4.1.2.23 | Blanchiment |  | 1d | 2027-02-16 | 2027-02-16 | 616 | 87d |  | GOURAUD |
| 621 | 4.1.2.24 | **Salles de bain/sanitaires** |  | 12d | 2027-02-02 | 2027-02-17 |  | 86d |  |  |
| 622 | 4.1.2.24.1 | Pose structure faux plafond |  | 2d | 2027-02-02 | 2027-02-03 | 608 | 86d | 0d | GOURAUD |
| 623 | 4.1.2.24.2 | Revêtement mural |  | 2d | 2027-02-04 | 2027-02-05 | 622 | 86d | 0d | LPP |
| 624 | 4.1.2.24.3 | Revêtement sol |  | 3d | 2027-02-08 | 2027-02-10 | 623 | 86d | 0d | LPP |
| 625 | 4.1.2.24.4 | Pose appareillages sanitaires |  | 4d | 2027-02-11 | 2027-02-16 | 624 | 86d | 0d | EIFFAGE |
| 626 | 4.1.2.24.5 | Pose mobilier/équip sanitaires |  | 1d | 2027-02-17 | 2027-02-17 | 625 | 86d |  |  |
| 627 | 4.1.2.25 | OPR - NORD BAT C |  | 10d | 2027-02-24 | 2027-03-09 | 614 | 0d |  |  |
| 628 | 4.1.2.26 | Levées de réserves |  | 10d | 2027-03-03 | 2027-03-16 | 627SS+5d | 0d |  |  |
| 629 | 4.1.2.27 | Réception et mise à disposition - NORD BAT C | milestone | 0d | 2027-03-16 | 2027-03-16 | 628 | 0d |  |  |
| 630 | 4.1.3 | **RDC & R+1 SUD Bât C** |  | 117d | 2027-01-06 | 2027-06-17 |  | 0d |  |  |
| 631 | 4.1.3.1 | Isolement de la zone |  | 1d | 2027-03-17 | 2027-03-17 | 629 | 0d |  |  |
| 632 | 4.1.3.2 | Consignation/dévoiements rsx |  | 2d | 2027-03-17 | 2027-03-18 | 631SS | 0d |  | EIFFAGE/FAUCHE |
| 633 | 4.1.3.3 | Curage |  | 6d | 2027-03-17 | 2027-03-24 | 631SS | 56d | 0d |  |
| 634 | 4.1.3.4 | Dépose cabine de douche |  | 5d | 2027-03-19 | 2027-03-25 | 632 | 0d |  | ALM |
| 635 | 4.1.3.5 | Reprises maçonneries (ouv, bouch, résa, renfo) |  | 11d | 2027-03-26 | 2027-04-09 | 634 | 0d |  | ALM |
| 636 | 4.1.3.6 | Mise à dispo supports ascensoriste | milestone | 0d | 2027-04-07 | 2027-04-07 | 635FS-3d | 32d | 0d |  |
| 637 | 4.1.3.7 | **Ascenseur** |  | 108d | 2027-01-06 | 2027-06-04 |  | 9d |  |  |
| 638 | 4.1.3.7.1 | Dépose de l'ascenseur existant |  | 5d | 2027-03-31 | 2027-04-07 | 636SF | 52d |  | AMS |
| 639 | 4.1.3.7.2 | Fab + Appro ascenseur |  | 70d | 2027-01-06 | 2027-04-14 | 640SF | 47d |  | AMS |
| 640 | 4.1.3.7.3 | Livraison + pose équipement ascenseur |  | 15d | 2027-04-14 | 2027-05-04 | 636FS+5d | 32d | 0d | AMS |
| 641 | 4.1.3.7.4 | Livraison + pose habillage ascenseur |  | 5d | 2027-05-24 | 2027-05-28 | 656 | 9d | 0d | AMS |
| 642 | 4.1.3.7.5 | Essaie et réglage / Mise en service |  | 5d | 2027-05-31 | 2027-06-04 | 641 | 9d |  | AMS |
| 643 | 4.1.3.8 | Pose Men EXT (Sud) |  | 5d | 2027-03-25 | 2027-03-31 | 633 | 56d |  | GEAY MEN |
| 644 | 4.1.3.9 | Création chappe |  | 4d | 2027-04-12 | 2027-04-15 | 635 | 0d |  | LPP |
| 645 | 4.1.3.10 | Intervention au RDC pour travail dans les plénums |  | 2d | 2027-04-13 | 2027-04-14 | 647SS+4d | 45d | 0d | GEAY |
| 646 | 4.1.3.11 | Blanchiment |  | 1d | 2027-04-15 | 2027-04-15 | 645 | 45d |  | GOURAUD |
| 647 | 4.1.3.12 | Distrib rsx élec (Cfo/Cfa - Nord) + accom cloison |  | 13d | 2027-04-07 | 2027-04-27 | 644SS-3d | 37d | 0d | FAUCHE |
| 648 | 4.1.3.13 | Distrib rsx CVC/Plb (Nord) + accomp cloison |  | 13d | 2027-04-07 | 2027-04-27 | 644SS-3d | 0d |  | EIFFAGE |
| 649 | 4.1.3.14 | Bon à fermer cloison (cis renforts) | milestone | 0d | 2027-04-21 | 2027-04-21 | 648FS-5d | 0d |  |  |
| 650 | 4.1.3.15 | Doublage, cloisons |  | 5d | 2027-04-21 | 2027-04-27 | 649 | 0d |  | GOURAUD |
| 651 | 4.1.3.16 | Livraison + pose Men INT |  | 1d | 2027-04-21 | 2027-04-21 | 650SS | 41d |  | FGV |
| 652 | 4.1.3.17 | Prépa peinture + 1ère couche |  | 5d | 2027-04-28 | 2027-05-04 | 650 | 0d |  | LPP |
| 653 | 4.1.3.18 | Pose structure faux plafond |  | 4d | 2027-05-05 | 2027-05-10 | 652 | 0d |  | GOURAUD |
| 654 | 4.1.3.19 | Pose terminaux (Cfo,Cfa, CVC) |  | 6d | 2027-05-07 | 2027-05-14 | 653FS-2d | 24d |  | EIFFAGE/FAUCHE |
| 655 | 4.1.3.20 | Revêtement mural |  | 5d | 2027-05-11 | 2027-05-17 | 653 | 0d |  | LPP |
| 656 | 4.1.3.21 | Revêtement sol |  | 5d | 2027-05-17 | 2027-05-21 | 655FS-1d | 0d |  | LPP |

| ID | WBS | Task | Type | Duration | Start | Finish | Predecessors | Total slack | Free slack | Text1 |
| --- | --- | --- | --- | --- | --- | --- | --- | --- | --- | --- |
| 657 | 4.1.3.22 | **Pose mobilier** |  | 25d | 2027-04-28 | 2027-06-01 |  | 12d |  | FGV |
| 658 | 4.1.3.22.1 | Ajustages de portes, cimaises & main courantes |  | 5d | 2027-04-28 | 2027-05-04 | 650 | 32d |  |  |
| 659 | 4.1.3.22.2 | Équipement portes décochoc, béquilles, mobiliers |  | 4d | 2027-05-27 | 2027-06-01 | 660 | 12d |  |  |
| 660 | 4.1.3.23 | Finitions peintures |  | 3d | 2027-05-24 | 2027-05-26 | 656 | 0d |  | LPP |
| 661 | 4.1.3.24 | Pose afficheurs, enjoliveurs élec/CVC |  | 1d | 2027-05-27 | 2027-05-27 | 660 | 15d |  | EIFFAGE/FAUCHE |
| 662 | 4.1.3.25 | Blanchiment |  | 1d | 2027-05-27 | 2027-05-27 | 660 | 0d |  | GOURAUD |
| 663 | 4.1.3.26 | **Salles de bain/sanitaires** |  | 8d | 2027-04-29 | 2027-05-10 |  | 28d |  |  |
| 664 | 4.1.3.26.1 | Pose structure faux plafond |  | 2d | 2027-04-29 | 2027-04-30 | 650FS+1d | 28d | 0d | GOURAUD |
| 665 | 4.1.3.26.2 | Revêtement mural |  | 1d | 2027-05-03 | 2027-05-03 | 664 | 28d | 0d | LPP |
| 666 | 4.1.3.26.3 | Revêtement sol |  | 2d | 2027-05-04 | 2027-05-05 | 665 | 28d | 0d | LPP |
| 667 | 4.1.3.26.4 | Pose appareillages sanitaires |  | 3d | 2027-05-06 | 2027-05-10 | 666 | 28d |  | EIFFAGE |
| 668 | 4.1.3.26.5 | Pose mobilier/équip sanitaires |  | 1d | 2027-05-06 | 2027-05-06 | 666 | 30d |  |  |
| 669 | 4.1.3.27 | OPR SUD BAT C |  | 10d | 2027-05-28 | 2027-06-10 | 662 | 0d |  |  |
| 670 | 4.1.3.28 | Levées de réserves - BAT C |  | 10d | 2027-06-04 | 2027-06-17 | 669SS+5d | 0d |  |  |
| 671 | 4.1.4 | Réception et mise à disposition - SUD BAT C | milestone | 0d | 2027-06-17 | 2027-06-17 | 670 | 0d |  |  |
